# GSTOP_rev 1

How a schedule from MS Project changed from version to version. A marks actual dates.

## Version 1 (data date 2005-03-23, saved 2005-04-08, file GSTOP Project Timeline04082005.mpp)

| ID | WBS | Task | Duration | Start | Finish | Predecessors | Complete | Total float | Constraint |
| --- | --- | --- | --- | --- | --- | --- | --- | --- | --- |
| 1 | 1 | **Initiate the GSTOP Project** | 105d? | 2004-10-20 A | 2005-03-15 A |  | 100% |  |  |
| 2 |  | GSTOP Executive Committee Formed | 6d | 2004-12-01 A | 2004-12-08 A |  | 100% |  | finish no earlier than 2004-12-08 |
| 3 |  | GSTOP Project Manager Identified | 1d | 2004-10-20 A | 2004-10-20 A |  | 100% |  | finish no earlier than 2004-10-20 |
| 4 |  | GSTOP Project Charter Approved | 31d | 2004-10-20 A | 2004-12-01 A |  | 100% |  |  |
| 5 |  | Secure GSTOP Project Funding | 68d | 2004-12-01 A | 2005-03-04 A |  | 100% |  | finish no earlier than 2005-03-04 |
| 6 | 1.5 | **Identify GSTOP Project Team** | 74d? | 2004-12-02 A | 2005-03-15 A |  | 100% |  |  |
| 7 | 1.5.1 | **Form the GSTOP Team** | 74d? | 2004-12-02 A | 2005-03-15 A | 4 | 100% |  |  |
| 8 |  | GSTOP Project Business Lead Identified | 29d | 2004-12-15 A | 2005-01-24 A |  | 100% |  | finish no earlier than 2005-01-24 |
| 9 |  | Define and Assign Project Subteams and Leads | 5d? | 2004-12-02 A | 2004-12-08 A |  | 100% |  |  |
| 10 |  | Develop Project Team Operating Principles & Guidelines | 5d? | 2004-12-02 A | 2004-12-08 A |  | 100% |  |  |
| 11 | 1.5.1.4 | **Develop the GSTOP Project Management Plans** | 74d? | 2004-12-02 A | 2005-03-15 A |  | 100% |  |  |
| 12 |  | Review Charter and resolve any ambiguities/issues | 51d? | 2004-12-02 A | 2005-02-10 A |  | 100% |  |  |
| 13 |  | Develop Intial Project Work Plan | 50d? | 2004-12-02 A | 2005-02-09 A |  | 100% |  |  |
| 14 |  | Develop Intial Project Communication Plan | 72d | 2004-12-06 A | 2005-03-15 A |  | 100% |  | finish no earlier than 2005-03-15 |
| 15 |  | Develop Intial Project Responsibility Matrix | 1d? | 2004-12-02 A | 2004-12-02 A |  | 100% |  |  |
| 16 |  | Develop Intial Project Resource Plan | 31d? | 2004-12-02 A | 2005-01-13 A |  | 100% |  |  |
| 17 | 1.5.1.5 | **Setup the project team's structures for communication** | 42d? | 2004-12-02 A | 2005-01-28 A |  | 100% |  |  |
| 18 |  | Create GSTOP private team workspace | 1d? | 2004-12-02 A | 2004-12-02 A |  | 100% |  |  |
| 19 |  | Develop Project Status Report Template | 42d? | 2004-12-02 A | 2005-01-28 A |  | 100% |  |  |
| 20 | 2 | **GSTOP Requirements** | 142d? | 2004-12-01 A | 2005-06-16 | 1 | 18% | 251d |  |
| 21 | 2.1 | **Incident GIS Standard Symbology** | 142d? | 2004-12-01 A | 2005-06-16 |  | 19% | -54d |  |
| 22 | 2.1.1 | **Establish Symbols Sub-Team business practices** | 58d? | 2005-01-12 A | 2005-04-01 |  |  | 0d |  |
| 23 | 2.1.1.1 | **Develop a Symbol Sub-team Communication Plan** | 53d? | 2005-01-12 A | 2005-03-25 |  |  | 4d |  |
| 24 |  | Define ground-rules for Sub-Team (internal) communication | 53d? | 2005-01-12 A | 2005-03-25 |  |  | 4d | finish no earlier than 2005-03-25 |
| 25 |  | Define ground-rules for communication between the Symbol Sub-Team and other GSTOP Sub-Teams | 53d? | 2005-01-12 A | 2005-03-25 |  |  | 4d | finish no earlier than 2005-03-25 |
| 26 |  | Define ground rules for communication between the Sub-Team and entities outside of the GSTOP Project | 53d? | 2005-01-12 A | 2005-03-25 |  |  | 4d | finish no earlier than 2005-03-25 |
| 27 |  | Establish a process and schedule for Sub-Team (internal) progress report updates | 53d? | 2005-01-12 A | 2005-03-25 |  |  | 4d | finish no earlier than 2005-03-25 |
| 28 |  | Establish a process and schedule for Sub-Team progress report updates to the GSTOP Team | 53d? | 2005-01-12 A | 2005-03-25 |  |  | 4d | finish no earlier than 2005-03-25 |
| 29 | 2.1.1.2 | **Establish Review Processes** | 58d? | 2005-01-12 A | 2005-04-01 |  |  | 0d |  |
| 30 |  | Establish a process for Sub-Team (internal) review of potential symbols | 58d? | 2005-01-12 A | 2005-04-01 |  |  | 0d | finish no earlier than 2005-04-01 |
| 31 |  | Establish a process for Sub-Team (internal) review of the draft standard symbols | 58d? | 2005-01-12 A | 2005-04-01 |  |  | 0d | finish no earlier than 2005-04-01 |
| 32 |  | Establish a process for peer reviews | 58d? | 2005-01-12 A | 2005-04-01 |  |  | 0d | finish no earlier than 2005-04-01 |
| 33 |  | Establish a process for periodic GSTOP Team reviews | 58d? | 2005-01-12 A | 2005-04-01 |  |  | 0d | finish no earlier than 2005-04-01 |
| 34 |  | Establish a process for reviewing the final report | 58d? | 2005-01-12 A | 2005-04-01 |  |  | 0d | finish no earlier than 2005-04-01 |
| 35 | 2.1.1.3 | **Establish Change processes** | 58d? | 2005-01-12 A | 2005-04-01 |  |  | 0d |  |
| 36 |  | Establish a process for additions/deletions of potential symbols mid-stream through the Project | 58d? | 2005-01-12 A | 2005-04-01 |  |  | -58d |  |
| 37 |  | Establish a change process for the additions/deletion of standard symbols after the final recommendation has been submitted and prior to completion of the GSTOP project | 58d? | 2005-01-12 A | 2005-04-01 | 36 |  | -58d |  |
| 38 |  | Establish a change process for the additions/deletion of standard symbols after the completion of the GSTOP project | 58d? | 2005-01-12 A | 2005-04-01 | 37 |  | -1d |  |
| 39 | 2.1.2 | **Develop GIS Standard Symbology SOP Requirements** | 49d? | 2005-02-01 A | 2005-04-08 |  |  | -5d |  |
| 40 | 2.1.2.1 | **Establish symbol evaluation methods** | 12d? | 2005-03-17 | 2005-04-01 |  |  | -7d |  |
| 41 |  | Define method for evaluating marker symbols | 12d? | 2005-03-17 | 2005-04-01 |  |  | -7d | finish no earlier than 2005-04-01 |
| 42 |  | Define method for evaluating line symbols | 12d? | 2005-03-17 | 2005-04-01 |  |  | -7d | finish no earlier than 2005-04-01 |
| 43 |  | Define method for evaluating fill symbols | 12d? | 2005-03-17 | 2005-04-01 |  |  | -7d | finish no earlier than 2005-04-01 |
| 44 |  | Conduct a final review of evaluation methods | 12d? | 2005-03-17 | 2005-04-01 |  |  | -7d | finish no earlier than 2005-04-01 |
| 45 | 2.1.2.2 | **Define criteria for the acceptance of symbols as standards** | 17d? | 2005-03-17 | 2005-04-08 |  |  | -12d |  |
| 46 |  | Develop acceptance criteria for marker symbols | 17d? | 2005-03-17 | 2005-04-08 |  |  | -12d | finish no earlier than 2005-04-08 |
| 47 |  | Develop acceptance criteria for line symbols | 17d? | 2005-03-17 | 2005-04-08 |  |  | -12d | finish no earlier than 2005-04-08 |
| 48 |  | Develop acceptance criteria for fill symbols | 17d? | 2005-03-17 | 2005-04-08 |  |  | -12d | finish no earlier than 2005-04-08 |
| 49 |  | Conduct a final review of selection criteria | 17d? | 2005-03-17 | 2005-04-08 |  |  | -12d | finish no earlier than 2005-04-08 |
| 50 | 2.1.2.3 | **Establish file format for symbols** | 44d? | 2005-02-01 A | 2005-04-01 |  |  | 0d |  |
| 51 |  | Define acceptable formats of symbols for evaluation | 44d? | 2005-02-01 A | 2005-04-01 |  |  | 0d | finish no earlier than 2005-04-01 |
| 52 |  | Define format of recommended standard symbols | 44d? | 2005-02-01 A | 2005-04-01 |  |  | 0d | finish no earlier than 2005-04-01 |
| 53 | 2.1.3 | **Develop Draft GIS Standard Symbology SOPs** | 125d? | 2004-12-01 A | 2005-05-24 | 39 | 81% | -38d |  |
| 54 | 2.1.3.1 | **Develop a list of symbols to be evaluated for acceptance as draft standards** | 101d? | 2004-12-01 A | 2005-04-20 |  | 94% | -20d |  |
| 55 |  | Collect Fire mapping symbols from the Fireline Handbook | 81d? | 2004-12-01 A | 2005-03-23 A |  | 100% |  |  |
| 56 |  | Collect Fire mapping symbols suggestions from the 5 federal fire management agencies (FS, BLM, NPS, FWS, BIA) and state agencies | 81d? | 2004-12-01 A | 2005-03-23 A |  | 100% |  |  |
| 57 |  | Collect Fire mapping symbols suggestions from the BIA | 7d? | 2005-04-11 | 2005-04-19 | 56 |  | -55d | finish no earlier than 2005-04-01 |
| 58 |  | Collect Fire mapping symbols from HSA (FEMA), FAA | 81d? | 2004-12-01 A | 2005-03-23 A |  | 100% |  |  |
| 59 |  | Collect Fire mapping symbols from HSA (FEMA), FAA, and DOD | 7d? | 2005-04-11 | 2005-04-19 | 58 |  | -54d | finish no earlier than 2005-04-01 |
| 60 |  | Document potential sources for additional fire mapping symbols | 1d? | 2005-04-11 | 2005-04-11 |  |  | -48d |  |
| 61 |  | Compile symbols into a single potential symbol set | 1d? | 2005-04-20 | 2005-04-20 | 55, 56, 57, 58 |  | -55d |  |
| 62 | 2.1.3.2 | **Determine the draft standard marker symbols** | 8d? | 2005-04-21 | 2005-05-02 | 54 |  | -55d |  |
| 63 |  | Evaluate each potential marker symbol against the marker symbol selection criteria | 1d? | 2005-04-21 | 2005-04-21 |  |  | -48d |  |
| 64 |  | Selection the draft standard marker symbols | 1d? | 2005-04-21 | 2005-04-21 |  |  | -48d |  |
| 65 |  | Conduct a completeness review of the draft standard marker symbols | 8d? | 2005-04-21 | 2005-05-02 |  |  | -55d | finish no earlier than 2005-04-14 |
| 66 | 2.1.3.3 | **Determine the draft standard line symbols** | 8d? | 2005-04-21 | 2005-05-02 | 54 |  | -55d |  |
| 67 |  | Evaluate each potential line symbol against the line symbol selection criteria | 1d? | 2005-04-21 | 2005-04-21 |  |  | -48d |  |
| 68 |  | Select the draft standard line symbols | 1d? | 2005-04-21 | 2005-04-21 |  |  | -48d |  |
| 69 |  | Conduct a completeness review of the draft standard line symbols | 8d? | 2005-04-21 | 2005-05-02 |  |  | -55d | finish no earlier than 2005-04-14 |
| 70 | 2.1.3.4 | **Determine the draft standard fill symbols** | 8d? | 2005-04-21 | 2005-05-02 | 54 |  | -55d |  |

| ID | WBS | Task | Duration | Start | Finish | Predecessors | Complete | Total float | Constraint |
| --- | --- | --- | --- | --- | --- | --- | --- | --- | --- |
| 71 |  | Evaluate each potential fill symbol against the fill symbol selection criteria | 1d? | 2005-04-21 | 2005-04-21 |  |  | -48d |  |
| 72 |  | Select the draft standard fill symbols | 1d? | 2005-04-21 | 2005-04-21 |  |  | -48d |  |
| 73 |  | Conduct a completeness review of the draft standard fill symbols | 8d? | 2005-04-21 | 2005-05-02 |  |  | -55d | finish no earlier than 2005-04-14 |
| 74 | 2.1.3.5 | **Conduct initial peer review of the draft standard marker, line, and fill symbols** | 16d? | 2005-05-03 | 2005-05-24 | 62, 66, 70 |  | -55d |  |
| 75 |  | Prepare draft standard symbols for initial peer review | 1d? | 2005-05-03 | 2005-05-03 |  |  | -55d |  |
| 76 |  | Submit the draft standard symbols to the 5 federal fire management agencies and State agencies via the NWCG Geospatial Task Group (GTG); and to the HSA (FEMA), FAA, DOD, and GSTOP Team for peer review | 0d | 2005-05-03 | 2005-05-03 | 75 |  | -55d |  |
| 77 |  | Review draft Standard Symbols | 5d | 2005-05-04 | 2005-05-10 | 76 |  | -45d |  |
| 78 |  | Review feedback of initial peer review | 2d | 2005-05-18 | 2005-05-19 | 76FS+10d |  | -55d |  |
| 79 |  | Identify required changes to draft standard symbols based on the initial peer review feedback | 2d | 2005-05-20 | 2005-05-23 | 78 |  | -55d |  |
| 80 |  | Make required changes, as identified, to draft standard symbols | 1d? | 2005-05-24 | 2005-05-24 | 79 |  | -55d |  |
| 81 |  | Prepare draft SOPs for field review | 1d? | 2005-04-19 | 2005-04-19 | 376 |  | -13d |  |
| 82 | 2.1.4 | **Conduct final peer review of the draft standard marker, line and fill symbols** | 17d? | 2005-05-25 | 2005-06-16 | 74 |  | -55d |  |
| 83 |  | Prepare draft standard symbols for final peer review | 1d? | 2005-05-25 | 2005-05-25 |  |  | -55d |  |
| 84 |  | Submit the draft standard symbols to the 5 federal fire management agencies and State agencies via the NWCG Geospatial Task Group (GTG); and to the HSA (FEMA), FAA, DOD, and GSTOP Team for peer review | 0d | 2005-05-25 | 2005-05-25 | 83 |  | -55d |  |
| 85 |  | Review draft Standard Symbols | 10d | 2005-05-26 | 2005-06-08 | 84 |  | -55d |  |
| 86 |  | Review feedback of the final peer review | 1d? | 2005-06-09 | 2005-06-09 | 85 |  | -55d |  |
| 87 |  | Identify required changes to draft standard symbols based on the final peer review feedback | 2d | 2005-06-10 | 2005-06-13 | 86 |  | -55d |  |
| 88 |  | Make required changes, as identified, to draft standard symbols | 2d | 2005-06-14 | 2005-06-15 | 87 |  | -55d |  |
| 89 |  | Ratify the final draft standard symbols | 1d? | 2005-06-16 | 2005-06-16 | 88 |  | -55d |  |
| 90 | 2.1.5 | **Finalize recommendation of standard Fire Mapping symbols** | 2d? | 2005-03-16 | 2005-03-17 |  |  | 10d |  |
| 91 |  | Create a report recommending the adoption of the draft standard symbols | 1d? | 2005-03-16 | 2005-03-16 |  |  | 10d |  |
| 92 |  | Conduct a review of the report | 1d? | 2005-03-17 | 2005-03-17 | 91 |  | 10d |  |
| 93 |  | Submit the report to GSTOP-PM | 0d | 2005-03-17 | 2005-03-17 | 92 |  | 10d |  |
| 94 | 2.2 | **Incident GIS Standard Naming Conventions** | 81d? | 2005-01-25 A | 2005-05-17 |  | 21% | -28d |  |
| 95 | 2.2.1 | **Develop GIS Naming Convention/Directory Structure Subteam Practices** | 1d? | 2005-03-16 | 2005-03-16 |  |  | 11d |  |
| 96 |  | Set objectives for work plan | 1d? | 2005-03-16 | 2005-03-16 |  |  | 11d |  |
| 97 |  | Define ground rules for sub team | 1d? | 2005-03-16 | 2005-03-16 |  |  | 11d |  |
| 98 |  | Define common ground with other sub teams | 1d? | 2005-03-16 | 2005-03-16 |  |  | 11d |  |
| 99 | 2.2.2 | **Develop GIS Standard Naming Convention SOP Requirements** | 62d? | 2005-01-25 A | 2005-04-20 |  | 53% | -9d |  |
| 100 |  | Define Information Needs (What do we need to gather?) | 1d? | 2005-03-16 | 2005-03-16 |  |  | -25d |  |
| 101 |  | Collect existing naming and filing conventions from GIST's attached to IMT's | 1d? | 2005-03-17 | 2005-03-17 | 100 |  | -25d |  |
| 102 | 2.2.2.3 | **Conduct Analysis** | 2d? | 2005-03-16 | 2005-03-17 |  |  | -25d |  |
| 103 |  | Review strengths & weaknesses of existing methodologies | 1d? | 2005-03-16 | 2005-03-16 |  |  | -25d |  |
| 104 |  | Resolve overlap and conflicts | 1d? | 2005-03-17 | 2005-03-17 | 103 |  | -25d |  |
| 105 | 2.2.2.4 | **Develop Preliminary Requirements for GIS Naming Convention and Directory Structure** | 3d? | 2005-01-25 A | 2005-01-27 A | 104 | 100% |  |  |
| 106 |  | Draft naming convention guidelines/requirements | 3d? | 2005-01-25 A | 2005-01-27 A |  | 100% |  |  |
| 107 |  | Draft directory structure guidelines/requirements | 3d? | 2005-01-25 A | 2005-01-27 A | 106 | 100% |  |  |
| 108 | 2.2.2.5 | **Review and Validate Requirements** | 11d? | 2005-04-05 A | 2005-04-19 | 107 | 50% | -8d |  |
| 109 |  | Post draft guidelines/requirements for GIS Naming Convention and Directory Structure for inter team review | 3d? | 2005-04-05 A | 2005-04-07 A |  | 100% |  |  |
| 110 |  | Review of draft guidelines/Requirements for GIS Naming Convention and Directory Structure | 1d | 2005-04-15 | 2005-04-15 | 109 |  | -49d | finish no earlier than 2005-04-15 |
| 111 |  | Edit draft guidelines/Requirements based on team input | 1d | 2005-04-18 | 2005-04-18 | 110 |  | -49d |  |
| 112 |  | Post draft guidelines/Requirements for external review | 1d? | 2005-04-19 | 2005-04-19 | 111 |  | -49d |  |
| 113 |  | Draft GIS Naming Convention/Directory Structure Requirements developed | 1d? | 2005-04-20 | 2005-04-20 | 108 |  | -49d |  |
| 114 | 2.2.3 | **Develop Draft GIS Standard Naming Convention SOPs** | 55d? | 2005-02-10 A | 2005-04-27 | 99 | 17% | -33d |  |
| 115 | 2.2.3.1 | **Prepare Sample of Naming Conventions and Directory Structure** | 52d? | 2005-02-10 A | 2005-04-22 |  | 33% | -33d |  |
| 116 |  | Prepare Naming conventions | 1d? | 2005-02-10 A | 2005-02-10 A |  | 100% |  |  |
| 117 |  | Develop Directory structure | 0d? | 2005-02-10 A | 2005-02-10 A |  | 100% |  |  |
| 118 |  | Prepare Methods of work | 1d? | 2005-04-21 | 2005-04-21 |  |  | -33d |  |
| 119 |  | Prepare draft SOPs for field review | 1d? | 2005-04-22 | 2005-04-22 | 116, 117, 118, 376 |  | -33d |  |
| 120 | 2.2.3.2 | **Sample Documents/draft SOPs Review and Validation** | 3d? | 2005-04-25 | 2005-04-27 | 115 |  | -33d |  |
| 121 |  | Post sample documents for inter team review | 1d? | 2005-04-25 | 2005-04-25 |  |  | -33d |  |
| 122 |  | Edit sample documents based on input | 1d? | 2005-04-26 | 2005-04-26 | 121 |  | -33d |  |
| 123 |  | Draft GIS Naming Convention/Directory Structure SOPs developed | 1d? | 2005-04-27 | 2005-04-27 | 122 |  | -33d |  |
| 124 | 2.2.4 | **Conduct External Review of GIS Naming Standard/Directory Structure SOP requirements and draft SOPs** | 12d? | 2005-04-28 | 2005-05-13 | 114 |  | -33d |  |
| 125 |  | Design External Review of guidelines/requirements for GIS Naming Standards and Directory Structure | 2d? | 2005-04-28 | 2005-04-29 | 112 |  | -28.5d |  |
| 126 |  | Post sample documents/SOPs for external review | 5d? | 2005-05-02 | 2005-05-06 | 125 |  | -28.5d |  |
| 127 |  | Conduct External review of Guidelines/Requirements and draft SOPs | 0.5d? | 2005-05-09 | 2005-05-09 | 126 |  | -28.5d |  |
| 128 |  | Edit draft guidelines/Requirements based on input | 1d? | 2005-04-28 | 2005-04-28 |  |  | -22d |  |
| 129 |  | Edit sample documents/SOPs based on input | 12d? | 2005-04-28 | 2005-05-13 |  |  | -33d |  |
| 130 | 2.2.5 | **Finalize recommendation of GIS Standard Naming Conventions** | 2d? | 2005-05-16 | 2005-05-17 | 124 |  | -33d |  |
| 131 |  | Create a report recommending the adoption of the standard | 1d? | 2005-05-16 | 2005-05-16 |  |  | -33d |  |
| 132 |  | Conduct a review of the report | 1d? | 2005-05-17 | 2005-05-17 | 131 |  | -33d |  |
| 133 |  | Submit the report to GSTOP-PM | 0d | 2005-05-17 | 2005-05-17 | 132 |  | -33d |  |
| 134 | 2.3 | **Incident GIS Standard Product Definitions** | 65d? | 2005-02-09 A | 2005-05-11 |  |  | -29d |  |
| 135 | 2.3.1 | **Develop GIS Standard Product Definitions SOP Requirements** | 52d? | 2005-02-09 A | 2005-04-22 |  |  | -16d |  |
| 136 | 2.3.1.1 | **Define criteria for the acceptance of standard products definitions** | 2d? | 2005-03-16 | 2005-03-17 |  |  | 10d |  |
| 137 |  | Develop acceptance criteria for std products definitions | 1d? | 2005-03-16 | 2005-03-16 |  |  | 10d |  |
| 138 |  | Conduct a final review of selection criteria | 1d? | 2005-03-17 | 2005-03-17 | 137 |  | 10d |  |
| 139 | 2.3.1.2 | **Define/Collect Information** | 25d? | 2005-02-09 A | 2005-03-16 |  |  | -11d |  |
| 140 |  | Develop Standard Products Matrix to compare many versions of standard products. (GIST Draft Taskbook/GIST Course Workbook/PNWCG Product Objectives) | 0d? | 2005-02-09 A | 2005-02-09 A |  | 100% |  |  |

| ID | WBS | Task | Duration | Start | Finish | Predecessors | Complete | Total float | Constraint |
| --- | --- | --- | --- | --- | --- | --- | --- | --- | --- |
| 141 |  | Acquire DPRO Standards and incorporate into above matrix. | 0d? | 2005-03-01 A | 2005-03-01 A |  | 100% |  |  |
| 142 |  | Victoria Smith definitions/PNWCG definitions/DPRO defs. Compile these into a list for group to review. Cite source. | 0d? | 2005-03-01 A | 2005-03-01 A |  | 100% |  |  |
| 143 |  | Post for review including samples | 1d? | 2005-03-16 | 2005-03-16 | 142 |  | -25d |  |
| 144 |  | Collect examples of new kinds of standard products that aren't in any of the existing definitions | 1d? | 2005-02-10 A | 2005-02-10 |  |  | -1d | start no earlier than 2005-02-10 |
| 145 | 2.3.1.3 | **Conduct Analysis** | 27d? | 2005-03-17 | 2005-04-22 | 139 |  | -29d |  |
| 146 |  | Define the meaning of product definitions - what goes into them? | 1d? | 2005-03-17 | 2005-03-17 |  |  | -3d |  |
| 147 |  | Create a draft template of what a product definition is | 1d? | 2005-03-23 | 2005-03-23 |  |  | -29d | finish no earlier than 2005-03-23 |
| 148 |  | Review existing standards definitions (Victoria/PNWCG/DPRO) & Identify discrepancies between groups defining standard | 10d | 2005-03-24 | 2005-04-06 | 147 |  | -29d |  |
| 149 |  | Highlight specific reasons for discrepancies (Fire Use vs. Type 1) if needed | 1d? | 2005-03-24 | 2005-03-24 | 147 |  | -20d |  |
| 150 |  | Bring these to the larger group for discussion and resolution | 10d | 2005-04-07 | 2005-04-20 | 149, 148, 147 |  | -29d |  |
| 151 |  | Gather responses from GSTOP and GTG; incorporte feedback | 1d? | 2005-04-21 | 2005-04-21 | 150 |  | -29d |  |
| 152 |  | Send out to wider folks for review (Field Test) | 1d? | 2005-04-22 | 2005-04-22 | 151 |  | -29d |  |
| 153 | 2.3.2 | **Develop draft GIS Standard Product Definition SOPs** | 1d? | 2005-04-25 | 2005-04-25 | 145 |  | -29d |  |
| 154 |  | Provide a package of draft products definitions and samples for review | 1d? | 2005-04-25 | 2005-04-25 |  |  | -29d |  |
| 155 |  | Evaluate std products against acceptance criteria | 1d? | 2005-04-25 | 2005-04-25 |  |  | -29d |  |
| 156 |  | Provide data location and review process to internal group | 1d? | 2005-04-25 | 2005-04-25 |  |  | -29d |  |
| 157 |  | Prepare draft SOPs for review | 1d? | 2005-04-25 | 2005-04-25 | 376 |  | -29d |  |
| 158 | 2.3.3 | **Conduct External Review of draft GIS Standard Product Definition SOPs** | 10d? | 2005-04-26 | 2005-05-09 | 153 |  | -29d |  |
| 159 | 2.3.3.1 | **Conduct outside peer review of the draft standard products definitions** | 4d? | 2005-04-26 | 2005-04-29 |  |  | -29d |  |
| 160 |  | Submit the draft standard symbols to the 5 federal fire management agencies and State agencies via the NWCG Geospatial Task Group (GTG); and to the DHS (FEMA), FAA, DOD, and GSTOP Team for peer review | 1d? | 2005-04-26 | 2005-04-26 |  |  | -29d |  |
| 161 |  | Review feedback of initial peer review | 1d? | 2005-04-27 | 2005-04-27 | 160 |  | -29d |  |
| 162 |  | Identify required changes to draft standard products based on the initial peer review feedback | 1d? | 2005-04-28 | 2005-04-28 | 161 |  | -29d |  |
| 163 |  | Make required changes, as identified, to draft standard products | 1d? | 2005-04-29 | 2005-04-29 | 162 |  | -29d |  |
| 164 | 2.3.3.2 | **Conduct final peer review of the draft standard products** | 6d? | 2005-05-02 | 2005-05-09 | 159 |  | -29d |  |
| 165 |  | Prepare draft standard products for final peer review | 1d? | 2005-05-02 | 2005-05-02 |  |  | -29d |  |
| 166 |  | Submit the draft standard products to the 5 federal fire management agencies and State agencies via the NWCG Geospatial Task Group (GTG); and to the HSA (FEMA), FAA, DOD, and GSTOP Team for peer review | 1d? | 2005-05-03 | 2005-05-03 | 165 |  | -29d |  |
| 167 |  | Review feedback of the final peer review | 1d? | 2005-05-04 | 2005-05-04 | 166 |  | -29d |  |
| 168 |  | Identify required changes to draft standard products based on the final peer review feedback | 1d? | 2005-05-05 | 2005-05-05 | 167 |  | -29d |  |
| 169 |  | Make required changes, as identified, to draft standard products | 1d? | 2005-05-06 | 2005-05-06 | 168 |  | -29d |  |
| 170 |  | Ratify the final draft standard symbols | 1d? | 2005-05-09 | 2005-05-09 | 169 |  | -29d |  |
| 171 | 2.3.4 | **Finalize recommendation of standard Fire Mapping products** | 2d? | 2005-05-10 | 2005-05-11 | 164 |  | -29d |  |
| 172 |  | Create a report recommending the adoption of the draft standard product definitions | 1d? | 2005-05-10 | 2005-05-10 |  |  | -29d |  |
| 173 |  | Conduct a review of the report for completeness, accuracy, language, and grammar | 1d? | 2005-05-11 | 2005-05-11 | 172 |  | -29d |  |
| 174 |  | Submit the report to GSTOP-PM | 0d | 2005-05-11 | 2005-05-11 | 173 |  | -29d |  |
| 175 |  | Find a permanent storage location for this package? National clearinghouse? | 1d? | 2005-05-10 | 2005-05-10 |  |  | -28d |  |
| 176 | 2.4 | **Incident GIST Minimum Qualifications & GIS Expectations** | 28.5d? | 2005-03-16 A | 2005-04-25 |  | 17% | -16.5d |  |
| 177 | 2.4.1 | **Develop Requirements for determining the GIST Minimum Qualifications & GIS Expectations** | 6.5d? | 2005-03-16 A | 2005-03-24 |  | 48% | -0.5d |  |
| 178 | 2.4.1.1 | **Establish evaluation methods for minimum GIST qualifications/GIS expectations** | 1d? | 2005-03-16 | 2005-03-16 |  |  | -11d |  |
| 179 |  | Define method for evaluating minimum GIST qualifications/GIS expectations | 1d? | 2005-03-16 | 2005-03-16 |  |  | -11d |  |
| 180 |  | Conduct a final review of evaluation methods | 1d? | 2005-03-16 | 2005-03-16 |  |  | -11d |  |
| 181 | 2.4.1.2 | **Define criteria for the acceptance of minimum GIST qualifications/GIS expectations** | 1d? | 2005-03-16 | 2005-03-16 |  |  | -11d |  |
| 182 |  | Develop acceptance criteria for minimum GIST qualifications/GIS expectations | 1d? | 2005-03-16 | 2005-03-16 |  |  | -11d |  |
| 183 |  | Conduct a final review of selection criteria | 1d? | 2005-03-16 | 2005-03-16 |  |  | -11d |  |
| 184 | 2.4.1.3 | **Collect Information on minimum GIST qualifications and minimum GIS expectations on an incident** | 6.5d? | 2005-03-16 A | 2005-03-24 |  | 71% | -0.5d |  |
| 185 |  | Gather documents and references (including white papers, memos, After Action Reviews, agency guidelines) | 6d? | 2005-03-16 A | 2005-03-23 A |  | 100% |  |  |
| 186 |  | Obtain and review revised Taskbook | 0.5d? | 2005-03-24 | 2005-03-24 | 185 |  | -16.5d |  |
| 187 |  | Scan or translate paper documents to electronic format | 1d? | 2005-03-16 | 2005-03-16 |  |  | -11d |  |
| 188 |  | Research current GIST/GIS standards | 1d? | 2005-03-16 | 2005-03-16 |  |  | -11d |  |
| 189 | 2.4.2 | **Develop draft of GIST Minimum Qualifications & Expecations** | 12d? | 2005-03-24 | 2005-04-11 | 177 |  | -16.5d |  |
| 190 | 2.4.2.1 | **Develop a list of GIST qualifications to be evaluated for acceptance as draft minimum standards** | 3d? | 2005-03-24 | 2005-03-29 | 184 |  | -16.5d |  |
| 191 |  | Compare the current GIST standards | 1d? | 2005-03-24 | 2005-03-25 |  |  | -16.5d |  |
| 192 |  | Compile the GIST qualifications into a single list of potential minimum GIST qualifications | 1d? | 2005-03-25 | 2005-03-28 | 191 |  | -16.5d |  |
| 193 |  | Compile a list of GIST qualifications which are deemed to be beyond the minimum for future reference | 1d? | 2005-03-28 | 2005-03-29 | 192 |  | -16.5d |  |
| 194 | 2.4.2.2 | **Determine the draft standard minimum GIST qualifications** | 3d? | 2005-03-29 | 2005-04-01 | 190 |  | -16.5d |  |
| 195 |  | Evaluate each potential minimum GIST qualification using the approved evaluation methods | 1d? | 2005-03-29 | 2005-03-30 | 178 |  | -16.5d |  |
| 196 |  | Select the minimum GIST qualifications | 1d? | 2005-03-30 | 2005-03-31 | 195 |  | -16.5d |  |
| 197 |  | Conduct a completeness review of the draft minimum GIST qualifications | 1d? | 2005-03-31 | 2005-04-01 | 196 |  | -16.5d |  |
| 198 | 2.4.2.3 | **Conduct internal review of draft standard minimum GIST qualifications & GIS expectations** | 6d? | 2005-04-01 | 2005-04-11 | 194 |  | -16.5d |  |
| 199 |  | Prepare draft standard minimum GIST qualifications and GIS expectations, including acceptance criteria | 1d? | 2005-04-01 | 2005-04-04 |  |  | -16.5d |  |
| 200 |  | Post draft standard to DisasterHelp website and notify GSTOP team for group review | 1d? | 2005-04-04 | 2005-04-05 | 199 |  | -16.5d |  |
| 201 |  | Provide data location and review process to internal group | 1d? | 2005-04-05 | 2005-04-06 | 200 |  | -16.5d |  |
| 202 |  | Review feedback of initial peer review | 1d? | 2005-04-06 | 2005-04-07 | 201 |  | -16.5d |  |
| 203 |  | Identify required changes to draft standard based on the initial peer review feedback | 1d? | 2005-04-07 | 2005-04-08 | 202 |  | -16.5d |  |
| 204 |  | Make required changes, as identified, to draft standard | 1d? | 2005-04-08 | 2005-04-11 | 203 |  | -16.5d |  |
| 205 | 2.4.3 | **Conduct final peer review of the draft standard minimum GIST qualifications & GIS expectations** | 7d? | 2005-04-11 | 2005-04-20 | 189 |  | -16.5d |  |
| 206 |  | Prepare survey or questionnaire to accompany draft standards for final peer review. | 1d? | 2005-04-11 | 2005-04-12 |  |  | -16.5d |  |
| 207 |  | Prepare draft standard minimum GIST Qualification/GIST expectations for final peer review, including the survey of results | 1d? | 2005-04-12 | 2005-04-13 | 206 |  | -16.5d |  |
| 208 |  | Submit the draft expectations to the 5 federal fire management agencies and State agencies via the NWCG Geospatial Task Group (GTG); and to the HSA (FEMA), FAA, DOD, and GSTOP Team for peer review. | 1d? | 2005-04-13 | 2005-04-14 | 207 |  | -16.5d |  |
| 209 |  | Review feedback of the final peer review, including survey of results | 1d? | 2005-04-14 | 2005-04-15 | 208 |  | -16.5d |  |
| 210 |  | Identify required changes to draft standard minimum GIST qualifications/GIS expectations based on the final peer review feedback | 1d? | 2005-04-15 | 2005-04-18 | 209 |  | -16.5d |  |

| ID | WBS | Task | Duration | Start | Finish | Predecessors | Complete | Total float | Constraint |
| --- | --- | --- | --- | --- | --- | --- | --- | --- | --- |
| 211 |  | Make required changes, as identified, to draft minimum GIST qualifications/GIS expectations symbols | 1d? | 2005-04-18 | 2005-04-19 | 210 |  | -16.5d |  |
| 212 |  | Ratify the final draft standard minimum GIST qualifications/GIS expectations | 1d? | 2005-04-19 | 2005-04-20 | 211 |  | -16.5d |  |
| 213 | 2.4.4 | **Finalize recommendation for standard Minimum GIST Qualifications & GIS Expectations on an Incident** | 3d? | 2005-04-20 | 2005-04-25 | 205 |  | -16.5d |  |
| 214 |  | Create a report recommending the adoption of the draft minimum GIST Qualifications/GIS Expectations | 1d? | 2005-04-20 | 2005-04-21 |  |  | -16.5d |  |
| 215 |  | Conduct a review of the report for completeness, accuracy, language, and grammar | 1d? | 2005-04-21 | 2005-04-22 | 214 |  | -16.5d |  |
| 216 |  | Submit the report to GSTOP-PM | 1d? | 2005-04-22 | 2005-04-25 | 215 |  | -16.5d |  |
| 217 | 2.5 | **Incident GIS Minimum Essential Datasets** | 53d? | 2005-02-10 A | 2005-04-25 |  | 4% | -12d |  |
| 218 | 2.5.1 | **Establish MED Sub-Team business practices** | 25d? | 2005-02-10 A | 2005-03-16 |  |  | 11d |  |
| 219 | 2.5.1.1 | **Develop a MED Sub-team Communication Plan** | 25d? | 2005-02-10 A | 2005-03-16 |  |  | 11d |  |
| 220 |  | Define ground-rules for Sub-Team (internal) communication | 1d? | 2005-03-16 | 2005-03-16 |  |  | 11d |  |
| 221 |  | Define ground-rules for communication between the MED Sub-Team and other GSTOP Sub-Teams | 1d? | 2005-02-10 A | 2005-02-10 |  |  | 35d |  |
| 222 |  | Define ground rules for communication between the Sub-Team and entities outside of the GSTOP Project | 1d? | 2005-02-10 A | 2005-02-10 |  |  | 35d |  |
| 223 |  | Establish a process and schedule for Sub-Team (internal) progress report updates | 1d? | 2005-02-10 A | 2005-02-10 |  |  | 35d |  |
| 224 |  | Establish a process and schedule for Sub-Team progress report updates to the GSTOP Team | 1d? | 2005-02-10 A | 2005-02-10 |  |  | 35d |  |
| 225 | 2.5.1.2 | **Establish Review Processes** | 25d? | 2005-02-10 A | 2005-03-16 |  |  | 11d |  |
| 226 |  | Establish a process for Sub-Team (internal) review of potential MEDs | 1d? | 2005-02-10 A | 2005-02-10 |  |  | -1d |  |
| 227 |  | Establish a process for Sub-Team (internal) review of the draft standard MEDs | 1d? | 2005-02-10 A | 2005-02-10 | 226 |  | 34d |  |
| 228 |  | Establish a process for peer reviews | 1d? | 2005-03-16 | 2005-03-16 | 227 |  | 11d |  |
| 229 |  | Establish a process for periodic GSTOP Team reviews | 1d? | 2005-03-01 A | 2005-03-01 |  |  | -1d |  |
| 230 |  | Establish a process for reviewing the final report | 1d? | 2005-03-01 A | 2005-03-01 | 229 |  | -1d |  |
| 231 | 2.5.1.3 | **Establish Change processes** | 12d? | 2005-03-01 A | 2005-03-16 | 230 |  | 11d |  |
| 232 |  | Establish a process for additions/deletions of potential MEDs mid-stream through the Project | 1d? | 2005-03-01 A | 2005-03-01 |  |  | -1d |  |
| 233 |  | Establish a change process for the additions/deletion of standard MEDs after the final recommendation has been submitted | 1d? | 2005-03-01 A | 2005-03-01 | 232 |  | 21d |  |
| 234 |  | Establish a change process for the additions/deletion of standard MEDs after the final recommendation has been approved through the GSTOP Team | 1d? | 2005-03-16 | 2005-03-16 | 233 |  | 11d |  |
| 235 | 2.5.2 | **Develop requirements for GIS Minimum Essential Datasets SOPs** | 29d? | 2005-03-01 A | 2005-04-08 |  | 5% | -1d |  |
| 236 | 2.5.2.1 | **Establish MED evaluation methods** | 18d? | 2005-03-16 A | 2005-04-08 |  | 14% | -1d |  |
| 237 | 2.5.2.1.1 | **Define High level criteria for the acceptance of MEDs as standards** | 17d? | 2005-03-17 A | 2005-04-08 |  |  | -1d |  |
| 238 |  | Determine incident tasks and required deliverables | 1d? | 2005-03-17 A | 2005-03-17 |  |  | -1d |  |
| 239 |  | Determine data availability criteria | 3d | 2005-04-05 A | 2005-04-07 |  |  | -17d |  |
| 240 |  | Develop accuracy standards for databases | 1d? | 2005-04-08 | 2005-04-08 | 239 |  | -17d |  |
| 241 |  | Define method for evaluating MEDs | 13d? | 2005-03-18 A | 2005-04-05 |  |  | -14d |  |
| 242 |  | Develop acceptance criteria for raster MEDs | 1d? | 2005-03-16 | 2005-03-16 |  |  | 0d |  |
| 243 |  | Post draft Acceptance Critera for GSTOP Team review | 4d? | 2005-03-18 A | 2005-03-23 A |  | 100% |  |  |
| 244 |  | Review draft Acceptance Criteria | 1d? | 2005-03-28 | 2005-03-28 | 243 |  | -13d | finish no earlier than 2005-03-28 |
| 245 |  | Update Acceptance Criteria for GSTOP Team input | 4d | 2005-03-29 | 2005-04-01 | 244 |  | -13d |  |
| 246 |  | Conduct a final review of selection criteria | 1d? | 2005-04-04 | 2005-04-04 | 245 |  | -13d |  |
| 247 | 2.5.2.2 | **Develop a list of MEDs to be evaluated for acceptance as draft standards** | 25d? | 2005-03-01 A | 2005-04-04 |  |  | -1d |  |
| 248 |  | Determine what datasets are required for each deliverable | 24d | 2005-03-01 A | 2005-04-01 |  |  | -12d | start no earlier than 2005-03-01 |
| 249 |  | Collect Standard Product Definition from GSTOP subteam to evaluate for potential MEDs | 24d? | 2005-03-01 A | 2005-04-01 |  |  | 0d | finish no earlier than 2005-04-01 |
| 250 |  | Document potential sources for additional fire mapping MEDs | 1d? | 2005-04-04 | 2005-04-04 | 249 |  | -13d |  |
| 251 |  | Compile MEDs into a single potential MED set | 1d? | 2005-04-04 | 2005-04-04 | 249 |  | -13d |  |
| 252 |  | Define methods a GIST should yuse to determine if dataset meets Accuracy Standards | 1d? | 2005-03-16 | 2005-03-16 |  |  | 0d |  |
| 253 | 2.5.3 | **Develop draft SOPs for GIS Minimum Essential Datasets** | 9d? | 2005-04-11 | 2005-04-21 | 235 |  | -17d |  |
| 254 | 2.5.3.1 | **Determine the draft standard Raster MEDs** | 3d? | 2005-04-11 | 2005-04-13 | 247 |  | -17d |  |
| 255 |  | Evaluate each potential marker MED against the MED selection criteria | 1d? | 2005-04-11 | 2005-04-11 |  |  | -17d |  |
| 256 |  | Sub-Team selection of the draft standards for MEDs vs. extended MED list | 1d? | 2005-04-12 | 2005-04-12 | 255 |  | -17d |  |
| 257 |  | Conduct a Sub-team completeness review of the draft standard MEDs | 1d? | 2005-04-13 | 2005-04-13 | 256 |  | -17d |  |
| 258 | 2.5.3.2 | **Conduct a Sub-team completeness review of the draft standard and extended MEDs** | 5d? | 2005-04-14 | 2005-04-20 | 254 |  | -17d |  |
| 259 |  | Prepare draft standard MEDs for initial peer review | 1d? | 2005-04-14 | 2005-04-14 |  |  | -17d |  |
| 260 |  | Submit the draft standard MEDs to the 5 federal fire management agencies, State agencies, and USGS via the NWCG Geospatial Task Group (GTG); and to DHS (FEMA), FAA, DOD, and GSTOP Team for peer review | 0d | 2005-04-14 | 2005-04-14 | 259 |  | -17d |  |
| 261 |  | Conduct initial peer review of the draft standard and extended MEDs | 1d? | 2005-04-15 | 2005-04-15 | 260 |  | -17d |  |
| 262 |  | Review feedback of initial peer review | 1d? | 2005-04-18 | 2005-04-18 | 261 |  | -17d |  |
| 263 |  | Identify required changes to draft standard MEDs based on the initial peer review feedback | 1d? | 2005-04-19 | 2005-04-19 | 262 |  | -17d |  |
| 264 |  | Make required changes, as identified, to draft standard MEDs | 1d? | 2005-04-20 | 2005-04-20 | 263 |  | -17d |  |
| 265 |  | Prepare draft SOPs for field test | 1d? | 2005-04-21 | 2005-04-21 | 258 |  | -17d |  |
| 266 | 2.5.4 | **Conduct final peer review of the draft standard marker, line, and fill MEDs** | 1d? | 2005-04-22 | 2005-04-22 | 253 |  | -17d |  |
| 267 |  | Prepare draft standard MEDs for final peer review | 1d? | 2005-04-22 | 2005-04-22 |  |  | -17d |  |
| 268 |  | Submit the draft standard MEDs to the 5 federal fire management agencies and State agencies via the NWCG Geospatial Task Group (GTG); and to the HSA (FEMA), FAA, DOD, and GSTOP Team for peer review | 1d? | 2005-04-22 | 2005-04-22 |  |  | -17d |  |
| 269 |  | Review feedback of the final peer review | 1d? | 2005-04-22 | 2005-04-22 |  |  | -17d |  |
| 270 |  | Identify required changes to draft standard MEDs based on the final peer review feedback | 1d? | 2005-04-22 | 2005-04-22 |  |  | -17d |  |
| 271 |  | Make required changes, as identified, to draft standard MEDs | 1d? | 2005-04-22 | 2005-04-22 |  |  | -17d |  |
| 272 |  | Ratification of the final draft standard MEDs by the Sub-Team | 1d? | 2005-04-22 | 2005-04-22 |  |  | -17d |  |
| 273 | 2.5.5 | **Finalize recommendation of standard Fire Mapping MEDs** | 1d? | 2005-04-25 | 2005-04-25 | 266 |  | -17d |  |
| 274 |  | Create a report recommending the adoption of the draft standard MEDs | 1d? | 2005-04-25 | 2005-04-25 |  |  | -17d |  |
| 275 |  | Conduct a Sub-Team review of the report | 1d? | 2005-04-25 | 2005-04-25 |  |  | -17d |  |
| 276 |  | Submit the report to GSTOP-PM | 1d? | 2005-04-25 | 2005-04-25 |  |  | -17d |  |
| 277 | 2.6 | **Incident GIS Standard Data Sharing and Archiving Standards** | 8.42d? | 2005-03-16 | 2005-03-28 |  |  | 3.58d |  |
| 278 | 2.6.1 | **Develop requirements for GIS Standard Data Sharing and Archiving Standards SOPs** | 4.42d? | 2005-03-16 | 2005-03-22 |  |  | 3.58d |  |
| 279 | 2.6.1.1 | **Define Information Needs (What do we need to gather?)** | 2.42d? | 2005-03-16 | 2005-03-18 |  |  | 3.58d |  |
| 280 |  | Compile existing archiving standards in use (e.g. data format, transfer mode) | 1d? | 2005-03-16 | 2005-03-16 |  |  | 3.58d |  |

| ID | WBS | Task | Duration | Start | Finish | Predecessors | Complete | Total float | Constraint |
| --- | --- | --- | --- | --- | --- | --- | --- | --- | --- |
| 281 |  | Identify how archiving is done at present time by ICS, military, other incident responders, project-management | 0.17d? | 2005-03-17 | 2005-03-17 | 280 |  | 3.58d |  |
| 282 |  | Gather NARA, Records Management requirements (review policies, lawsuits) e.g. physical location, acceptable media, supporting documentation | 0.25d? | 2005-03-17 | 2005-03-17 | 281 |  | 3.58d |  |
| 283 |  | Determine the least common denominator (shapefile) or possibility of multiple formats | 1d? | 2005-03-17 | 2005-03-18 | 282 |  | 3.58d |  |
| 284 |  | Collect Information: Conduct literature review | 1d? | 2005-03-18 | 2005-03-21 | 279 |  | 3.58d |  |
| 285 |  | Conduct Analysis: Compile & Synthesize Requirements | 1d? | 2005-03-21 | 2005-03-22 | 284 |  | 3.58d |  |
| 286 | 2.6.2 | **Develop draft SOPs for GIS Standard Data Sharing and Archiving Standards** | 4d? | 2005-03-22 | 2005-03-28 | 278 |  | 3.58d |  |
| 287 |  | Develop Preliminary SOPs | 1d? | 2005-03-22 | 2005-03-23 |  |  | 3.58d |  |
| 288 |  | Sub-Team Review of SOP | 1d? | 2005-03-23 | 2005-03-24 | 287 |  | 3.58d |  |
| 289 |  | Revise, Edit Proposed SOP | 1d? | 2005-03-24 | 2005-03-25 | 288 |  | 3.58d |  |
| 290 |  | Submit to Project Manager for Team Review | 1d? | 2005-03-25 | 2005-03-28 | 289 |  | 3.58d |  |
| 291 | 2.7 | **Incident GIS Standard Documentation and Archiving** | 23d? | 2005-03-16 A | 2005-04-15 |  | 32% | -5d |  |
| 292 | 2.7.1 | **Develop requirements for GIS Standard Documentation and Archiving SOPs** | 20d? | 2005-03-16 A | 2005-04-12 |  | 54% | -2d |  |
| 293 | 2.7.1.1 | **Define Information Needs (What do we need to gather?)** | 18d? | 2005-03-16 A | 2005-04-08 |  | 59% | 0d |  |
| 294 |  | Compile existing archiving standards in use (e.g. data format, transfer mode) | 10d? | 2005-03-23 A | 2005-04-05 A |  | 100% |  |  |
| 295 |  | Identify how archiving is done at present time by ICS, military, other incident responders, project-management | 13d? | 2005-03-23 A | 2005-04-08 | 294 |  | 0d | finish no earlier than 2005-04-08 |
| 296 |  | ?? Gather NARA, Records Management requirements (review policies, lawsuits) e.g. physical location, acceptable media, supporting documentation | 1d | 2005-03-16 | 2005-03-16 |  |  | 6d |  |
| 297 |  | Determine the least common denominator (shapefile) or possibility of multiple formats | 10d? | 2005-03-23 A | 2005-04-05 A | 294, 295, 296 | 100% |  |  |
| 298 |  | Review Documentation Unit Leader Task book and Job Aid | 1d? | 2005-03-16 | 2005-03-16 |  |  | 6d |  |
| 299 |  | Conduct Analysis: Compile, Synthesize requirements | 1d? | 2005-04-11 | 2005-04-11 | 298, 293 |  | -11d |  |
| 300 |  | Document Preliminary Requirements Specifications | 1d? | 2005-04-12 | 2005-04-12 | 299 |  | -11d |  |
| 301 |  | Post subteam Requirements for GSTOP Team Review | 0d | 2005-04-12 | 2005-04-12 | 300 |  | -11d |  |
| 302 | 2.7.2 | **Develop draft SOPs for GIS Standard Documentation and Archiving** | 3d? | 2005-04-13 | 2005-04-15 | 292 |  | -11d |  |
| 303 |  | Develop Preliminary SOPs | 1d? | 2005-04-13 | 2005-04-13 |  |  | -11d |  |
| 304 |  | Sub-Team Review of SOP | 1d? | 2005-04-14 | 2005-04-14 | 303 |  | -11d |  |
| 305 |  | Revise, Edit Proposed SOP | 1d? | 2005-04-15 | 2005-04-15 | 304 |  | -11d |  |
| 306 |  | Submit to Project Manager for Team Review | 0d | 2005-04-15 | 2005-04-15 | 305 |  | -11d |  |
| 307 | 2.7.3 | **Conduct External Review of GIS Standard Data Sharing and Archiving Standards SOP requirements and draft SOPs** | 12d? | 2005-03-16 | 2005-03-31 |  |  | -2d |  |
| 308 |  | Design External Review of guidelines/requirements for GIS Standard Documentation and Archiving SOPs | 2d? | 2005-03-16 | 2005-03-17 |  |  | 2.5d |  |
| 309 |  | Post sample documents/SOPs for external review | 5d? | 2005-03-18 | 2005-03-24 | 308 |  | 2.5d |  |
| 310 |  | Conduct External review of Guidelines/Requirements and draft SOPs | 0.5d? | 2005-03-25 | 2005-03-25 | 309 |  | 2.5d |  |
| 311 |  | Edit draft guidelines/Requirements based on input | 1d? | 2005-03-16 | 2005-03-16 |  |  | 9d |  |
| 312 |  | Edit sample documents/SOPs based on input | 12d? | 2005-03-16 | 2005-03-31 |  |  | -2d |  |
| 313 | 2.7.4 | **Finalize recommendation of GIS Standard Documentation and Archiving** | 2d? | 2005-04-01 | 2005-04-04 | 307 |  | -2d |  |
| 314 |  | Create a report recommending the adoption of the standard | 1d? | 2005-04-01 | 2005-04-01 |  |  | -2d |  |
| 315 |  | Conduct a review of the report | 1d? | 2005-04-04 | 2005-04-04 | 314 |  | -2d |  |
| 316 |  | Submit the report to GSTOP-PM | 0d | 2005-04-04 | 2005-04-04 | 315 |  | -2d |  |
| 317 | 2.8 | **Incident GIS Transition Procedures** | 65d? | 2005-03-16 A | 2005-06-14 |  | 26% | 253d |  |
| 318 | 2.8.1 | **Develop requirements for GIS Transition Procedures** | 17d? | 2005-03-18 A | 2005-04-11 |  | 63% | -5d |  |
| 319 | 2.8.1.1 | **Define Information Needs (What do we need to gather?)** | 12d? | 2005-03-18 A | 2005-04-04 |  | 86% | 0d |  |
| 320 |  | Determine "universe" of transitions: (team to team); (team to unit); (team to archive) | 1d? | 2005-03-23 A | 2005-03-23 |  |  | -1d |  |
| 321 |  | Conduct interviews and compile procedures documents currently in use | 1d? | 2005-03-23 A | 2005-03-23 | 320 |  | 1d |  |
| 322 |  | Identify if existing procedures in use "somewhere out there" may be acceptible (e.g. NARA) | 12d? | 2005-03-18 A | 2005-04-04 A | 321 | 100% |  |  |
| 323 |  | Evaluate Procedures: Identify test procedures for documentation and archiving | 1d? | 2005-04-05 | 2005-04-05 | 319 |  | -7d |  |
| 324 |  | Conduct Analysis: Test and identify strengths/weaknesses of existing procedures | 1d? | 2005-04-06 | 2005-04-06 | 323 |  | -7d |  |
| 325 |  | Develop Preliminary Requirements Specifications | 1d? | 2005-04-07 | 2005-04-07 | 324 |  | -7d |  |
| 326 | 2.8.1.5 | **Review and Validate Requirements** | 2d? | 2005-04-08 | 2005-04-11 | 325 |  | -7d |  |
| 327 |  | Sub-Team Review of Requirements | 1d? | 2005-04-08 | 2005-04-08 |  |  | -7d |  |
| 328 |  | Revise, Edit requirements | 1d? | 2005-04-11 | 2005-04-11 | 327 |  | -7d |  |
| 329 |  | Submit to Project Manager for Team Review | 0d | 2005-04-11 | 2005-04-11 | 328 |  | -7d |  |
| 330 | 2.8.2 | **Develop Preliminary SOP’s** | 5d? | 2005-06-08 | 2005-06-14 | 372, 318 |  | 253d |  |
| 331 |  | Create draft GIS Transition SOPs | 1d? | 2005-06-08 | 2005-06-08 |  |  | 253d |  |
| 332 |  | Review draft GIS Transition SOPs | 1d? | 2005-06-09 | 2005-06-09 | 331 |  | 253d |  |
| 333 |  | Revise, Edit draft GIS Transition SOPs | 1d? | 2005-06-10 | 2005-06-10 | 332 |  | 253d |  |
| 334 |  | Submit to Project Manager for Team Review | 0d | 2005-06-10 | 2005-06-10 | 333 |  | 253d |  |
| 335 |  | Review Draft GIS Transition SOPs | 1d? | 2005-06-13 | 2005-06-13 | 334 |  | 253d |  |
| 336 |  | Revise, Edit GIS Transition SOPs | 1d? | 2005-06-14 | 2005-06-14 | 335 |  | 253d |  |
| 337 | 2.8.3 | **Conduct External Review of GIS Transition Procedures SOP requirements and draft SOPs** | 12d? | 2005-03-16 | 2005-03-31 |  |  | 290d |  |
| 338 |  | Design External Review of guidelines/requirements for GIS Transition Procedures | 2d? | 2005-03-16 | 2005-03-17 |  |  | 294.5d |  |
| 339 |  | Post sample documents/SOPs for external review | 5d? | 2005-03-18 | 2005-03-24 | 338 |  | 294.5d |  |
| 340 |  | Conduct External review of Guidelines/Requirements and draft SOPs | 0.5d? | 2005-03-25 | 2005-03-25 | 339 |  | 294.5d |  |
| 341 |  | Edit draft guidelines/Requirements based on input | 1d? | 2005-03-16 | 2005-03-16 |  |  | 301d |  |
| 342 |  | Edit sample documents/SOPs based on input | 12d? | 2005-03-16 | 2005-03-31 |  |  | 290d |  |
| 343 | 2.8.4 | **Finalize recommendation of GIS Transition Procedures** | 2d? | 2005-04-01 | 2005-04-04 | 337 |  | 290d |  |
| 344 |  | Create a report recommending the adoption of the standard | 1d? | 2005-04-01 | 2005-04-01 |  |  | 290d |  |
| 345 |  | Conduct a review of the report | 1d? | 2005-04-04 | 2005-04-04 | 344 |  | 290d |  |
| 346 |  | Submit the report to GSTOP-PM | 0d | 2005-04-04 | 2005-04-04 | 345 |  | 290d |  |
| 347 | 3 | **Agency Review of Incident GIS SOPs** | 185d? | 2005-05-16 | 2006-01-27 | 381 |  | -31d |  |
| 348 |  | Design common review processes for GIS SOP peer review | 1d? | 2005-05-16 | 2005-05-16 |  |  | 153d |  |
| 349 | 3.2 | **Review and Validate draft SOP’s** | 1d? | 2005-05-16 | 2005-05-16 |  |  | 153d |  |
| 350 |  | Review and Validate draft SOP’s for completeness | 0.5d? | 2005-05-16 | 2005-05-16 |  |  | 153.5d |  |

| ID | WBS | Task | Duration | Start | Finish | Predecessors | Complete | Total float | Constraint |
| --- | --- | --- | --- | --- | --- | --- | --- | --- | --- |
| 351 |  | Review and Validate draft SOP’s for GIS content | 1d? | 2005-05-16 | 2005-05-16 |  |  | 153d |  |
| 352 | 3.3 | **Agencies' review of Draft SOPs** | 182d? | 2005-05-16 | 2006-01-24 |  |  | -31d |  |
| 353 |  | Create a cover letter and response process | 1d? | 2005-05-16 | 2005-05-16 |  |  | -31d |  |
| 354 |  | Distribute draft SOPs for Agency review | 1d? | 2005-05-17 | 2005-05-17 | 353 |  | -31d |  |
| 355 |  | Review and Validate draft SOP’s | 180d | 2005-05-18 | 2006-01-24 | 354 |  | -31d |  |
| 356 | 3.4 | **Incorporate Feedback from reviewers** | 3d? | 2006-01-25 | 2006-01-27 | 352 |  | -31d |  |
| 357 |  | Consolidate reviewers' inputs | 1d? | 2006-01-25 | 2006-01-25 |  |  | -31d |  |
| 358 |  | Evaluate Feedback for inclusion in SOP revision | 1d? | 2006-01-26 | 2006-01-26 | 357 |  | -31d |  |
| 359 |  | Update draft SOPs for accepted feedback from reviewers | 1d? | 2006-01-27 | 2006-01-27 | 358 |  | -31d |  |
| 361 | 4 | **Field Test of Incident GIS SOPs (including business requirements)** | 1d? | 2005-05-16 | 2005-05-16 | 381 |  | 153d |  |
| 362 |  | Develop a list of GSTOP deliverable reviewers | 1d? | 2005-05-16 | 2005-05-16 |  |  | 153d |  |
| 363 | 4.2 | **Develop Quality Assurance and Field Test Plan** | 1d? | 2005-05-16 | 2005-05-16 |  |  | 153d |  |
| 364 |  | Develop survey instrument to capture field test feedback | 1d? | 2005-05-16 | 2005-05-16 |  |  | 153d |  |
| 365 | 4.3 | **Execute Quality Assurance and Field Test Plan** | 1d? | 2005-05-16 | 2005-05-16 |  |  | 153d |  |
| 366 |  | Conduct interviews with GISTs to measure success of Draft SOPs | 1d? | 2005-05-16 | 2005-05-16 |  |  | 153d |  |
| 367 |  | Conduct interviews with SIT Unit Leaders to measure success of Draft SOPs | 1d? | 2005-05-16 | 2005-05-16 |  |  | 153d |  |
| 368 |  | Collect written/survey results from the field test | 1d? | 2005-05-16 | 2005-05-16 |  |  | 153d |  |
| 369 |  | Analyze Quality Assurance and Field Test Plan Results | 1d? | 2005-05-16 | 2005-05-16 |  |  | 153d |  |
| 370 | 5 | **GSTOP Requirements Milestones** | 221d? | 2005-02-10 A | 2005-12-15 |  | 61% | 116d |  |
| 371 |  | MS1: Requirements for GIS SOPs are developed | 0d | 2005-03-31 | 2005-03-31 | 21, 94, 134, 176, 217, 277, 291, 329 |  | -55d | must finish on 2005-03-31 |
| 372 | 5.2 | **Develop template for GIS SOPs** | 84d? | 2005-02-10 A | 2005-06-07 |  | 62% | 253d |  |
| 373 |  | Review current formats and compile representative selections | 37d? | 2005-02-10 A | 2005-04-01 A |  | 100% |  |  |
| 374 |  | Itemize standard SOP content | 2d? | 2005-03-31 A | 2005-04-01 A | 373 | 100% |  |  |
| 375 |  | Review content for completeness | 10d? | 2005-04-04 A | 2005-04-15 | 374 |  | 0d | finish no earlier than 2005-04-15 |
| 376 |  | Design standard GIS SOP format | 1d? | 2005-04-18 | 2005-04-18 | 375 |  | -30d |  |
| 377 |  | Provide sample SOPs for publishing | 1d? | 2005-04-19 | 2005-04-19 | 376 |  | 286d |  |
| 378 |  | Mockup final GIS SOPs for GSTOP Team Review | 1d? | 2005-04-20 | 2005-04-20 | 377 |  | 286d |  |
| 379 |  | Review final GIS SOP mockup | 1d? | 2005-04-21 | 2005-04-21 | 378 |  | 286d |  |
| 380 |  | Final formatting and publication of draft SOPs for Field Test | 10d | 2005-05-25 | 2005-06-07 | 302, 53, 114, 153, 189, 253, 286 |  | -17.5d |  |
| 381 |  | MS2: Draft SOPs are produced and ready for Field Test | 0.5d? | 2005-05-13 | 2005-05-13 | 380 |  | -17.5d | must finish on 2005-05-13 |
| 382 |  | MS3: Requirements are reviewed and tested by business community | 0d | 2005-12-15 | 2005-12-15 | 361, 347 |  | -31d | must finish on 2005-12-15 |
| 384 | 6 | **Final Incident GIS SOPs** | 120d? | 2005-12-16 | 2006-06-01 | 382 |  | 1d |  |
| 385 |  | Determine what changes need to be made to the Incident GIS SOPs | 1d? | 2005-12-16 | 2005-12-16 |  |  | 120d |  |
| 386 |  | Update and finalize all Incident GIS SOPs | 1d? | 2005-12-16 | 2005-12-16 |  |  | 120d |  |
| 387 |  | MS5: GIS SOPs are finalized | 0d | 2006-05-15 | 2006-05-15 | 90, 130, 213, 273, 313, 343, 171 |  | 0d | must finish on 2006-05-15 |
| 388 |  | Deliver Final Incident GIS SOPs to Executive Committee | 0d | 2006-05-15 | 2006-05-15 | 387 |  | 14d |  |
| 389 |  | Deliver Final Incident GIS SOPs to Incident Based Automation Project | 0d | 2006-05-15 | 2006-05-15 | 387 |  | 14d |  |
| 390 | 6.6 | **Prepare delivery package for final SOPs to GTG** | 1d? | 2005-12-16 | 2005-12-16 |  |  | 120d |  |
| 391 |  | Prepare GIS SOP Implementation Plan | 1d? | 2005-12-16 | 2005-12-16 |  |  | 120d |  |
| 392 | 6.6.2 | **Prepare GIS SOP Change Management Plan** | 1d? | 2005-12-16 | 2005-12-16 |  |  | 120d |  |
| 393 |  | Develop GIS SOP Change Management Plan | 1d? | 2005-12-16 | 2005-12-16 |  |  | 120d |  |
| 394 |  | Review GIS SOP Change Management Plan | 1d? | 2005-12-16 | 2005-12-16 |  |  | 120d |  |
| 395 |  | MS6: Draft recommendation for SOP implementation | 0d | 2006-06-01 | 2006-06-01 |  |  | 0d | must finish on 2006-06-01 |
| 396 | 7 | **GSTOP Project Management** | 423d? | 2004-10-20 A | 2006-06-02 |  | 18% | 0d |  |
| 397 | 7.1 | **Establish Subteam Business Practices** | 120d? | 2004-10-20 A | 2005-04-05 |  |  | 303d |  |
| 398 |  | Review Business Practices Developed by Symbology SubTeam (communication, review process and change process) | 1d? | 2005-04-04 A | 2005-04-04 | 22 |  | 303d |  |
| 399 |  | Finalize Sub-Team business practices | 1d? | 2005-04-05 | 2005-04-05 | 398 |  | 303d |  |
| 400 |  | Complete Team Operating Principles for document management (standard title page, headers/footers, naming convention, document location, etc.) | 1d? | 2004-10-20 | 2004-10-20 |  |  | 422d |  |
| 401 |  | Establish a process for providing feedback to Wildland Fire Agency Management from the GSTOP team | 1d? | 2004-10-20 | 2004-10-20 |  |  | 422d |  |
| 402 | 7.3 | **Conduct Periodic Team Meetings** | 78d | 2005-01-25 A | 2005-05-12 |  | 33% | 276d |  |
| 403 |  | January Team Meeting (Portland) | 3d | 2005-01-25 A | 2005-01-27 A |  | 100% |  | start no earlier than 2005-01-25 |
| 404 |  | April Working Session (Denver) | 3d | 2005-04-26 | 2005-04-28 |  |  | 286d | start no earlier than 2005-04-26 |
| 405 |  | May Team Meeting (Denver) | 3d | 2005-05-10 | 2005-05-12 |  |  | 276d | start no earlier than 2005-05-10 |
| 406 | 7.4 | **Develop GIS SOP Implementation Plan** | 1d? | 2004-10-20 | 2004-10-20 |  |  | 422d |  |
| 407 |  | Develop and implement GSTOP SOP User education and distribution strategy | 1d? | 2004-10-20 | 2004-10-20 |  |  | 422d |  |
| 408 |  | Ensure incorporation of GSTOP deliverables into national and local training programs | 1d? | 2004-10-20 | 2004-10-20 |  |  | 422d |  |
| 409 | 7.5 | **Closeout GSTOP Project** | 1d? | 2006-06-02 | 2006-06-02 | 395 |  | 0d |  |
| 410 |  | Prepare GSTOP Team Recommendations | 1d? | 2006-06-02 | 2006-06-02 |  |  | 0d |  |
| 411 |  | Document Lessons Learned | 1d? | 2006-06-02 | 2006-06-02 |  |  | 0d |  |
| 412 |  | GSTOP Project Complete | 0d | 2006-06-02 | 2006-06-02 |  |  | 0d | finish no earlier than 2006-06-02 |
| 413 | 8 | **Implement GSTOP Project Communication Plan** | 356d? | 2004-10-20 A | 2006-03-01 |  | 3% | 67d |  |
| 414 | 8.1 | **Create processes and methods for communication to stakeholders** | 114d? | 2004-10-20 A | 2005-03-28 |  |  | 309d |  |
| 415 | 8.1.1 | **Establish communications with other projects/teams/agencies** | 1d? | 2004-10-20 | 2004-10-20 |  |  | 422d |  |
| 416 |  | Convey GSTOP deliverables to teams responsible for fire mapping tool development | 1d? | 2004-10-20 | 2004-10-20 |  |  | 422d |  |
| 417 |  | Establish interproject liaison and communication agreement and schedule with Incident-Based Automation project | 1d? | 2004-10-20 | 2004-10-20 |  |  | 422d |  |
| 418 |  | Establish interproject liaison and communication agreement and schedule with Fire Incident Mapping Tool project | 1d? | 2004-10-20 | 2004-10-20 |  |  | 422d |  |
| 419 |  | Establish interproject liaison and communication agreement and schedule with NWCG GIST position development and training effort | 1d? | 2004-10-20 | 2004-10-20 |  |  | 422d |  |
| 420 |  | Establish interproject liaison and communication agreement and schedule with NWCG DPRO training cirriculum revision effort | 1d? | 2004-10-20 | 2004-10-20 |  |  | 422d |  |
| 421 |  | Establish interproject liaison and communication agreement and schedule with SIT Unit Leader SME group | 1d? | 2004-10-20 | 2004-10-20 |  |  | 422d |  |
| 422 |  | Establish interproject liaison and communication agreement and schedule with NWCG Training WT | 1d? | 2004-10-20 | 2004-10-20 |  |  | 422d |  |

| ID | WBS | Task | Duration | Start | Finish | Predecessors | Complete | Total float | Constraint |
| --- | --- | --- | --- | --- | --- | --- | --- | --- | --- |
| 423 |  | Establish liaison relationships with Other All-Risk organizations involved with GIS SOP development | 1d? | 2004-10-20 | 2004-10-20 |  |  | 422d |  |
| 424 |  | Establish project status reporting processes | 1d? | 2004-10-20 | 2004-10-20 |  |  | 422d |  |
| 425 | 8.1.3 | **Establish GSTOP Project communications methods** | 114d? | 2004-10-20 A | 2005-03-28 |  |  | 309d |  |
| 426 |  | Establish team workspace on disaster help | 0d? | 2005-01-05 A | 2005-01-05 A |  | 100% |  |  |
| 427 |  | Find a storage location for GSTOP group review (NIFC site?) | 0d? | 2005-01-25 A | 2005-01-25 A |  | 100% |  |  |
| 428 |  | Establish GSTOP project webpages linked to GTG website | 1d? | 2005-03-28 A | 2005-03-28 |  |  | 309d |  |
| 429 |  | Establish process for information dissemination to Wildland Fire Agency Management via GACCs | 1d? | 2004-10-20 | 2004-10-20 |  |  | 422d |  |
| 430 |  | Establish process for reviewing and posting general project documents for view by project stakeholders | 1d? | 2004-10-20 | 2004-10-20 |  |  | 422d |  |
| 431 |  | Establish process for developing and maintaining FAQs for GSTOP users | 1d? | 2004-10-20 | 2004-10-20 |  |  | 422d |  |
| 432 |  | Establish process for developing and maintaining FAQ for business managers | 1d? | 2004-10-20 | 2004-10-20 |  |  | 422d |  |
| 433 |  | Develop a process for obtaining quantifiable feedback to evaluate the effectiveness of GSTOP communications efforts | 1d? | 2004-10-20 | 2004-10-20 |  |  | 422d |  |
| 434 | 8.2 | **Setup Project Briefings** | 2d? | 2005-01-25 A | 2005-01-26 |  |  | 352d |  |
| 435 |  | Determine the set of meetings at which updates for the GSTOP project will be presented | 1d? | 2005-01-25 A | 2005-01-25 |  |  | 352d |  |
| 436 |  | Schedule the presentations and all required logistics | 1d? | 2005-01-26 | 2005-01-26 | 435 |  | 352d |  |
| 437 | 8.3 | **Prepare Stakeholder Communications** | 1d? | 2004-10-20 | 2004-10-20 |  |  | 422d |  |
| 438 |  | Post general project documents for stakeholder view | 1d? | 2004-10-20 | 2004-10-20 |  |  | 422d |  |
| 439 |  | Develop GSTOP FAQs for users | 1d? | 2004-10-20 | 2004-10-20 |  |  | 422d |  |
| 440 |  | Develop GSTOP FAQs for business managers | 1d? | 2004-10-20 | 2004-10-20 |  |  | 422d |  |
| 441 |  | Develop GSTOP briefing(s) for GSTOP Sponsors | 1d? | 2004-10-20 | 2004-10-20 |  |  | 422d |  |
| 442 |  | Develop GSTOP briefing(s) for GSTOP Users | 1d? | 2004-10-20 | 2004-10-20 |  |  | 422d |  |
| 443 |  | Develop issue/white papers for Wildland Fire Agency Management | 1d? | 2004-10-20 | 2004-10-20 |  |  | 422d |  |
| 444 |  | Develop GSTOP briefing(s) for Agency Technical community | 1d? | 2004-10-20 | 2004-10-20 |  |  | 422d |  |
| 445 |  | Develop standard form informational letters for general use throughout the project | 1d? | 2004-10-20 | 2004-10-20 |  |  | 422d |  |
| 446 |  | Develop GSTOP overview letter | 1d? | 2004-10-20 | 2004-10-20 |  |  | 422d |  |
| 447 |  | Develop GSTOP introduction letter soliciting input from other all-risk oganizations involved with GIS SOP development (include weblink to GSTOP project pages) | 1d? | 2004-10-20 | 2004-10-20 |  |  | 422d |  |
| 448 | 8.4 | **Conduct project briefings to stakeholders** | 356d? | 2004-10-20 A | 2006-03-01 |  | 11% | 67d |  |
| 449 | 8.4.1 | **Conduct briefings for project sponsors (when and where?)** | 251d? | 2005-03-16 A | 2006-03-01 |  | 17% | 67d |  |
| 450 | 8.4.1.1 | **Report to Executive Committee** | 251d? | 2005-03-16 A | 2006-03-01 |  | 17% | 67d |  |
| 451 |  | 2005 Q1 Executive Briefing | 1d | 2005-03-16 A | 2005-03-16 A |  | 100% |  |  |
| 452 |  | 2005 Q2 Executive Briefing | 1d | 2005-06-01 | 2005-06-01 |  |  | 262d | start no earlier than 2005-06-01 |
| 453 |  | 2005 Q3 Executive Briefing | 1d? | 2005-09-01 | 2005-09-01 |  |  | 196d | start no earlier than 2005-09-01 |
| 454 |  | 2005 Q4 Executive Briefing | 1d? | 2005-12-01 | 2005-12-01 |  |  | 131d | start no earlier than 2005-12-01 |
| 455 |  | 2006 Q1 Executive Briefing | 1d? | 2006-03-01 | 2006-03-01 |  |  | 67d | start no earlier than 2006-03-01 |
| 456 |  | 2006 Q2 Executive Briefing | 1d | 2005-06-01 | 2005-06-01 |  |  | 262d | start no earlier than 2005-06-01 |
| 457 | 8.4.2 | **Conduct project briefings at GSTOP SOP User community meetings (when and where?)** | 1d? | 2005-11-01 | 2005-11-01 |  |  | 153d |  |
| 458 |  | SIT Unit Leader SME meeting (where) | 1d? | 2005-11-01 | 2005-11-01 |  |  | 153d | start no earlier than 2005-11-01 |
| 459 |  | Conduct project briefings at Wildland Fire Agency Management business community meetings and conferences and agency meetings (when and where?) | 0.5d? | 2004-10-20 | 2004-10-20 |  |  | 422.5d |  |
| 460 | 8.4.4 | **Conduct project briefings for Agency Technocal community (when and where?)** | 1d? | 2006-01-02 | 2006-01-02 |  |  | 109d |  |
| 461 |  | Agency IRM meeting (where?) | 1d? | 2006-01-02 | 2006-01-02 |  |  | 109d | start no earlier than 2006-01-02 |
| 462 |  | Attend Fire Incident Mapping Tool beta test courses | 1d? | 2004-10-20 | 2004-10-20 |  |  | 422d |  |

## Version 2 (data date 2005-03-23, saved 2005-04-20, file GSTOP Project Timeline04112005.mpp)

Last finish stays 2006-06-02. Complete tasks 36 → 37.

Added:

| ID | Task | Duration | Start | Finish | Constraint | Resources |
| --- | --- | --- | --- | --- | --- | --- |
| 423 | Establish liaison relationships with Regional GIS coordinators | 26d? | 2005-04-04 | 2005-05-09 | finish no earlier than 2005-05-09 | Business Lead |
| 429 | **Establish process for information dissemination to Wildland Fire Agency Management** | 1d? | 2004-10-20 | 2004-10-20 |  | Business Lead |
| 430 | Confirm which segment of "management" we need to communicate with when about what. | 0.33d? | 2004-10-20 | 2004-10-20 |  | Business Lead; Project Mgr; Susan Goodman |
| 431 | Design communciations and schedule for dissemination to Fire GIS qulaified folks | 1d? | 2004-10-20 | 2004-10-20 |  |  |
| 432 | Complete distribution list of all regional ckey contacts for Fire GIS qualified staff | 1d? | 2004-10-20 | 2004-10-20 |  |  |
| 433 | Advise regional Fire GIS contacts re: GSTOP communciation plan and schedule | 1d? | 2004-10-20 | 2004-10-20 |  |  |
| 434 | Adjust GSTOP Communciation plan for feedback | 1d? | 2004-10-20 | 2004-10-20 |  |  |
| 436 | Design communication and schedule (what messages, for whom when). | 0.33d? | 2004-10-20 | 2004-10-20 |  | Business Lead; Project Mgr; Susan Goodman |
| 437 | Advise NICC Coordinator re: planned communciations for GSTOP field test and rollout | 1d? | 2004-10-20 | 2004-10-20 |  |  |

Removed: 418 Establish interproject liaison and communication agreement and schedule with Fire Incident Mapping Tool project

Changed:

| ID | Task | Start | Finish | Duration | Complete | Total float | Other |
| --- | --- | --- | --- | --- | --- | --- | --- |
| 370 | **GSTOP Requirements Milestones** |  |  |  | 61% → 77% |  |  |
| 372 | **Develop template for GIS SOPs** |  |  |  | 62% → 78% |  |  |
| 375 | Review content for completeness |  | 2005-04-15 A |  | 0% → 100% | 0d → none |  |
| 396 | **GSTOP Project Management** |  |  |  | 18% → 17% |  |  |
| 410 | Convey final GSTOP deliverables to fire mapping tool development team (ESRI) | 2004-10-20 → 2006-06-02 (+590d) | 2004-10-20 → 2006-06-02 (+590d) |  |  | 422d → 0d | was named Convey GSTOP deliverables to teams responsible for fire mapping tool development |
| 414 | **Implement GSTOP Project Communication Plan** |  |  |  | 3% → 0% |  |  |
| 415 | **Create processes and methods for communication to stakeholders** |  | 2005-03-28 → 2005-05-09 (+42d) | 114d? → 144d? |  | 309d → 279d |  |
| 416 | **Establish communications with other projects/teams/agencies** | 2004-10-20 → 2004-12-01 A (+42d) | 2004-10-20 → 2005-05-09 (+201d) | 1d? → 114d? |  | 422d → 279d |  |
| 417 | Establish interproject liaison and communication agreement and schedule with Incident-Based Automation project | 2004-10-20 → 2004-12-01 A (+42d) | 2004-10-20 → 2004-12-01 (+42d) |  |  | 422d → 392d | constraint none → start no earlier than 2004-12-01; resources none → Project Mgr |
| 418 | Establish interproject liaison and communication agreement and schedule with NWCG GIST position development and training effort | 2004-10-20 → 2005-04-04 A (+166d) | 2004-10-20 → 2005-05-09 (+201d) | 1d? → 26d |  | 422d → 279d | resources none → Business Lead |
| 419 | Establish interproject liaison and communication agreement and schedule with NWCG DPRO training cirriculum revision effort | 2004-10-20 → 2005-04-04 A (+166d) | 2004-10-20 → 2005-05-09 (+201d) | 1d? → 26d |  | 422d → 279d | resources none → Business Lead |
| 420 | Establish interproject liaison and communication agreement and schedule with SIT Unit Leader SME group | 2004-10-20 → 2005-04-04 A (+166d) | 2004-10-20 → 2005-05-09 (+201d) | 1d? → 26d |  | 422d → 279d | resources none → Business Lead |
| 421 | Establish interproject liaison and communication agreement and schedule with NWCG Training WT | 2004-10-20 → 2005-04-04 A (+166d) | 2004-10-20 → 2005-05-09 (+201d) | 1d? → 26d |  | 422d → 279d |  |
| 422 | Establish liaison relationships with Other All-Risk organizations involved with GIS SOP development [NIIMS Group,Department of Homeland Security (DHS),FEMA] | 2004-10-20 → 2005-02-15 A (+118d) | 2004-10-20 → 2005-05-09 (+201d) | 1d? → 60d? |  | 422d → 279d | was named Establish liaison relationships with Other All-Risk organizations involved with GIS SOP development; constraint none → finish no earlier than 2005-05-09 |
| 424 | Establish project status reporting processes | 2004-10-20 → 2004-12-06 A (+47d) | 2004-10-20 → 2004-12-06 (+47d) |  |  | 422d → 389d |  |
| 425 | **Establish GSTOP Project communications methods** |  | 2005-03-28 → 2005-04-29 (+32d) | 114d? → 138d? |  | 309d → 285d |  |
| 428 | Establish GSTOP project webpages linked to GTG website | 2005-03-28 A → 2005-04-29 A (+32d) | 2005-03-28 → 2005-04-29 (+32d) |  |  | 309d → 285d | resources none → Project Mgr |
| 435 | **Establish process for information dissemination to Incident Management Teams via GACCs** |  |  |  |  |  | was named Establish process for information dissemination to Wildland Fire Agency Management via GACCs; resources none → Business Lead |

## Version 3 (data date 2005-03-23, saved 2005-09-29, file GSTOP Project Timeline05202005.mpp)

Last finish stays 2006-06-02. Complete tasks 37 → 44.

Added:

| ID | Task | Duration | Start | Finish | Constraint | Resources |
| --- | --- | --- | --- | --- | --- | --- |
| 429 | Identify Website Content | 8d? | 2005-06-01 | 2005-06-10 | start no earlier than 2005-06-01 | Project Mgr |

Removed: 404 April Working Session (Denver)

Changed:

| ID | Task | Start | Finish | Duration | Complete | Total float | Other |
| --- | --- | --- | --- | --- | --- | --- | --- |
| 347 | **Agency Review of Incident GIS SOPs** | 2005-05-16 → 2005-06-07 (+22d) | 2006-01-27 → 2006-02-20 (+24d) |  |  | -31d → -167d |  |
| 348 | Design common review processes for GIS SOP peer review | 2005-05-16 → 2005-06-07 (+22d) | 2005-05-16 → 2005-06-07 (+22d) |  |  | 153d → 17d |  |
| 349 | **Review and Validate draft SOP’s** | 2005-05-16 → 2005-06-07 (+22d) | 2005-05-16 → 2005-06-07 (+22d) |  |  | 153d → 17d |  |
| 350 | Review and Validate draft SOP’s for completeness | 2005-05-16 → 2005-06-07 (+22d) | 2005-05-16 → 2005-06-07 (+22d) |  |  | 153.5d → 17.5d |  |
| 351 | Review and Validate draft SOP’s for GIS content | 2005-05-16 → 2005-06-07 (+22d) | 2005-05-16 → 2005-06-07 (+22d) |  |  | 153d → 17d |  |
| 352 | **Agencies' review of Draft SOPs** | 2005-05-16 → 2005-06-07 (+22d) | 2006-01-24 → 2006-02-15 (+22d) |  |  | -31d → -167d |  |
| 353 | Create a cover letter and response process | 2005-05-16 → 2005-06-07 (+22d) | 2005-05-16 → 2005-06-07 (+22d) |  |  | -31d → -167d |  |
| 354 | Distribute draft SOPs for Agency review | 2005-05-17 → 2005-06-08 (+22d) | 2005-05-17 → 2005-06-08 (+22d) |  |  | -31d → -167d |  |
| 355 | Review and Validate draft SOP’s | 2005-05-18 → 2005-06-09 (+22d) | 2006-01-24 → 2006-02-15 (+22d) |  |  | -31d → -167d |  |
| 356 | **Incorporate Feedback from reviewers** | 2006-01-25 → 2006-02-16 (+22d) | 2006-01-27 → 2006-02-20 (+24d) |  |  | -31d → -167d |  |
| 357 | Consolidate reviewers' inputs | 2006-01-25 → 2006-02-16 (+22d) | 2006-01-25 → 2006-02-16 (+22d) |  |  | -31d → -167d |  |
| 358 | Evaluate Feedback for inclusion in SOP revision | 2006-01-26 → 2006-02-17 (+22d) | 2006-01-26 → 2006-02-17 (+22d) |  |  | -31d → -167d |  |
| 359 | Update draft SOPs for accepted feedback from reviewers | 2006-01-27 → 2006-02-20 (+24d) | 2006-01-27 → 2006-02-20 (+24d) |  |  | -31d → -167d |  |
| 361 | **Field Test of Incident GIS SOPs (including business requirements)** | 2005-05-16 → 2005-06-07 (+22d) | 2005-05-16 → 2005-06-07 (+22d) |  |  | 153d → 17d |  |
| 362 | Develop a list of GSTOP deliverable reviewers | 2005-05-16 → 2005-06-07 (+22d) | 2005-05-16 → 2005-06-07 (+22d) |  |  | 153d → 17d |  |
| 363 | **Develop Quality Assurance and Field Test Plan** | 2005-05-16 → 2005-06-07 (+22d) | 2005-05-16 → 2005-06-07 (+22d) |  |  | 153d → 17d |  |
| 364 | Develop survey instrument to capture field test feedback | 2005-05-16 → 2005-06-07 (+22d) | 2005-05-16 → 2005-06-07 (+22d) |  |  | 153d → 17d |  |
| 365 | **Execute Quality Assurance and Field Test Plan** | 2005-05-16 → 2005-06-07 (+22d) | 2005-05-16 → 2005-06-07 (+22d) |  |  | 153d → 17d |  |
| 366 | Conduct interviews with GISTs to measure success of Draft SOPs | 2005-05-16 → 2005-06-07 (+22d) | 2005-05-16 → 2005-06-07 (+22d) |  |  | 153d → 17d |  |
| 367 | Conduct interviews with SIT Unit Leaders to measure success of Draft SOPs | 2005-05-16 → 2005-06-07 (+22d) | 2005-05-16 → 2005-06-07 (+22d) |  |  | 153d → 17d |  |
| 368 | Collect written/survey results from the field test | 2005-05-16 → 2005-06-07 (+22d) | 2005-05-16 → 2005-06-07 (+22d) |  |  | 153d → 17d |  |
| 369 | Analyze Quality Assurance and Field Test Plan Results | 2005-05-16 → 2005-06-07 (+22d) | 2005-05-16 → 2005-06-07 (+22d) |  |  | 153d → 17d |  |
| 370 | **GSTOP Requirements Milestones** |  | 2005-12-15 → 2005-07-01 (-167d) | 221d? → 101d? | 77% → 99% | 116d → 120d |  |
| 372 | **Develop template for GIS SOPs** |  | 2005-06-07 A |  | 78% → 100% | 253d → none |  |
| 376 | Design standard GIS SOP format | 2005-04-18 A | 2005-04-18 A |  | 0% → 100% | -30d → none |  |
| 377 | Provide sample SOPs for publishing | 2005-04-19 A | 2005-04-19 A |  | 0% → 100% | 286d → none |  |
| 378 | Mockup final GIS SOPs for GTG Team Review | 2005-04-20 A | 2005-04-20 A |  | 0% → 100% | 286d → none | was named Mockup final GIS SOPs for GSTOP Team Review |
| 379 | Review final GIS SOP mockup | 2005-04-21 A | 2005-04-21 A |  | 0% → 100% | 286d → none |  |
| 380 | Final formatting and publication of draft SOPs for Field Test | 2005-05-25 A | 2005-06-07 A |  | 0% → 100% | -17.5d → none |  |
| 381 | MS2: Draft SOPs are produced and ready for Field Test | 2005-05-13 A | 2005-05-13 → 2005-06-06 A (+24d) | 0.5d? → 16.5d? | 0% → 100% | -17.5d → none |  |
| 383 | MS3: Requirements are reviewed and tested by business community | 2005-12-15 → 2005-07-01 A (-167d) | 2005-12-15 → 2005-07-01 (-167d) |  |  | -31d → 120d |  |
| 385 | **Final Incident GIS SOPs** | 2005-12-16 → 2005-07-01 (-168d) |  | 120d? → 240d? |  |  |  |
| 386 | Determine what changes need to be made to the Incident GIS SOPs | 2005-12-16 → 2005-07-01 (-168d) | 2005-12-16 → 2005-07-01 (-168d) |  |  | 120d → 240d |  |
| 387 | Update and finalize all Incident GIS SOPs | 2005-12-16 → 2005-07-01 (-168d) | 2005-12-16 → 2005-07-01 (-168d) |  |  | 120d → 240d |  |
| 391 | **Prepare delivery package for final SOPs to GTG** | 2005-12-16 → 2005-07-01 (-168d) | 2005-12-16 → 2005-07-01 (-168d) |  |  | 120d → 240d |  |
| 392 | Prepare GIS SOP Implementation Plan | 2005-12-16 → 2005-07-01 (-168d) | 2005-12-16 → 2005-07-01 (-168d) |  |  | 120d → 240d |  |
| 393 | **Prepare GIS SOP Change Management Plan** | 2005-12-16 → 2005-07-01 (-168d) | 2005-12-16 → 2005-07-01 (-168d) |  |  | 120d → 240d |  |
| 394 | Develop GIS SOP Change Management Plan | 2005-12-16 → 2005-07-01 (-168d) | 2005-12-16 → 2005-07-01 (-168d) |  |  | 120d → 240d |  |
| 395 | Review GIS SOP Change Management Plan | 2005-12-16 → 2005-07-01 (-168d) | 2005-12-16 → 2005-07-01 (-168d) |  |  | 120d → 240d |  |
| 397 | **GSTOP Project Management** |  |  |  | 17% → 40% |  |  |
| 403 | **Conduct Periodic Team Meetings** |  | 2005-05-12 A |  | 33% → 100% | 276d → none |  |
| 405 | May Team Meeting (Denver) | 2005-05-10 A | 2005-05-12 A |  | 0% → 100% | 276d → none |  |
| 415 | **Create processes and methods for communication to stakeholders** |  | 2005-05-09 → 2005-06-10 (+32d) | 144d? → 168d? |  | 279d → 255d |  |
| 425 | **Establish GSTOP Project communications methods** |  | 2005-04-29 → 2005-06-10 (+42d) | 138d? → 168d? |  | 285d → 255d |  |
| 428 | **Establish GSTOP project webpages linked to GTG website** | 2005-04-29 A → 2005-06-01 (+33d) | 2005-04-29 → 2005-06-10 (+42d) | 1d? → 8d? |  | 285d → 255d |  |

## Version 4 (data date 2005-03-23, saved 2006-04-28, file 2006_0111_GSTOP Project Timeline.mpp)

Last finish 2006-06-02 → 2006-06-30 (+28d). Complete tasks 44 → 296.

Added:

| ID | Task | Duration | Start | Finish | Predecessors | Constraint | Resources |
| --- | --- | --- | --- | --- | --- | --- | --- |
| 383 | Prep Final Text | 3d? | 2006-01-17 A | 2006-01-19 A |  | start no earlier than 2006-01-17 | GSTOP Team |
| 384 | Prep map product examples graphics with annotation, for web and hardcopy | 11d? | 2006-01-20 A | 2006-02-03 A | 383 |  | John Guthrie |
| 385 | Update MEDs | 10d? | 2006-01-19 A | 2006-02-01 A |  | start no earlier than 2006-01-19 | John Guthrie |
| 386 | Prep symbols graphics | 9d? | 2006-01-20 A | 2006-02-01 A |  | start no earlier than 2006-01-20 | Ken |
| 387 | Executive Summary and Introduction | 9d? | 2006-01-20 A | 2006-02-01 A |  | finish no earlier than 2006-02-01 | Business Lead |
| 388 | Final Draft SOP's Version 3 | 2d? | 2006-01-20 A | 2006-01-23 A |  |  | Yvonne |
| 389 | GTG Executive Committee Review | 3d? | 2006-02-14 A | 2006-02-16 A |  | start no earlier than 2006-02-14 | GTG |
| 390 | BLM Edit and Layout | 25d? | 2006-03-06 | 2006-04-07 |  | start no earlier than 2006-03-06 | BLM |
| 391 | Final Release to Web | 13d? | 2006-05-16 | 2006-06-01 |  | start no earlier than 2006-05-16 |  |
| 400 | Change Management Form | 1d? | 2005-07-01 | 2005-07-01 |  |  |  |
| 401 | Change Management Form on Internet | 1d? | 2005-07-01 | 2005-07-01 |  |  |  |
| 409 | **Conduct Periodic Conference Calls** | 284d? | 2004-10-20 | 2005-11-21 |  |  |  |
| 410 | Conference Call | 1d? | 2005-10-12 | 2005-10-12 |  | start no earlier than 2005-10-12 |  |
| 411 | Conference Call | 1d? | 2005-11-21 | 2005-11-21 |  | start no earlier than 2005-11-21 |  |
| 412 | Conference Call | 1d? | 2004-10-20 | 2004-10-20 |  |  |  |
| 416 | January Team Meeting (Denver) | 3d? | 2006-01-17 A | 2006-01-19 A |  | finish no earlier than 2006-01-19 |  |
| 424 | GSTOP Letters, Plaques, Coupons | 1d? | 2006-06-02 | 2006-06-02 |  |  |  |

Removed: 386 Determine what changes need to be made to the Incident GIS SOPs; 387 Update and finalize all Incident GIS SOPs; 389 Deliver Final Incident GIS SOPs to Executive Committee

Changed:

| ID | Task | Start | Finish | Complete | Total float |
| --- | --- | --- | --- | --- | --- |
| 20 | **GSTOP Requirements** |  | 2005-06-16 A | 18% → 100% | 251d → none |
| 21 | **Incident GIS Standard Symbology** |  | 2005-06-16 A | 19% → 100% | -54d → none |
| 22 | **Establish Symbols Sub-Team business practices** |  | 2005-04-01 A | 0% → 100% | 0d → none |
| 23 | **Develop a Symbol Sub-team Communication Plan** |  | 2005-03-25 A | 0% → 100% | 4d → none |
| 24 | Define ground-rules for Sub-Team (internal) communication |  | 2005-03-25 A | 0% → 100% | 4d → none |
| 25 | Define ground-rules for communication between the Symbol Sub-Team and other GSTOP Sub-Teams |  | 2005-03-25 A | 0% → 100% | 4d → none |
| 26 | Define ground rules for communication between the Sub-Team and entities outside of the GSTOP Project |  | 2005-03-25 A | 0% → 100% | 4d → none |
| 27 | Establish a process and schedule for Sub-Team (internal) progress report updates |  | 2005-03-25 A | 0% → 100% | 4d → none |
| 28 | Establish a process and schedule for Sub-Team progress report updates to the GSTOP Team |  | 2005-03-25 A | 0% → 100% | 4d → none |
| 29 | **Establish Review Processes** |  | 2005-04-01 A | 0% → 100% | 0d → none |
| 30 | Establish a process for Sub-Team (internal) review of potential symbols |  | 2005-04-01 A | 0% → 100% | 0d → none |
| 31 | Establish a process for Sub-Team (internal) review of the draft standard symbols |  | 2005-04-01 A | 0% → 100% | 0d → none |
| 32 | Establish a process for peer reviews |  | 2005-04-01 A | 0% → 100% | 0d → none |
| 33 | Establish a process for periodic GSTOP Team reviews |  | 2005-04-01 A | 0% → 100% | 0d → none |
| 34 | Establish a process for reviewing the final report |  | 2005-04-01 A | 0% → 100% | 0d → none |
| 35 | **Establish Change processes** |  | 2005-04-01 A | 0% → 100% | 0d → none |
| 36 | Establish a process for additions/deletions of potential symbols mid-stream through the Project |  | 2005-04-01 A | 0% → 100% | -58d → none |
| 37 | Establish a change process for the additions/deletion of standard symbols after the final recommendation has been submitted and prior to completion of the GSTOP project |  | 2005-04-01 A | 0% → 100% | -58d → none |
| 38 | Establish a change process for the additions/deletion of standard symbols after the completion of the GSTOP project |  | 2005-04-01 A | 0% → 100% | -1d → none |
| 39 | **Develop GIS Standard Symbology SOP Requirements** |  | 2005-04-08 A | 0% → 100% | -5d → none |
| 40 | **Establish symbol evaluation methods** | 2005-03-17 A | 2005-04-01 A | 0% → 100% | -7d → none |
| 41 | Define method for evaluating marker symbols | 2005-03-17 A | 2005-04-01 A | 0% → 100% | -7d → none |
| 42 | Define method for evaluating line symbols | 2005-03-17 A | 2005-04-01 A | 0% → 100% | -7d → none |
| 43 | Define method for evaluating fill symbols | 2005-03-17 A | 2005-04-01 A | 0% → 100% | -7d → none |
| 44 | Conduct a final review of evaluation methods | 2005-03-17 A | 2005-04-01 A | 0% → 100% | -7d → none |
| 45 | **Define criteria for the acceptance of symbols as standards** | 2005-03-17 A | 2005-04-08 A | 0% → 100% | -12d → none |
| 46 | Develop acceptance criteria for marker symbols | 2005-03-17 A | 2005-04-08 A | 0% → 100% | -12d → none |
| 47 | Develop acceptance criteria for line symbols | 2005-03-17 A | 2005-04-08 A | 0% → 100% | -12d → none |
| 48 | Develop acceptance criteria for fill symbols | 2005-03-17 A | 2005-04-08 A | 0% → 100% | -12d → none |
| 49 | Conduct a final review of selection criteria | 2005-03-17 A | 2005-04-08 A | 0% → 100% | -12d → none |
| 50 | **Establish file format for symbols** |  | 2005-04-01 A | 0% → 100% | 0d → none |
| 51 | Define acceptable formats of symbols for evaluation |  | 2005-04-01 A | 0% → 100% | 0d → none |
| 52 | Define format of recommended standard symbols |  | 2005-04-01 A | 0% → 100% | 0d → none |
| 53 | **Develop Draft GIS Standard Symbology SOPs** |  | 2005-05-24 A | 81% → 100% | -38d → none |
| 54 | **Develop a list of symbols to be evaluated for acceptance as draft standards** |  | 2005-04-20 A | 94% → 100% | -20d → none |
| 57 | Collect Fire mapping symbols suggestions from the BIA | 2005-04-11 A | 2005-04-19 A | 0% → 100% | -55d → none |
| 59 | Collect Fire mapping symbols from HSA (FEMA), FAA, and DOD | 2005-04-11 A | 2005-04-19 A | 0% → 100% | -54d → none |
| 60 | Document potential sources for additional fire mapping symbols | 2005-04-11 A | 2005-04-11 A | 0% → 100% | -48d → none |
| 61 | Compile symbols into a single potential symbol set | 2005-04-20 A | 2005-04-20 A | 0% → 100% | -55d → none |
| 62 | **Determine the draft standard marker symbols** | 2005-04-21 A | 2005-05-02 A | 0% → 100% | -55d → none |
| 63 | Evaluate each potential marker symbol against the marker symbol selection criteria | 2005-04-21 A | 2005-04-21 A | 0% → 100% | -48d → none |
| 64 | Selection the draft standard marker symbols | 2005-04-21 A | 2005-04-21 A | 0% → 100% | -48d → none |
| 65 | Conduct a completeness review of the draft standard marker symbols | 2005-04-21 A | 2005-05-02 A | 0% → 100% | -55d → none |
| 66 | **Determine the draft standard line symbols** | 2005-04-21 A | 2005-05-02 A | 0% → 100% | -55d → none |
| 67 | Evaluate each potential line symbol against the line symbol selection criteria | 2005-04-21 A | 2005-04-21 A | 0% → 100% | -48d → none |
| 68 | Select the draft standard line symbols | 2005-04-21 A | 2005-04-21 A | 0% → 100% | -48d → none |
| 69 | Conduct a completeness review of the draft standard line symbols | 2005-04-21 A | 2005-05-02 A | 0% → 100% | -55d → none |
| 70 | **Determine the draft standard fill symbols** | 2005-04-21 A | 2005-05-02 A | 0% → 100% | -55d → none |
| 71 | Evaluate each potential fill symbol against the fill symbol selection criteria | 2005-04-21 A | 2005-04-21 A | 0% → 100% | -48d → none |
| 72 | Select the draft standard fill symbols | 2005-04-21 A | 2005-04-21 A | 0% → 100% | -48d → none |
| 73 | Conduct a completeness review of the draft standard fill symbols | 2005-04-21 A | 2005-05-02 A | 0% → 100% | -55d → none |
| 74 | **Conduct initial peer review of the draft standard marker, line, and fill symbols** | 2005-05-03 A | 2005-05-24 A | 0% → 100% | -55d → none |
| 75 | Prepare draft standard symbols for initial peer review | 2005-05-03 A | 2005-05-03 A | 0% → 100% | -55d → none |
| 76 | Submit the draft standard symbols to the 5 federal fire management agencies and State agencies via the NWCG Geospatial Task Group (GTG); and to the HSA (FEMA), FAA, DOD, and GSTOP Team for peer review | 2005-05-03 A | 2005-05-03 A | 0% → 100% | -55d → none |
| 77 | Review draft Standard Symbols | 2005-05-04 A | 2005-05-10 A | 0% → 100% | -45d → none |
| 78 | Review feedback of initial peer review | 2005-05-18 A | 2005-05-19 A | 0% → 100% | -55d → none |
| 79 | Identify required changes to draft standard symbols based on the initial peer review feedback | 2005-05-20 A | 2005-05-23 A | 0% → 100% | -55d → none |
| 80 | Make required changes, as identified, to draft standard symbols | 2005-05-24 A | 2005-05-24 A | 0% → 100% | -55d → none |
| 81 | Prepare draft SOPs for field review | 2005-04-19 A | 2005-04-19 A | 0% → 100% | -13d → none |
| 82 | **Conduct final peer review of the draft standard marker, line and fill symbols** | 2005-05-25 A | 2005-06-16 A | 0% → 100% | -55d → none |
| 83 | Prepare draft standard symbols for final peer review | 2005-05-25 A | 2005-05-25 A | 0% → 100% | -55d → none |
| 84 | Submit the draft standard symbols to the 5 federal fire management agencies and State agencies via the NWCG Geospatial Task Group (GTG); and to the HSA (FEMA), FAA, DOD, and GSTOP Team for peer review | 2005-05-25 A | 2005-05-25 A | 0% → 100% | -55d → none |
| 85 | Review draft Standard Symbols | 2005-05-26 A | 2005-06-08 A | 0% → 100% | -55d → none |
| 86 | Review feedback of the final peer review | 2005-06-09 A | 2005-06-09 A | 0% → 100% | -55d → none |
| 87 | Identify required changes to draft standard symbols based on the final peer review feedback | 2005-06-10 A | 2005-06-13 A | 0% → 100% | -55d → none |
| 88 | Make required changes, as identified, to draft standard symbols | 2005-06-14 A | 2005-06-15 A | 0% → 100% | -55d → none |
| 89 | Ratify the final draft standard symbols | 2005-06-16 A | 2005-06-16 A | 0% → 100% | -55d → none |
| 90 | **Finalize recommendation of standard Fire Mapping symbols** | 2005-03-16 A | 2005-03-17 A | 0% → 100% | 10d → none |
| 91 | Create a report recommending the adoption of the draft standard symbols | 2005-03-16 A | 2005-03-16 A | 0% → 100% | 10d → none |
| 92 | Conduct a review of the report | 2005-03-17 A | 2005-03-17 A | 0% → 100% | 10d → none |

| ID | Task | Start | Finish | Complete | Total float |
| --- | --- | --- | --- | --- | --- |
| 93 | Submit the report to GSTOP-PM | 2005-03-17 A | 2005-03-17 A | 0% → 100% | 10d → none |
| 94 | **Incident GIS Standard Naming Conventions** |  | 2005-05-17 A | 21% → 100% | -28d → none |
| 95 | **Develop GIS Naming Convention/Directory Structure Subteam Practices** | 2005-03-16 A | 2005-03-16 A | 0% → 100% | 11d → none |
| 96 | Set objectives for work plan | 2005-03-16 A | 2005-03-16 A | 0% → 100% | 11d → none |
| 97 | Define ground rules for sub team | 2005-03-16 A | 2005-03-16 A | 0% → 100% | 11d → none |
| 98 | Define common ground with other sub teams | 2005-03-16 A | 2005-03-16 A | 0% → 100% | 11d → none |
| 99 | **Develop GIS Standard Naming Convention SOP Requirements** |  | 2005-04-20 A | 53% → 100% | -9d → none |
| 100 | Define Information Needs (What do we need to gather?) | 2005-03-16 A | 2005-03-16 A | 0% → 100% | -25d → none |
| 101 | Collect existing naming and filing conventions from GIST's attached to IMT's | 2005-03-17 A | 2005-03-17 A | 0% → 100% | -25d → none |
| 102 | **Conduct Analysis** | 2005-03-16 A | 2005-03-17 A | 0% → 100% | -25d → none |
| 103 | Review strengths & weaknesses of existing methodologies | 2005-03-16 A | 2005-03-16 A | 0% → 100% | -25d → none |
| 104 | Resolve overlap and conflicts | 2005-03-17 A | 2005-03-17 A | 0% → 100% | -25d → none |
| 108 | **Review and Validate Requirements** |  | 2005-04-19 A | 50% → 100% | -8d → none |
| 110 | Review of draft guidelines/Requirements for GIS Naming Convention and Directory Structure | 2005-04-15 A | 2005-04-15 A | 0% → 100% | -49d → none |
| 111 | Edit draft guidelines/Requirements based on team input | 2005-04-18 A | 2005-04-18 A | 0% → 100% | -49d → none |
| 112 | Post draft guidelines/Requirements for external review | 2005-04-19 A | 2005-04-19 A | 0% → 100% | -49d → none |
| 113 | Draft GIS Naming Convention/Directory Structure Requirements developed | 2005-04-20 A | 2005-04-20 A | 0% → 100% | -49d → none |
| 114 | **Develop Draft GIS Standard Naming Convention SOPs** |  | 2005-04-27 A | 17% → 100% | -33d → none |
| 115 | **Prepare Sample of Naming Conventions and Directory Structure** |  | 2005-04-22 A | 33% → 100% | -33d → none |
| 118 | Prepare Methods of work | 2005-04-21 A | 2005-04-21 A | 0% → 100% | -33d → none |
| 119 | Prepare draft SOPs for field review | 2005-04-22 A | 2005-04-22 A | 0% → 100% | -33d → none |
| 120 | **Sample Documents/draft SOPs Review and Validation** | 2005-04-25 A | 2005-04-27 A | 0% → 100% | -33d → none |
| 121 | Post sample documents for inter team review | 2005-04-25 A | 2005-04-25 A | 0% → 100% | -33d → none |
| 122 | Edit sample documents based on input | 2005-04-26 A | 2005-04-26 A | 0% → 100% | -33d → none |
| 123 | Draft GIS Naming Convention/Directory Structure SOPs developed | 2005-04-27 A | 2005-04-27 A | 0% → 100% | -33d → none |
| 124 | **Conduct External Review of GIS Naming Standard/Directory Structure SOP requirements and draft SOPs** | 2005-04-28 A | 2005-05-13 A | 0% → 100% | -33d → none |
| 125 | Design External Review of guidelines/requirements for GIS Naming Standards and Directory Structure | 2005-04-28 A | 2005-04-29 A | 0% → 100% | -28.5d → none |
| 126 | Post sample documents/SOPs for external review | 2005-05-02 A | 2005-05-06 A | 0% → 100% | -28.5d → none |
| 127 | Conduct External review of Guidelines/Requirements and draft SOPs | 2005-05-09 A | 2005-05-09 A | 0% → 100% | -28.5d → none |
| 128 | Edit draft guidelines/Requirements based on input | 2005-04-28 A | 2005-04-28 A | 0% → 100% | -22d → none |
| 129 | Edit sample documents/SOPs based on input | 2005-04-28 A | 2005-05-13 A | 0% → 100% | -33d → none |
| 130 | **Finalize recommendation of GIS Standard Naming Conventions** | 2005-05-16 A | 2005-05-17 A | 0% → 100% | -33d → none |
| 131 | Create a report recommending the adoption of the standard | 2005-05-16 A | 2005-05-16 A | 0% → 100% | -33d → none |
| 132 | Conduct a review of the report | 2005-05-17 A | 2005-05-17 A | 0% → 100% | -33d → none |
| 133 | Submit the report to GSTOP-PM | 2005-05-17 A | 2005-05-17 A | 0% → 100% | -33d → none |
| 134 | **Incident GIS Standard Product Definitions** |  | 2005-05-11 A | 0% → 100% | -29d → none |
| 135 | **Develop GIS Standard Product Definitions SOP Requirements** |  | 2005-04-22 A | 0% → 100% | -16d → none |
| 136 | **Define criteria for the acceptance of standard products definitions** | 2005-03-16 A | 2005-03-17 A | 0% → 100% | 10d → none |
| 137 | Develop acceptance criteria for std products definitions | 2005-03-16 A | 2005-03-16 A | 0% → 100% | 10d → none |
| 138 | Conduct a final review of selection criteria | 2005-03-17 A | 2005-03-17 A | 0% → 100% | 10d → none |
| 139 | **Define/Collect Information** |  | 2005-03-16 A | 0% → 100% | -11d → none |
| 143 | Post for review including samples | 2005-03-16 A | 2005-03-16 A | 0% → 100% | -25d → none |
| 144 | Collect examples of new kinds of standard products that aren't in any of the existing definitions |  | 2005-02-10 A | 0% → 100% | -1d → none |
| 145 | **Conduct Analysis** | 2005-03-17 A | 2005-04-22 A | 0% → 100% | -29d → none |
| 146 | Define the meaning of product definitions - what goes into them? | 2005-03-17 A | 2005-03-17 A | 0% → 100% | -3d → none |
| 147 | Create a draft template of what a product definition is | 2005-03-23 A | 2005-03-23 A | 0% → 100% | -29d → none |
| 148 | Review existing standards definitions (Victoria/PNWCG/DPRO) & Identify discrepancies between groups defining standard | 2005-03-24 A | 2005-04-06 A | 0% → 100% | -29d → none |
| 149 | Highlight specific reasons for discrepancies (Fire Use vs. Type 1) if needed | 2005-03-24 A | 2005-03-24 A | 0% → 100% | -20d → none |
| 150 | Bring these to the larger group for discussion and resolution | 2005-04-07 A | 2005-04-20 A | 0% → 100% | -29d → none |
| 151 | Gather responses from GSTOP and GTG; incorporte feedback | 2005-04-21 A | 2005-04-21 A | 0% → 100% | -29d → none |
| 152 | Send out to wider folks for review (Field Test) | 2005-04-22 A | 2005-04-22 A | 0% → 100% | -29d → none |
| 153 | **Develop draft GIS Standard Product Definition SOPs** | 2005-04-25 A | 2005-04-25 A | 0% → 100% | -29d → none |
| 154 | Provide a package of draft products definitions and samples for review | 2005-04-25 A | 2005-04-25 A | 0% → 100% | -29d → none |
| 155 | Evaluate std products against acceptance criteria | 2005-04-25 A | 2005-04-25 A | 0% → 100% | -29d → none |
| 156 | Provide data location and review process to internal group | 2005-04-25 A | 2005-04-25 A | 0% → 100% | -29d → none |
| 157 | Prepare draft SOPs for review | 2005-04-25 A | 2005-04-25 A | 0% → 100% | -29d → none |
| 158 | **Conduct External Review of draft GIS Standard Product Definition SOPs** | 2005-04-26 A | 2005-05-09 A | 0% → 100% | -29d → none |
| 159 | **Conduct outside peer review of the draft standard products definitions** | 2005-04-26 A | 2005-04-29 A | 0% → 100% | -29d → none |
| 160 | Submit the draft standard symbols to the 5 federal fire management agencies and State agencies via the NWCG Geospatial Task Group (GTG); and to the DHS (FEMA), FAA, DOD, and GSTOP Team for peer review | 2005-04-26 A | 2005-04-26 A | 0% → 100% | -29d → none |
| 161 | Review feedback of initial peer review | 2005-04-27 A | 2005-04-27 A | 0% → 100% | -29d → none |
| 162 | Identify required changes to draft standard products based on the initial peer review feedback | 2005-04-28 A | 2005-04-28 A | 0% → 100% | -29d → none |
| 163 | Make required changes, as identified, to draft standard products | 2005-04-29 A | 2005-04-29 A | 0% → 100% | -29d → none |
| 164 | **Conduct final peer review of the draft standard products** | 2005-05-02 A | 2005-05-09 A | 0% → 100% | -29d → none |
| 165 | Prepare draft standard products for final peer review | 2005-05-02 A | 2005-05-02 A | 0% → 100% | -29d → none |
| 166 | Submit the draft standard products to the 5 federal fire management agencies and State agencies via the NWCG Geospatial Task Group (GTG); and to the HSA (FEMA), FAA, DOD, and GSTOP Team for peer review | 2005-05-03 A | 2005-05-03 A | 0% → 100% | -29d → none |
| 167 | Review feedback of the final peer review | 2005-05-04 A | 2005-05-04 A | 0% → 100% | -29d → none |
| 168 | Identify required changes to draft standard products based on the final peer review feedback | 2005-05-05 A | 2005-05-05 A | 0% → 100% | -29d → none |
| 169 | Make required changes, as identified, to draft standard products | 2005-05-06 A | 2005-05-06 A | 0% → 100% | -29d → none |
| 170 | Ratify the final draft standard symbols | 2005-05-09 A | 2005-05-09 A | 0% → 100% | -29d → none |
| 171 | **Finalize recommendation of standard Fire Mapping products** | 2005-05-10 A | 2005-05-11 A | 0% → 100% | -29d → none |

| ID | Task | Start | Finish | Complete | Total float |
| --- | --- | --- | --- | --- | --- |
| 172 | Create a report recommending the adoption of the draft standard product definitions | 2005-05-10 A | 2005-05-10 A | 0% → 100% | -29d → none |
| 173 | Conduct a review of the report for completeness, accuracy, language, and grammar | 2005-05-11 A | 2005-05-11 A | 0% → 100% | -29d → none |
| 174 | Submit the report to GSTOP-PM | 2005-05-11 A | 2005-05-11 A | 0% → 100% | -29d → none |
| 175 | Find a permanent storage location for this package? National clearinghouse? | 2005-05-10 A | 2005-05-10 A | 0% → 100% | -28d → none |
| 176 | **Incident GIST Minimum Qualifications & GIS Expectations** |  | 2005-04-25 A | 17% → 100% | -16.5d → none |
| 177 | **Develop Requirements for determining the GIST Minimum Qualifications & GIS Expectations** |  | 2005-03-24 A | 48% → 100% | -0.5d → none |
| 178 | **Establish evaluation methods for minimum GIST qualifications/GIS expectations** | 2005-03-16 A | 2005-03-16 A | 0% → 100% | -11d → none |
| 179 | Define method for evaluating minimum GIST qualifications/GIS expectations | 2005-03-16 A | 2005-03-16 A | 0% → 100% | -11d → none |
| 180 | Conduct a final review of evaluation methods | 2005-03-16 A | 2005-03-16 A | 0% → 100% | -11d → none |
| 181 | **Define criteria for the acceptance of minimum GIST qualifications/GIS expectations** | 2005-03-16 A | 2005-03-16 A | 0% → 100% | -11d → none |
| 182 | Develop acceptance criteria for minimum GIST qualifications/GIS expectations | 2005-03-16 A | 2005-03-16 A | 0% → 100% | -11d → none |
| 183 | Conduct a final review of selection criteria | 2005-03-16 A | 2005-03-16 A | 0% → 100% | -11d → none |
| 184 | **Collect Information on minimum GIST qualifications and minimum GIS expectations on an incident** |  | 2005-03-24 A | 71% → 100% | -0.5d → none |
| 186 | Obtain and review revised Taskbook | 2005-03-24 A | 2005-03-24 A | 0% → 100% | -16.5d → none |
| 187 | Scan or translate paper documents to electronic format | 2005-03-16 A | 2005-03-16 A | 0% → 100% | -11d → none |
| 188 | Research current GIST/GIS standards | 2005-03-16 A | 2005-03-16 A | 0% → 100% | -11d → none |
| 189 | **Develop draft of GIST Minimum Qualifications & Expecations** | 2005-03-24 A | 2005-04-11 A | 0% → 100% | -16.5d → none |
| 190 | **Develop a list of GIST qualifications to be evaluated for acceptance as draft minimum standards** | 2005-03-24 A | 2005-03-29 A | 0% → 100% | -16.5d → none |
| 191 | Compare the current GIST standards | 2005-03-24 A | 2005-03-25 A | 0% → 100% | -16.5d → none |
| 192 | Compile the GIST qualifications into a single list of potential minimum GIST qualifications | 2005-03-25 A | 2005-03-28 A | 0% → 100% | -16.5d → none |
| 193 | Compile a list of GIST qualifications which are deemed to be beyond the minimum for future reference | 2005-03-28 A | 2005-03-29 A | 0% → 100% | -16.5d → none |
| 194 | **Determine the draft standard minimum GIST qualifications** | 2005-03-29 A | 2005-04-01 A | 0% → 100% | -16.5d → none |
| 195 | Evaluate each potential minimum GIST qualification using the approved evaluation methods | 2005-03-29 A | 2005-03-30 A | 0% → 100% | -16.5d → none |
| 196 | Select the minimum GIST qualifications | 2005-03-30 A | 2005-03-31 A | 0% → 100% | -16.5d → none |
| 197 | Conduct a completeness review of the draft minimum GIST qualifications | 2005-03-31 A | 2005-04-01 A | 0% → 100% | -16.5d → none |
| 198 | **Conduct internal review of draft standard minimum GIST qualifications & GIS expectations** | 2005-04-01 A | 2005-04-11 A | 0% → 100% | -16.5d → none |
| 199 | Prepare draft standard minimum GIST qualifications and GIS expectations, including acceptance criteria | 2005-04-01 A | 2005-04-04 A | 0% → 100% | -16.5d → none |
| 200 | Post draft standard to DisasterHelp website and notify GSTOP team for group review | 2005-04-04 A | 2005-04-05 A | 0% → 100% | -16.5d → none |
| 201 | Provide data location and review process to internal group | 2005-04-05 A | 2005-04-06 A | 0% → 100% | -16.5d → none |
| 202 | Review feedback of initial peer review | 2005-04-06 A | 2005-04-07 A | 0% → 100% | -16.5d → none |
| 203 | Identify required changes to draft standard based on the initial peer review feedback | 2005-04-07 A | 2005-04-08 A | 0% → 100% | -16.5d → none |
| 204 | Make required changes, as identified, to draft standard | 2005-04-08 A | 2005-04-11 A | 0% → 100% | -16.5d → none |
| 205 | **Conduct final peer review of the draft standard minimum GIST qualifications & GIS expectations** | 2005-04-11 A | 2005-04-20 A | 0% → 100% | -16.5d → none |
| 206 | Prepare survey or questionnaire to accompany draft standards for final peer review. | 2005-04-11 A | 2005-04-12 A | 0% → 100% | -16.5d → none |
| 207 | Prepare draft standard minimum GIST Qualification/GIST expectations for final peer review, including the survey of results | 2005-04-12 A | 2005-04-13 A | 0% → 100% | -16.5d → none |
| 208 | Submit the draft expectations to the 5 federal fire management agencies and State agencies via the NWCG Geospatial Task Group (GTG); and to the HSA (FEMA), FAA, DOD, and GSTOP Team for peer review. | 2005-04-13 A | 2005-04-14 A | 0% → 100% | -16.5d → none |
| 209 | Review feedback of the final peer review, including survey of results | 2005-04-14 A | 2005-04-15 A | 0% → 100% | -16.5d → none |
| 210 | Identify required changes to draft standard minimum GIST qualifications/GIS expectations based on the final peer review feedback | 2005-04-15 A | 2005-04-18 A | 0% → 100% | -16.5d → none |
| 211 | Make required changes, as identified, to draft minimum GIST qualifications/GIS expectations symbols | 2005-04-18 A | 2005-04-19 A | 0% → 100% | -16.5d → none |
| 212 | Ratify the final draft standard minimum GIST qualifications/GIS expectations | 2005-04-19 A | 2005-04-20 A | 0% → 100% | -16.5d → none |
| 213 | **Finalize recommendation for standard Minimum GIST Qualifications & GIS Expectations on an Incident** | 2005-04-20 A | 2005-04-25 A | 0% → 100% | -16.5d → none |
| 214 | Create a report recommending the adoption of the draft minimum GIST Qualifications/GIS Expectations | 2005-04-20 A | 2005-04-21 A | 0% → 100% | -16.5d → none |
| 215 | Conduct a review of the report for completeness, accuracy, language, and grammar | 2005-04-21 A | 2005-04-22 A | 0% → 100% | -16.5d → none |
| 216 | Submit the report to GSTOP-PM | 2005-04-22 A | 2005-04-25 A | 0% → 100% | -16.5d → none |
| 217 | **Incident GIS Minimum Essential Datasets** |  | 2005-04-25 A | 4% → 100% | -12d → none |
| 218 | **Establish MED Sub-Team business practices** |  | 2005-03-16 A | 0% → 100% | 11d → none |
| 219 | **Develop a MED Sub-team Communication Plan** |  | 2005-03-16 A | 0% → 100% | 11d → none |
| 220 | Define ground-rules for Sub-Team (internal) communication | 2005-03-16 A | 2005-03-16 A | 0% → 100% | 11d → none |
| 221 | Define ground-rules for communication between the MED Sub-Team and other GSTOP Sub-Teams |  | 2005-02-10 A | 0% → 100% | 35d → none |
| 222 | Define ground rules for communication between the Sub-Team and entities outside of the GSTOP Project |  | 2005-02-10 A | 0% → 100% | 35d → none |
| 223 | Establish a process and schedule for Sub-Team (internal) progress report updates |  | 2005-02-10 A | 0% → 100% | 35d → none |
| 224 | Establish a process and schedule for Sub-Team progress report updates to the GSTOP Team |  | 2005-02-10 A | 0% → 100% | 35d → none |
| 225 | **Establish Review Processes** |  | 2005-03-16 A | 0% → 100% | 11d → none |
| 226 | Establish a process for Sub-Team (internal) review of potential MEDs |  | 2005-02-10 A | 0% → 100% | -1d → none |
| 227 | Establish a process for Sub-Team (internal) review of the draft standard MEDs |  | 2005-02-10 A | 0% → 100% | 34d → none |
| 228 | Establish a process for peer reviews | 2005-03-16 A | 2005-03-16 A | 0% → 100% | 11d → none |
| 229 | Establish a process for periodic GSTOP Team reviews |  | 2005-03-01 A | 0% → 100% | -1d → none |
| 230 | Establish a process for reviewing the final report |  | 2005-03-01 A | 0% → 100% | -1d → none |
| 231 | **Establish Change processes** |  | 2005-03-16 A | 0% → 100% | 11d → none |
| 232 | Establish a process for additions/deletions of potential MEDs mid-stream through the Project |  | 2005-03-01 A | 0% → 100% | -1d → none |
| 233 | Establish a change process for the additions/deletion of standard MEDs after the final recommendation has been submitted |  | 2005-03-01 A | 0% → 100% | 21d → none |
| 234 | Establish a change process for the additions/deletion of standard MEDs after the final recommendation has been approved through the GSTOP Team | 2005-03-16 A | 2005-03-16 A | 0% → 100% | 11d → none |
| 235 | **Develop requirements for GIS Minimum Essential Datasets SOPs** |  | 2005-04-08 A | 5% → 100% | -1d → none |
| 236 | **Establish MED evaluation methods** |  | 2005-04-08 A | 14% → 100% | -1d → none |
| 237 | **Define High level criteria for the acceptance of MEDs as standards** |  | 2005-04-08 A | 0% → 100% | -1d → none |
| 238 | Determine incident tasks and required deliverables |  | 2005-03-17 A | 0% → 100% | -1d → none |
| 239 | Determine data availability criteria |  | 2005-04-07 A | 0% → 100% | -17d → none |
| 240 | Develop accuracy standards for databases | 2005-04-08 A | 2005-04-08 A | 0% → 100% | -17d → none |
| 241 | Define method for evaluating MEDs |  | 2005-04-05 A | 0% → 100% | -14d → none |
| 242 | Develop acceptance criteria for raster MEDs | 2005-03-16 A | 2005-03-16 A | 0% → 100% | 0d → none |

| ID | Task | Start | Finish | Complete | Total float |
| --- | --- | --- | --- | --- | --- |
| 244 | Review draft Acceptance Criteria | 2005-03-28 A | 2005-03-28 A | 0% → 100% | -13d → none |
| 245 | Update Acceptance Criteria for GSTOP Team input | 2005-03-29 A | 2005-04-01 A | 0% → 100% | -13d → none |
| 246 | Conduct a final review of selection criteria | 2005-04-04 A | 2005-04-04 A | 0% → 100% | -13d → none |
| 247 | **Develop a list of MEDs to be evaluated for acceptance as draft standards** |  | 2005-04-04 A | 0% → 100% | -1d → none |
| 248 | Determine what datasets are required for each deliverable |  | 2005-04-01 A | 0% → 100% | -12d → none |
| 249 | Collect Standard Product Definition from GSTOP subteam to evaluate for potential MEDs |  | 2005-04-01 A | 0% → 100% | 0d → none |
| 250 | Document potential sources for additional fire mapping MEDs | 2005-04-04 A | 2005-04-04 A | 0% → 100% | -13d → none |
| 251 | Compile MEDs into a single potential MED set | 2005-04-04 A | 2005-04-04 A | 0% → 100% | -13d → none |
| 252 | Define methods a GIST should yuse to determine if dataset meets Accuracy Standards | 2005-03-16 A | 2005-03-16 A | 0% → 100% | 0d → none |
| 253 | **Develop draft SOPs for GIS Minimum Essential Datasets** | 2005-04-11 A | 2005-04-21 A | 0% → 100% | -17d → none |
| 254 | **Determine the draft standard Raster MEDs** | 2005-04-11 A | 2005-04-13 A | 0% → 100% | -17d → none |
| 255 | Evaluate each potential marker MED against the MED selection criteria | 2005-04-11 A | 2005-04-11 A | 0% → 100% | -17d → none |
| 256 | Sub-Team selection of the draft standards for MEDs vs. extended MED list | 2005-04-12 A | 2005-04-12 A | 0% → 100% | -17d → none |
| 257 | Conduct a Sub-team completeness review of the draft standard MEDs | 2005-04-13 A | 2005-04-13 A | 0% → 100% | -17d → none |
| 258 | **Conduct a Sub-team completeness review of the draft standard and extended MEDs** | 2005-04-14 A | 2005-04-20 A | 0% → 100% | -17d → none |
| 259 | Prepare draft standard MEDs for initial peer review | 2005-04-14 A | 2005-04-14 A | 0% → 100% | -17d → none |
| 260 | Submit the draft standard MEDs to the 5 federal fire management agencies, State agencies, and USGS via the NWCG Geospatial Task Group (GTG); and to DHS (FEMA), FAA, DOD, and GSTOP Team for peer review | 2005-04-14 A | 2005-04-14 A | 0% → 100% | -17d → none |
| 261 | Conduct initial peer review of the draft standard and extended MEDs | 2005-04-15 A | 2005-04-15 A | 0% → 100% | -17d → none |
| 262 | Review feedback of initial peer review | 2005-04-18 A | 2005-04-18 A | 0% → 100% | -17d → none |
| 263 | Identify required changes to draft standard MEDs based on the initial peer review feedback | 2005-04-19 A | 2005-04-19 A | 0% → 100% | -17d → none |
| 264 | Make required changes, as identified, to draft standard MEDs | 2005-04-20 A | 2005-04-20 A | 0% → 100% | -17d → none |
| 265 | Prepare draft SOPs for field test | 2005-04-21 A | 2005-04-21 A | 0% → 100% | -17d → none |
| 266 | **Conduct final peer review of the draft standard marker, line, and fill MEDs** | 2005-04-22 A | 2005-04-22 A | 0% → 100% | -17d → none |
| 267 | Prepare draft standard MEDs for final peer review | 2005-04-22 A | 2005-04-22 A | 0% → 100% | -17d → none |
| 268 | Submit the draft standard MEDs to the 5 federal fire management agencies and State agencies via the NWCG Geospatial Task Group (GTG); and to the HSA (FEMA), FAA, DOD, and GSTOP Team for peer review | 2005-04-22 A | 2005-04-22 A | 0% → 100% | -17d → none |
| 269 | Review feedback of the final peer review | 2005-04-22 A | 2005-04-22 A | 0% → 100% | -17d → none |
| 270 | Identify required changes to draft standard MEDs based on the final peer review feedback | 2005-04-22 A | 2005-04-22 A | 0% → 100% | -17d → none |
| 271 | Make required changes, as identified, to draft standard MEDs | 2005-04-22 A | 2005-04-22 A | 0% → 100% | -17d → none |
| 272 | Ratification of the final draft standard MEDs by the Sub-Team | 2005-04-22 A | 2005-04-22 A | 0% → 100% | -17d → none |
| 273 | **Finalize recommendation of standard Fire Mapping MEDs** | 2005-04-25 A | 2005-04-25 A | 0% → 100% | -17d → none |
| 274 | Create a report recommending the adoption of the draft standard MEDs | 2005-04-25 A | 2005-04-25 A | 0% → 100% | -17d → none |
| 275 | Conduct a Sub-Team review of the report | 2005-04-25 A | 2005-04-25 A | 0% → 100% | -17d → none |
| 276 | Submit the report to GSTOP-PM | 2005-04-25 A | 2005-04-25 A | 0% → 100% | -17d → none |
| 277 | **Incident GIS Standard Data Sharing and Archiving Standards** | 2005-03-16 A | 2005-03-28 A | 0% → 100% | 3.58d → none |
| 278 | **Develop requirements for GIS Standard Data Sharing and Archiving Standards SOPs** | 2005-03-16 A | 2005-03-22 A | 0% → 100% | 3.58d → none |
| 279 | **Define Information Needs (What do we need to gather?)** | 2005-03-16 A | 2005-03-18 A | 0% → 100% | 3.58d → none |
| 280 | Compile existing archiving standards in use (e.g. data format, transfer mode) | 2005-03-16 A | 2005-03-16 A | 0% → 100% | 3.58d → none |
| 281 | Identify how archiving is done at present time by ICS, military, other incident responders, project-management | 2005-03-17 A | 2005-03-17 A | 0% → 100% | 3.58d → none |
| 282 | Gather NARA, Records Management requirements (review policies, lawsuits) e.g. physical location, acceptable media, supporting documentation | 2005-03-17 A | 2005-03-17 A | 0% → 100% | 3.58d → none |
| 283 | Determine the least common denominator (shapefile) or possibility of multiple formats | 2005-03-17 A | 2005-03-18 A | 0% → 100% | 3.58d → none |
| 284 | Collect Information: Conduct literature review | 2005-03-18 A | 2005-03-21 A | 0% → 100% | 3.58d → none |
| 285 | Conduct Analysis: Compile & Synthesize Requirements | 2005-03-21 A | 2005-03-22 A | 0% → 100% | 3.58d → none |
| 286 | **Develop draft SOPs for GIS Standard Data Sharing and Archiving Standards** | 2005-03-22 A | 2005-03-28 A | 0% → 100% | 3.58d → none |
| 287 | Develop Preliminary SOPs | 2005-03-22 A | 2005-03-23 A | 0% → 100% | 3.58d → none |
| 288 | Sub-Team Review of SOP | 2005-03-23 A | 2005-03-24 A | 0% → 100% | 3.58d → none |
| 289 | Revise, Edit Proposed SOP | 2005-03-24 A | 2005-03-25 A | 0% → 100% | 3.58d → none |
| 290 | Submit to Project Manager for Team Review | 2005-03-25 A | 2005-03-28 A | 0% → 100% | 3.58d → none |
| 291 | **Incident GIS Standard Documentation and Archiving** |  | 2005-04-15 A | 32% → 100% | -5d → none |
| 292 | **Develop requirements for GIS Standard Documentation and Archiving SOPs** |  | 2005-04-12 A | 54% → 100% | -2d → none |
| 293 | **Define Information Needs (What do we need to gather?)** |  | 2005-04-08 A | 59% → 100% | 0d → none |
| 295 | Identify how archiving is done at present time by ICS, military, other incident responders, project-management |  | 2005-04-08 A | 0% → 100% | 0d → none |
| 296 | ?? Gather NARA, Records Management requirements (review policies, lawsuits) e.g. physical location, acceptable media, supporting documentation | 2005-03-16 A | 2005-03-16 A | 0% → 100% | 6d → none |
| 298 | Review Documentation Unit Leader Task book and Job Aid | 2005-03-16 A | 2005-03-16 A | 0% → 100% | 6d → none |
| 299 | Conduct Analysis: Compile, Synthesize requirements | 2005-04-11 A | 2005-04-11 A | 0% → 100% | -11d → none |
| 300 | Document Preliminary Requirements Specifications | 2005-04-12 A | 2005-04-12 A | 0% → 100% | -11d → none |
| 301 | Post subteam Requirements for GSTOP Team Review | 2005-04-12 A | 2005-04-12 A | 0% → 100% | -11d → none |
| 302 | **Develop draft SOPs for GIS Standard Documentation and Archiving** | 2005-04-13 A | 2005-04-15 A | 0% → 100% | -11d → none |
| 303 | Develop Preliminary SOPs | 2005-04-13 A | 2005-04-13 A | 0% → 100% | -11d → none |
| 304 | Sub-Team Review of SOP | 2005-04-14 A | 2005-04-14 A | 0% → 100% | -11d → none |
| 305 | Revise, Edit Proposed SOP | 2005-04-15 A | 2005-04-15 A | 0% → 100% | -11d → none |
| 306 | Submit to Project Manager for Team Review | 2005-04-15 A | 2005-04-15 A | 0% → 100% | -11d → none |
| 307 | **Conduct External Review of GIS Standard Data Sharing and Archiving Standards SOP requirements and draft SOPs** | 2005-03-16 A | 2005-03-31 A | 0% → 100% | -2d → none |
| 308 | Design External Review of guidelines/requirements for GIS Standard Documentation and Archiving SOPs | 2005-03-16 A | 2005-03-17 A | 0% → 100% | 2.5d → none |
| 309 | Post sample documents/SOPs for external review | 2005-03-18 A | 2005-03-24 A | 0% → 100% | 2.5d → none |
| 310 | Conduct External review of Guidelines/Requirements and draft SOPs | 2005-03-25 A | 2005-03-25 A | 0% → 100% | 2.5d → none |
| 311 | Edit draft guidelines/Requirements based on input | 2005-03-16 A | 2005-03-16 A | 0% → 100% | 9d → none |
| 312 | Edit sample documents/SOPs based on input | 2005-03-16 A | 2005-03-31 A | 0% → 100% | -2d → none |
| 313 | **Finalize recommendation of GIS Standard Documentation and Archiving** | 2005-04-01 A | 2005-04-04 A | 0% → 100% | -2d → none |
| 314 | Create a report recommending the adoption of the standard | 2005-04-01 A | 2005-04-01 A | 0% → 100% | -2d → none |
| 315 | Conduct a review of the report | 2005-04-04 A | 2005-04-04 A | 0% → 100% | -2d → none |

| ID | Task | Start | Finish | Duration | Complete | Total float | Predecessors | Other |
| --- | --- | --- | --- | --- | --- | --- | --- | --- |
| 316 | Submit the report to GSTOP-PM | 2005-04-04 A | 2005-04-04 A |  | 0% → 100% | -2d → none |  |  |
| 317 | **Incident GIS Transition Procedures** |  | 2005-06-14 A |  | 26% → 100% | 253d → none |  |  |
| 318 | **Develop requirements for GIS Transition Procedures** |  | 2005-04-11 A |  | 63% → 100% | -5d → none |  |  |
| 319 | **Define Information Needs (What do we need to gather?)** |  | 2005-04-04 A |  | 86% → 100% | 0d → none |  |  |
| 320 | Determine "universe" of transitions: (team to team); (team to unit); (team to archive) |  | 2005-03-23 A |  | 0% → 100% | -1d → none |  |  |
| 321 | Conduct interviews and compile procedures documents currently in use |  | 2005-03-23 A |  | 0% → 100% | 1d → none |  |  |
| 323 | Evaluate Procedures: Identify test procedures for documentation and archiving | 2005-04-05 A | 2005-04-05 A |  | 0% → 100% | -7d → none |  |  |
| 324 | Conduct Analysis: Test and identify strengths/weaknesses of existing procedures | 2005-04-06 A | 2005-04-06 A |  | 0% → 100% | -7d → none |  |  |
| 325 | Develop Preliminary Requirements Specifications | 2005-04-07 A | 2005-04-07 A |  | 0% → 100% | -7d → none |  |  |
| 326 | **Review and Validate Requirements** | 2005-04-08 A | 2005-04-11 A |  | 0% → 100% | -7d → none |  |  |
| 327 | Sub-Team Review of Requirements | 2005-04-08 A | 2005-04-08 A |  | 0% → 100% | -7d → none |  |  |
| 328 | Revise, Edit requirements | 2005-04-11 A | 2005-04-11 A |  | 0% → 100% | -7d → none |  |  |
| 329 | Submit to Project Manager for Team Review | 2005-04-11 A | 2005-04-11 A |  | 0% → 100% | -7d → none |  |  |
| 330 | **Develop Preliminary SOP’s** | 2005-06-08 A | 2005-06-14 A |  | 0% → 100% | 253d → none |  |  |
| 331 | Create draft GIS Transition SOPs | 2005-06-08 A | 2005-06-08 A |  | 0% → 100% | 253d → none |  |  |
| 332 | Review draft GIS Transition SOPs | 2005-06-09 A | 2005-06-09 A |  | 0% → 100% | 253d → none |  |  |
| 333 | Revise, Edit draft GIS Transition SOPs | 2005-06-10 A | 2005-06-10 A |  | 0% → 100% | 253d → none |  |  |
| 334 | Submit to Project Manager for Team Review | 2005-06-10 A | 2005-06-10 A |  | 0% → 100% | 253d → none |  |  |
| 335 | Review Draft GIS Transition SOPs | 2005-06-13 A | 2005-06-13 A |  | 0% → 100% | 253d → none |  |  |
| 336 | Revise, Edit GIS Transition SOPs | 2005-06-14 A | 2005-06-14 A |  | 0% → 100% | 253d → none |  |  |
| 337 | **Conduct External Review of GIS Transition Procedures SOP requirements and draft SOPs** | 2005-03-16 A | 2005-03-31 A |  | 0% → 100% | 290d → none |  |  |
| 338 | Design External Review of guidelines/requirements for GIS Transition Procedures | 2005-03-16 A | 2005-03-17 A |  | 0% → 100% | 294.5d → none |  |  |
| 339 | Post sample documents/SOPs for external review | 2005-03-18 A | 2005-03-24 A |  | 0% → 100% | 294.5d → none |  |  |
| 340 | Conduct External review of Guidelines/Requirements and draft SOPs | 2005-03-25 A | 2005-03-25 A |  | 0% → 100% | 294.5d → none |  |  |
| 341 | Edit draft guidelines/Requirements based on input | 2005-03-16 A | 2005-03-16 A |  | 0% → 100% | 301d → none |  |  |
| 342 | Edit sample documents/SOPs based on input | 2005-03-16 A | 2005-03-31 A |  | 0% → 100% | 290d → none |  |  |
| 343 | **Finalize recommendation of GIS Transition Procedures** | 2005-04-01 A | 2005-04-04 A |  | 0% → 100% | 290d → none |  |  |
| 344 | Create a report recommending the adoption of the standard | 2005-04-01 A | 2005-04-01 A |  | 0% → 100% | 290d → none |  |  |
| 345 | Conduct a review of the report | 2005-04-04 A | 2005-04-04 A |  | 0% → 100% | 290d → none |  |  |
| 346 | Submit the report to GSTOP-PM | 2005-04-04 A | 2005-04-04 A |  | 0% → 100% | 290d → none |  |  |
| 347 | **Agency Review of Incident GIS SOPs** | 2005-06-07 A | 2006-02-20 A |  | 0% → 100% | -167d → none |  |  |
| 348 | Design common review processes for GIS SOP peer review | 2005-06-07 A | 2005-06-07 A |  | 0% → 100% | 17d → none |  |  |
| 349 | **Review and Validate draft SOP’s** | 2005-06-07 A | 2005-06-07 A |  | 0% → 100% | 17d → none |  |  |
| 350 | Review and Validate draft SOP’s for completeness | 2005-06-07 A | 2005-06-07 A |  | 0% → 100% | 17.5d → none |  |  |
| 351 | Review and Validate draft SOP’s for GIS content | 2005-06-07 A | 2005-06-07 A |  | 0% → 100% | 17d → none |  |  |
| 352 | **Agencies' review of Draft SOPs** | 2005-06-07 A | 2006-02-15 A |  | 0% → 100% | -167d → none |  |  |
| 353 | Create a cover letter and response process | 2005-06-07 A | 2005-06-07 A |  | 0% → 100% | -167d → none |  |  |
| 354 | Distribute draft SOPs for Agency review | 2005-06-08 A | 2005-06-08 A |  | 0% → 100% | -167d → none |  |  |
| 355 | Review and Validate draft SOP’s | 2005-06-09 A | 2006-02-15 A |  | 0% → 100% | -167d → none |  |  |
| 356 | **Incorporate Feedback from reviewers** | 2006-02-16 A | 2006-02-20 A |  | 0% → 100% | -167d → none |  |  |
| 357 | Consolidate reviewers' inputs | 2006-02-16 A | 2006-02-16 A |  | 0% → 100% | -167d → none |  |  |
| 358 | Evaluate Feedback for inclusion in SOP revision | 2006-02-17 A | 2006-02-17 A |  | 0% → 100% | -167d → none |  |  |
| 359 | Update draft SOPs for accepted feedback from reviewers | 2006-02-20 A | 2006-02-20 A |  | 0% → 100% | -167d → none |  |  |
| 381 | MS3: Requirements are reviewed and tested by business community |  | 2005-07-01 A |  | 0% → 100% | 120d → none |  |  |
| 382 | **Final Incident GIS SOPs** | 2005-07-01 A |  |  | 0% → 31% | 1d → 21d |  |  |
| 393 | MS5: GIS SOPs are finalized | 2006-05-15 → 2005-07-01 (-318d) | 2006-05-15 → 2005-09-23 (-234d) | 0d → 61d |  | 0d → 200d |  | constraint must finish on 2006-05-15 → none |
| 394 | Deliver Final Incident GIS SOPs to Incident Based Automation Project | 2006-05-15 → 2005-07-01 (-318d) | 2006-05-15 → 2005-07-01 (-318d) |  |  | 14d → 261d | 393 → none |  |
| 403 | **GSTOP Project Management** |  | 2006-06-02 → 2006-06-30 (+28d) | 423d? → 443d? | 40% → 4% |  |  |  |
| 413 | **Conduct Periodic Team Meetings** |  | 2005-05-12 A → 2006-01-19 A (+252d) | 78d → 258d? |  |  |  |  |
| 417 | **Develop GIS SOP Implementation Plan** | 2004-10-20 → 2005-01-18 (+90d) | 2004-10-20 → 2006-06-30 (+618d) | 1d? → 379d? |  | 422d → 0d |  |  |
| 418 | Develop and implement GSTOP SOP User education and distribution strategy | 2004-10-20 → 2005-01-18 (+90d) | 2004-10-20 → 2005-05-20 (+212d) | 1d? → 89d? |  | 422d → 290d |  | constraint none → start no earlier than 2005-01-18 |
| 419 | Ensure incorporation of GSTOP deliverables into national and local training programs | 2004-10-20 → 2006-02-01 (+469d) | 2004-10-20 → 2006-06-30 (+618d) | 1d? → 108d? |  | 422d → 0d |  | constraint none → start no earlier than 2006-02-01 |
| 421 | Convey final GSTOP deliverables to fire mapping tool development team (ESRI) |  |  |  |  | 0d → 20d |  | resources none → GTG Joe Frost |
| 426 | **Implement GSTOP Project Communication Plan** |  | 2006-03-01 → 2006-05-04 (+64d) | 356d? → 402d? | 0% → 5% | 67d → 41d |  |  |
| 427 | **Create processes and methods for communication to stakeholders** |  |  |  | 0% → 4% | 255d → 275d |  |  |
| 437 | **Establish GSTOP Project communications methods** |  |  |  | 0% → 48% | 255d → 275d |  |  |
| 440 | **Establish GSTOP project webpages linked to GTG website** | 2005-06-01 A | 2005-06-10 A |  | 0% → 100% | 255d → none |  |  |
| 441 | Identify Website Content | 2005-06-01 A | 2005-06-10 A |  | 0% → 100% | 255d → none |  |  |
| 444 | Design communciations and schedule for dissemination to Fire GIS qualified folks |  |  |  |  | 422d → 442d |  | was named Design communciations and schedule for dissemination to Fire GIS qulaified folks |
| 445 | Complete distribution list of all regional key contacts for Fire GIS qualified staff |  |  |  |  | 422d → 442d |  | was named Complete distribution list of all regional ckey contacts for Fire GIS qualified staff |
| 469 | **Conduct project briefings to stakeholders** |  | 2006-03-01 → 2006-05-04 (+64d) | 356d? → 402d? | 11% → 35% | 67d → 41d |  |  |
| 470 | **Conduct briefings for project sponsors (when and where?)** |  | 2006-03-01 → 2006-05-04 (+64d) | 251d? → 297d? | 17% → 50% | 67d → 41d |  |  |
| 471 | **Report to Executive Committee** |  | 2006-03-01 → 2006-05-04 (+64d) | 251d? → 297d? | 17% → 50% | 67d → 41d |  |  |
| 473 | 2005 Q2 Executive Briefing | 2005-06-01 A | 2005-06-01 A |  | 0% → 100% | 262d → none |  |  |
| 474 | 2005 Q3 Executive Briefing | 2005-09-01 A | 2005-09-01 A |  | 0% → 100% | 196d → none |  |  |
| 475 | 2005 Q4 Executive Briefing | 2005-12-01 A | 2005-12-01 A |  | 0% → 100% | 131d → none |  |  |
| 476 | 2006 Q1 Executive Briefing | 2006-03-01 → 2006-02-14 (-15d) | 2006-03-01 → 2006-02-14 (-15d) |  |  | 67d → 98d |  | constraint start no earlier than 2006-03-01 → finish no earlier than 2006-02-14 |
| 477 | 2006 Q2 Executive Briefing | 2005-06-01 → 2006-05-02 (+335d) | 2005-06-01 → 2006-05-04 (+337d) | 1d → 3d |  | 262d → 41d |  | constraint start no earlier than 2005-06-01 → start no earlier than 2006-05-02 |
