# GSTOP_rev 1

How a schedule from MS Project changed from version to version. A marks actual dates.

## Version 1 (saved 2005-03-10, file GSTOP Project Timeline030405_Port.mpp)

| ID | WBS | Task | Duration | Start | Finish | Predecessors | Total float | Constraint |
| --- | --- | --- | --- | --- | --- | --- | --- | --- |
| 1 | 1 | **GSTOP Project Initiation** | 105d? | 2004-10-20 | 2005-03-15 |  | 318d |  |
| 2 | 1.1 | **Initiate the GSTOP Project** | 98d | 2004-10-20 | 2005-03-04 |  | 325d |  |
| 3 |  | GSTOP Executive Committee Formed | 6d | 2004-12-01 | 2004-12-08 |  | 387d | finish no earlier than 2004-12-08 |
| 4 |  | GSTOP Project Manager Identified | 1d | 2004-10-20 | 2004-10-20 |  | 422d | finish no earlier than 2004-10-20 |
| 5 |  | GSTOP Project Charter Approved | 1d | 2004-12-01 | 2004-12-01 |  | 392d |  |
| 6 |  | GSTOP Project Funding Secured | 68d | 2004-12-01 | 2005-03-04 |  | 325d | finish no earlier than 2005-03-04 |
| 7 | 1.2 | **GSTOP Project Team Identified** | 75d? | 2004-12-01 | 2005-03-15 |  | 318d |  |
| 8 | 1.2.1 | **Form the GSTOP Team** | 75d? | 2004-12-01 | 2005-03-15 |  | 318d |  |
| 9 |  | GSTOP Project Business Lead Identified | 29d | 2004-12-15 | 2005-01-24 |  | 354d | finish no earlier than 2005-01-24 |
| 10 |  | Define and Assign Project Subteams and Leads | 5d? | 2005-01-24 | 2005-01-28 |  | 350d | start no earlier than 2005-01-24 |
| 11 |  | Develop Project Team Operating Principles & Guidelines | 5d? | 2005-01-24 | 2005-01-28 |  | 350d | start no earlier than 2005-01-24 |
| 12 | 1.2.1.4 | **Develop the GSTOP Project Management Plans** | 75d? | 2004-12-01 | 2005-03-15 |  | 318d |  |
| 13 |  | Review Charter and resolve any ambiguities/issues | 51d? | 2005-01-03 | 2005-03-14 |  | 306d | start no earlier than 2005-01-03 |
| 14 |  | Develop Intial Project Work Plan | 50d? | 2005-01-04 | 2005-03-14 |  | 306d | start no earlier than 2005-01-04 |
| 15 |  | Develop Intial Project Communication Plan | 72d | 2004-12-06 | 2005-03-15 |  | 305d | finish no earlier than 2005-03-15 |
| 16 |  | Develop Intial Project Responsibility Matrix | 1d? | 2004-12-01 | 2004-12-01 |  | 379d |  |
| 17 |  | Develop Intial Project Resource Plan | 31d? | 2005-01-31 | 2005-03-14 |  | 306d | start no earlier than 2005-01-31 |
| 18 | 1.2.1.5 | **Develop the GSTOP Communication and Management Structures** | 65d? | 2004-12-01 | 2005-03-01 |  | 328d |  |
| 19 |  | Research 4 websites and select option for public communications | 1d? | 2004-12-01 | 2004-12-01 |  | 379d |  |
| 20 |  | Create GSTOP private team workspace | 1d? | 2004-12-01 | 2004-12-01 |  | 379d |  |
| 21 |  | Develop Project Status Report Template | 42d? | 2005-01-03 | 2005-03-01 |  | 315d | start no earlier than 2005-01-03 |
| 22 |  | Team Meeting | 5d? | 2005-01-24 | 2005-01-28 |  | 350d | finish no earlier than 2005-01-28 |
| 23 |  | Progress Report to Executive Committee | 1d? | 2005-03-15 | 2005-03-15 |  | 305d | start no earlier than 2005-03-15 |
| 25 | 2 | **GSTOP Requirements** | 13d? | 2005-03-15 | 2005-04-01 | 23 | 305d |  |
| 26 | 2.1 | **Incident GIS Standard Symbology Requirements** | 4d? | 2005-03-16 | 2005-03-21 |  | 314d |  |
| 27 | 2.1.1 | **Establish Symbols Sub-Team business practices** | 1d? | 2005-03-16 | 2005-03-16 |  | 317d |  |
| 28 | 2.1.1.1 | **Develop a Symbol Sub-team Communication Plan** | 1d? | 2005-03-16 | 2005-03-16 |  | 317d |  |
| 29 |  | Define ground-rules for Sub-Team (internal) communication | 1d? | 2005-03-16 | 2005-03-16 |  | 317d |  |
| 30 |  | Define ground-rules for communication between the Symbol Sub-Team and other GSTOP Sub-Teams | 1d? | 2005-03-16 | 2005-03-16 |  | 317d |  |
| 31 |  | Define ground rules for communication between the Sub-Team and entities outside of the GSTOP Project | 1d? | 2005-03-16 | 2005-03-16 |  | 317d |  |
| 32 |  | Establish a process and schedule for Sub-Team (internal) progress report updates | 1d? | 2005-03-16 | 2005-03-16 |  | 317d |  |
| 33 |  | Establish a process and schedule for Sub-Team progress report updates to the GSTOP Team | 1d? | 2005-03-16 | 2005-03-16 |  | 317d |  |
| 34 | 2.1.1.2 | **Establish Review Processes** | 1d? | 2005-03-16 | 2005-03-16 |  | 317d |  |
| 35 |  | Establish a process for Sub-Team (internal) review of potential symbols | 1d? | 2005-03-16 | 2005-03-16 |  | 317d |  |
| 36 |  | Establish a process for Sub-Team (internal) review of the draft standard symbols | 1d? | 2005-03-16 | 2005-03-16 |  | 317d |  |
| 37 |  | Establish a process for peer reviews | 1d? | 2005-03-16 | 2005-03-16 |  | 317d |  |
| 38 |  | Establish a process for periodic GSTOP Team reviews | 1d? | 2005-03-16 | 2005-03-16 |  | 317d |  |
| 39 |  | Establish a process for reviewing the final report | 1d? | 2005-03-16 | 2005-03-16 |  | 317d |  |
| 40 | 2.1.1.3 | **Establish Change processes** | 1d? | 2005-03-16 | 2005-03-16 |  | 317d |  |
| 41 |  | Establish a process for additions/deletions of potential symbols mid-stream through the Project | 1d? | 2005-03-16 | 2005-03-16 |  | 317d |  |
| 42 |  | Establish a change process for the additions/deletion of standard symbols after the final recommendation has been submitted and prior to completion of the GSTOP project | 1d? | 2005-03-16 | 2005-03-16 |  | 317d |  |
| 43 |  | Establish a change process for the additions/deletion of standard symbols after the completion of the GSTOP project | 1d? | 2005-03-16 | 2005-03-16 |  | 317d |  |
| 44 | 2.1.2 | **Establish symbol evaluation methods** | 1d? | 2005-03-16 | 2005-03-16 |  | 317d |  |
| 45 |  | Define method for evaluating marker symbols | 1d? | 2005-03-16 | 2005-03-16 |  | 317d |  |
| 46 |  | Define method for evaluating line symbols | 1d? | 2005-03-16 | 2005-03-16 |  | 317d |  |
| 47 |  | Define method for evaluating fill symbols | 1d? | 2005-03-16 | 2005-03-16 |  | 317d |  |
| 48 |  | Conduct a final review of evaluation methods | 1d? | 2005-03-16 | 2005-03-16 |  | 317d |  |
| 49 | 2.1.3 | **Define criteria for the acceptance of symbols as standards** | 1d? | 2005-03-16 | 2005-03-16 |  | 317d |  |
| 50 |  | Develop acceptance criteria for marker symbols | 1d? | 2005-03-16 | 2005-03-16 |  | 317d |  |
| 51 |  | Develop acceptance criteria for line symbols | 1d? | 2005-03-16 | 2005-03-16 |  | 317d |  |
| 52 |  | Develop acceptance criteria for fill symbols | 1d? | 2005-03-16 | 2005-03-16 |  | 317d |  |
| 53 |  | Conduct a final review of selection criteria | 1d? | 2005-03-16 | 2005-03-16 |  | 317d |  |
| 54 | 2.1.4 | **Establish file format for symbols** | 1d? | 2005-03-16 | 2005-03-16 |  | 317d |  |
| 55 |  | Define acceptable formats of symbols for evaluation | 1d? | 2005-03-16 | 2005-03-16 |  | 317d |  |
| 56 |  | Define format of recommended standard symbols | 1d? | 2005-03-16 | 2005-03-16 |  | 317d |  |
| 57 | 2.1.5 | **Develop a list of symbols to be evaluated for acceptance as draft standards** | 1d? | 2005-03-16 | 2005-03-16 |  | 317d |  |
| 58 |  | Collect Fire mapping symbols from the Fireline Handbook | 1d? | 2005-03-16 | 2005-03-16 |  | 317d |  |
| 59 |  | Collect Fire mapping symbols suggestions from the 5 federal fire management agencies (FS, BLM, NPS, FWS, BIA) and state agencies via the NWCG Geospatial Task Group (GTG) | 1d? | 2005-03-16 | 2005-03-16 |  | 317d |  |
| 60 |  | Collect Fire mapping symbols from HSA (FEMA), FAA, and DOD | 1d? | 2005-03-16 | 2005-03-16 |  | 317d |  |
| 61 |  | Document potential sources for additional fire mapping symbols | 1d? | 2005-03-16 | 2005-03-16 |  | 317d |  |
| 62 |  | Compile symbols into a single potential symbol set | 1d? | 2005-03-16 | 2005-03-16 |  | 317d |  |
| 63 | 2.1.6 | **Determine the draft standard marker symbols** | 1d? | 2005-03-16 | 2005-03-16 |  | 317d |  |
| 64 |  | Evaluate each potential marker symbol against the marker symbol selection criteria | 1d? | 2005-03-16 | 2005-03-16 |  | 317d |  |
| 65 |  | Selection the draft standard marker symbols | 1d? | 2005-03-16 | 2005-03-16 |  | 317d |  |
| 66 |  | Conduct a completeness review of the draft standard marker symbols | 1d? | 2005-03-16 | 2005-03-16 |  | 317d |  |
| 67 | 2.1.7 | **Determine the draft standard line symbols** | 1d? | 2005-03-16 | 2005-03-16 |  | 317d |  |
| 68 |  | Evaluate each potential line symbol against the line symbol selection criteria | 1d? | 2005-03-16 | 2005-03-16 |  | 317d |  |
| 69 |  | Select the draft standard line symbols | 1d? | 2005-03-16 | 2005-03-16 |  | 317d |  |
| 70 |  | Conduct a completeness review of the draft standard line symbols | 1d? | 2005-03-16 | 2005-03-16 |  | 317d |  |
| 71 | 2.1.8 | **Determine the draft standard fill symbols** | 1d? | 2005-03-16 | 2005-03-16 |  | 317d |  |

| ID | WBS | Task | Duration | Start | Finish | Predecessors | Total float |
| --- | --- | --- | --- | --- | --- | --- | --- |
| 72 |  | Evaluate each potential fill symbol against the fill symbol selection criteria | 1d? | 2005-03-16 | 2005-03-16 |  | 317d |
| 73 |  | Select the draft standard fill symbols | 1d? | 2005-03-16 | 2005-03-16 |  | 317d |
| 74 |  | Conduct a completeness review of the draft standard fill symbols | 1d? | 2005-03-16 | 2005-03-16 |  | 317d |
| 75 | 2.1.9 | **Conduct initial peer review of the draft standard marker, line, and fill symbols** | 4d? | 2005-03-16 | 2005-03-21 |  | 314d |
| 76 |  | Prepare draft standard symbols for initial peer review | 1d? | 2005-03-16 | 2005-03-16 |  | 317d |
| 77 |  | Submit the draft standard symbols to the 5 federal fire management agencies and State agencies via the NWCG Geospatial Task Group (GTG); and to the HSA (FEMA), FAA, DOD, and GSTOP Team for peer review | 1d? | 2005-03-16 | 2005-03-16 |  | 314d |
| 78 |  | Review feedback of initial peer review | 1d? | 2005-03-17 | 2005-03-17 | 77 | 314d |
| 79 |  | Identify required changes to draft standard symbols based on the initial peer review feedback | 1d? | 2005-03-18 | 2005-03-18 | 78 | 314d |
| 80 |  | Make required changes, as identified, to draft standard symbols | 1d? | 2005-03-21 | 2005-03-21 | 79 | 314d |
| 81 | 2.1.10 | **Conduct final peer review of the draft standard marker, line and fill symbols** | 1d? | 2005-03-16 | 2005-03-16 |  | 317d |
| 82 |  | Prepare draft standard symbols for final peer review | 1d? | 2005-03-16 | 2005-03-16 |  | 317d |
| 83 |  | Submit the draft standard symbols to the 5 federal fire management agencies and State agencies via the NWCG Geospatial Task Group (GTG); and to the HSA (FEMA), FAA, DOD, and GSTOP Team for peer review | 1d? | 2005-03-16 | 2005-03-16 |  | 317d |
| 84 |  | Review feedback of the final peer review | 1d? | 2005-03-16 | 2005-03-16 |  | 317d |
| 85 |  | Identify required changes to draft standard symbols based on the final peer review feedback | 1d? | 2005-03-16 | 2005-03-16 |  | 317d |
| 86 |  | Make required changes, as identified, to draft standard symbols | 1d? | 2005-03-16 | 2005-03-16 |  | 317d |
| 87 |  | Ratify the final draft standard symbols | 1d? | 2005-03-16 | 2005-03-16 |  | 317d |
| 88 | 2.1.11 | **Finalize recommendation of standard Fire Mapping symbols** | 1d? | 2005-03-16 | 2005-03-16 |  | 317d |
| 89 |  | Create a report recommending the adoption of the draft standard symbols | 1d? | 2005-03-16 | 2005-03-16 |  | 317d |
| 90 |  | Conduct a review of the report | 1d? | 2005-03-16 | 2005-03-16 |  | 317d |
| 91 |  | Submit the report to GSTOP-PM | 1d | 2005-03-16 | 2005-03-16 |  | 317d |
| 92 | 2.2 | **Incident GIS Standard Naming Conventions Requirements** | 12d? | 2005-03-16 | 2005-03-31 |  | 306d |
| 93 | 2.2.1 | **Define Information Needs (What do we need to gather?)** | 1d? | 2005-03-16 | 2005-03-16 |  | 317d |
| 94 |  | Set objectives for work plan | 1d? | 2005-03-16 | 2005-03-16 |  | 317d |
| 95 |  | Define ground rules for sub team | 1d? | 2005-03-16 | 2005-03-16 |  | 317d |
| 96 |  | Define common ground with other sub teams | 1d? | 2005-03-16 | 2005-03-16 |  | 317d |
| 97 | 2.2.2 | **Collect Information** | 1d? | 2005-03-16 | 2005-03-16 |  | 312d |
| 98 |  | Collect existing naming and filing conventions from GIST's attached to IMT's | 1d? | 2005-03-16 | 2005-03-16 |  | 312d |
| 99 | 2.2.3 | **Conduct Analysis** | 2d? | 2005-03-17 | 2005-03-18 | 98 | 312d |
| 100 |  | Review strengths & weaknesses of existing methodologies | 1d? | 2005-03-17 | 2005-03-17 |  | 312d |
| 101 |  | Resolve overlap and conflicts | 1d? | 2005-03-18 | 2005-03-18 | 100 | 312d |
| 102 | 2.2.4 | **Develop Preliminary Requirements Specifications** | 2d? | 2005-03-21 | 2005-03-22 | 101 | 312d |
| 103 |  | Draft naming convention guidelines | 1d? | 2005-03-21 | 2005-03-21 |  | 312d |
| 104 |  | Draft directory structure guidelines | 1d? | 2005-03-22 | 2005-03-22 | 103 | 312d |
| 105 | 2.2.5 | **Requirements Review and Validation** | 1d? | 2005-03-23 | 2005-03-23 | 104 | 312d |
| 106 |  | Post draft guidelines for inter team review | 1d? | 2005-03-23 | 2005-03-23 |  | 312d |
| 107 |  | Edit draft guidelines based on input | 1d? | 2005-03-23 | 2005-03-23 |  | 312d |
| 108 |  | Post draft guidelines for external review | 1d? | 2005-03-23 | 2005-03-23 |  | 312d |
| 109 |  | Edit draft guidelines based on input | 1d? | 2005-03-23 | 2005-03-23 |  | 312d |
| 110 | 2.2.6 | **Prepare Sample Documents** | 1d? | 2005-03-16 | 2005-03-16 |  | 317d |
| 111 |  | Prepare Naming conventions | 1d? | 2005-03-16 | 2005-03-16 |  | 317d |
| 112 |  | Develop Directory structure | 1d? | 2005-03-16 | 2005-03-16 |  | 317d |
| 113 |  | Prepare Methods of work | 1d? | 2005-03-16 | 2005-03-16 |  | 317d |
| 114 | 2.2.7 | **Sample Documents Review and Validation** | 12d? | 2005-03-16 | 2005-03-31 |  | 306d |
| 115 |  | Post sample documents for inter team review | 1d? | 2005-03-16 | 2005-03-16 |  | 317d |
| 116 |  | Edit sample documents based on input | 1d? | 2005-03-16 | 2005-03-16 |  | 317d |
| 117 |  | Post sample documents for external review | 5d? | 2005-03-16 | 2005-03-22 |  | 313d |
| 118 |  | Edit sample documents based on input | 12d? | 2005-03-16 | 2005-03-31 |  | 306d |
| 119 | 2.3 | **Incident GIS Standard Product Definitions Requirements** | 8d? | 2005-03-16 | 2005-03-25 |  | 310d |
| 120 | 2.3.1 | **Define Information Needs (What do we need to gather?)** | 4d? | 2005-03-16 | 2005-03-21 |  | 314d |
| 121 |  | Develop Standard Products Matrix to compare many versions of standard products. (GIST Draft Taskbook/GIST Course Workbook/PNWCG Product Objectives) | 1d? | 2005-03-16 | 2005-03-16 |  | 314d |
| 122 |  | Acquire DPRO Standards and incorporate into above matrix. | 1d? | 2005-03-17 | 2005-03-17 | 121 | 314d |
| 123 |  | Need group assistance – there are no members who volunteered for this subgroup. It will need the participation of everyone to work. | 1d? | 2005-03-18 | 2005-03-18 | 122 | 314d |
| 124 |  | Provide a final package of Standard Products including definitions and examples. | 1d? | 2005-03-21 | 2005-03-21 | 123 | 314d |
| 125 | 2.3.2 | **Collect Information** | 3d? | 2005-03-16 | 2005-03-18 |  | 310d |
| 126 |  | Definitions exist in the National Training course workbook for GIST. PNWCG has also created some standard definitions. Compile these into a list for group to review. Cite source. | 1d? | 2005-03-16 | 2005-03-16 |  | 310d |
| 127 |  | Review DPRO product definitions and compare to existing definitions for GIST. | 1d? | 2005-03-17 | 2005-03-17 | 126 | 310d |
| 128 |  | Collect examples of standard products. | 1d? | 2005-03-18 | 2005-03-18 | 127 | 310d |
| 129 | 2.3.3 | **Conduct Analysis** | 2d? | 2005-03-21 | 2005-03-22 | 128 | 310d |
| 130 |  | Review existing standards definitions (GIST course/PNWCG/DPRO) | 1d? | 2005-03-21 | 2005-03-21 |  | 310d |
| 131 |  | Identify discrepancies between groups defining standard and bring these to the larger group for discussion and resolution. There may be specific reasons for discrepancies (Fire Use vs. Type 1) so these should be highlighted for the preliminary package. | 1d? | 2005-03-22 | 2005-03-22 | 130 | 310d |
| 132 | 2.3.4 | **Develop Preliminary Requirements Specifications** | 2d? | 2005-03-23 | 2005-03-24 | 131 | 310d |
| 133 |  | Provide a package of products definitions and samples for group review (GIST/SITL review?) | 1d? | 2005-03-23 | 2005-03-23 |  | 310d |
| 134 |  | Find a storage location for GSTOP group review (NIFC site?) | 1d? | 2005-03-24 | 2005-03-24 | 133 | 310d |
| 135 | 2.3.5 | **Review and Validate Requirements** | 1d? | 2005-03-25 | 2005-03-25 | 134 | 310d |
| 136 |  | Decide upon method of acceptance/rejection/modification | 1d? | 2005-03-25 | 2005-03-25 |  | 310d |
| 137 |  | Decide who to get feedback from (GIST 1st, then SITL/PLSC/others?) | 1d? | 2005-03-25 | 2005-03-25 |  | 310d |
| 138 |  | Incorporate feedback into final package of definitions & samples | 1d? | 2005-03-25 | 2005-03-25 |  | 310d |
| 139 |  | Find a permanent storage location for this package? National clearinghouse? | 1d? | 2005-03-25 | 2005-03-25 |  | 310d |
| 140 | 2.4 | **Incident GIST Minimum Qualifications Requirements** | 1d? | 2005-03-16 | 2005-03-16 |  | 317d |
| 141 | 2.4.1 | **Establish Min GIST qualifications/GIS expectations Sub-Team business practices** | 1d? | 2005-03-16 | 2005-03-16 |  | 317d |

| ID | WBS | Task | Duration | Start | Finish | Predecessors | Total float |
| --- | --- | --- | --- | --- | --- | --- | --- |
| 142 | 2.4.1.1 | **Develop a Symbol Sub-team Communication Plan** | 1d? | 2005-03-16 | 2005-03-16 |  | 317d |
| 143 |  | Define ground-rules for Sub-Team (internal) communication | 1d? | 2005-03-16 | 2005-03-16 |  | 317d |
| 144 |  | Define ground-rules for communication between the Min GIST qualifications/GIS expectations Sub-Team and other GSTOP Sub-Teams | 1d? | 2005-03-16 | 2005-03-16 |  | 317d |
| 145 |  | Define ground rules for communication between the Sub-Team and entities outside of the GSTOP Project | 1d? | 2005-03-16 | 2005-03-16 |  | 317d |
| 146 |  | Establish a process and schedule for Sub-Team (internal) progress report updates | 1d? | 2005-03-16 | 2005-03-16 |  | 317d |
| 147 |  | Establish a process and schedule for Sub-Team progress report updates to the GSTOP Team | 1d? | 2005-03-16 | 2005-03-16 |  | 317d |
| 148 | 2.4.1.2 | **Establish Review Processes** | 1d? | 2005-03-16 | 2005-03-16 |  | 317d |
| 149 |  | Establish a process for Sub-Team (internal) review of potential minimum GIST qualifications/GIS expectations | 1d? | 2005-03-16 | 2005-03-16 |  | 317d |
| 150 |  | Establish a process for Sub-Team (internal) review of the draft minimum GIST qualifications/GIS expectations | 1d? | 2005-03-16 | 2005-03-16 |  | 317d |
| 151 |  | Establish a process for peer reviews | 1d? | 2005-03-16 | 2005-03-16 |  | 317d |
| 152 |  | Establish a process for periodic GSTOP Team reviews | 1d? | 2005-03-16 | 2005-03-16 |  | 317d |
| 153 |  | Establish a process for reviewing the final report | 1d? | 2005-03-16 | 2005-03-16 |  | 317d |
| 154 | 2.4.1.3 | **Establish Change processes** | 1d? | 2005-03-16 | 2005-03-16 |  | 317d |
| 155 |  | Establish a process for additions/deletions of potential minimum GIST qualifications/GIS expectations mid-stream through the project | 1d? | 2005-03-16 | 2005-03-16 |  | 317d |
| 156 |  | Establish a change process for the additions/deletion of minimum GIST qualifications/GIS expectations after the final recommendation has been submitted and prior to completion of the GSTOP project | 1d? | 2005-03-16 | 2005-03-16 |  | 317d |
| 157 |  | Establish a change process for the additions/deletion of minimum GIST qualifications/GIS expectations after the completion of the GSTOP project | 1d? | 2005-03-16 | 2005-03-16 |  | 317d |
| 158 | 2.4.2 | **Establish evaluation methods for minimum GIST qualifications/GIS expectations** | 1d? | 2005-03-16 | 2005-03-16 |  | 317d |
| 159 |  | Define method for evaluating minimum GIST qualifications/GIS expectations | 1d? | 2005-03-16 | 2005-03-16 |  | 317d |
| 160 |  | Conduct a final review of evaluation methods | 1d? | 2005-03-16 | 2005-03-16 |  | 317d |
| 161 | 2.4.3 | **Define criteria for the acceptance of minimum GIST qualifications/GIS expectations** | 1d? | 2005-03-16 | 2005-03-16 |  | 317d |
| 162 |  | Develop acceptance criteria for minimum GIST qualifications/GIS expectations | 1d? | 2005-03-16 | 2005-03-16 |  | 317d |
| 163 |  | Conduct a final review of selection criteria | 1d? | 2005-03-16 | 2005-03-16 |  | 317d |
| 164 | 2.4.4 | **Collect Information on minimum GIST qualifications and minimum GIS expectations on an incident** | 1d? | 2005-03-16 | 2005-03-16 |  | 317d |
| 165 |  | Gather documents and references (including white papers, memos, After Action Reviews) | 1d? | 2005-03-16 | 2005-03-16 |  | 317d |
| 166 |  | Scan or translate paper documents to electronic format | 1d? | 2005-03-16 | 2005-03-16 |  | 317d |
| 167 |  | Research current GIST/GIS standards | 1d? | 2005-03-16 | 2005-03-16 |  | 317d |
| 168 | 2.4.5 | **Develop a list of GIST qualifications to be evaluated for acceptance as draft minimum standards** | 1d? | 2005-03-16 | 2005-03-16 |  | 317d |
| 169 |  | Compare the current GIST standards | 1d? | 2005-03-16 | 2005-03-16 |  | 317d |
| 170 |  | Compile the GIST qualifications into a single list of potential minimum GIST qualifications | 1d? | 2005-03-16 | 2005-03-16 |  | 317d |
| 171 |  | Compile a list of GIST qualifications which are deemed to be beyond the minimum for future reference | 1d? | 2005-03-16 | 2005-03-16 |  | 317d |
| 172 | 2.4.6 | **Develop a list of GIS expectations to be evaluated for acceptance as draft minimum standards** | 1d? | 2005-03-16 | 2005-03-16 |  | 317d |
| 173 |  | Compare any current GIS expectation standards | 1d? | 2005-03-16 | 2005-03-16 |  | 317d |
| 174 |  | Compile the GIS expectations into a list of potential minimum GIS expectations on an incident | 1d? | 2005-03-16 | 2005-03-16 |  | 317d |
| 175 |  | Compile a list of GIST qualifications which are deemed to be beyond the minimum for future reference | 1d? | 2005-03-16 | 2005-03-16 |  | 317d |
| 176 | 2.4.7 | **Determine the draft standard minimum GIST qualifications** | 1d? | 2005-03-16 | 2005-03-16 |  | 317d |
| 177 |  | Evaluate each potential minimum GIST qualification using the evaluation methods in 2.4.2 | 1d? | 2005-03-16 | 2005-03-16 |  | 317d |
| 178 |  | Select the minimum GIST qualifications | 1d? | 2005-03-16 | 2005-03-16 |  | 317d |
| 179 |  | Conduct a completeness review of the draft minimum GIST qualifications | 1d? | 2005-03-16 | 2005-03-16 |  | 317d |
| 180 | 2.4.8 | **Determine the draft standard minimum GIS expectations** | 1d? | 2005-03-16 | 2005-03-16 |  | 317d |
| 181 |  | Evaluate each potential minimum GIS expectation using the evaluation methods in 2.4.2 | 1d? | 2005-03-16 | 2005-03-16 |  | 317d |
| 182 |  | Select the minimum GIS expectations | 1d? | 2005-03-16 | 2005-03-16 |  | 317d |
| 183 |  | Conduct a completeness review of the draft minimum GIS expectations | 1d? | 2005-03-16 | 2005-03-16 |  | 317d |
| 184 | 2.4.9 | **Conduct internal review of draft standard minimum GIST qualifications and GIS expectations** | 1d? | 2005-03-16 | 2005-03-16 |  | 317d |
| 185 |  | Prepare draft standard minimum GIST qualifications and GIS expectations, including acceptance criteria | 1d? | 2005-03-16 | 2005-03-16 |  | 317d |
| 186 |  | Post draft standard to DisasterHelp website and notify GSTOP team for group review | 1d? | 2005-03-16 | 2005-03-16 |  | 317d |
| 187 |  | Provide data location and review process to internal group | 1d? | 2005-03-16 | 2005-03-16 |  | 317d |
| 188 |  | Review feedback of initial peer review | 1d? | 2005-03-16 | 2005-03-16 |  | 317d |
| 189 |  | Identify required changes to draft standard based on the initial peer review feedback | 1d? | 2005-03-16 | 2005-03-16 |  | 317d |
| 190 |  | Make required changes, as identified, to draft standard | 1d? | 2005-03-16 | 2005-03-16 |  | 317d |
| 191 | 2.4.10 | **Conduct final peer review of the draft standard minimum GIST qualifications and GIS expectations** | 1d? | 2005-03-16 | 2005-03-16 |  | 317d |
| 192 |  | Prepare survey or questionnaire to accompany draft standards for final peer review. | 1d? | 2005-03-16 | 2005-03-16 |  | 317d |
| 193 |  | Prepare draft standard minimum GIST Qualification/GIST expectations for final peer review, including the survey or questionnaire | 1d? | 2005-03-16 | 2005-03-16 |  | 317d |
| 194 |  | Submit the draft expectations to the 5 federal fire management agencies and State agencies via the NWCG Geospatial Task Group (GTG); and to the HSA (FEMA), FAA, DOD, and GSTOP Team for peer review. | 1d? | 2005-03-16 | 2005-03-16 |  | 317d |
| 195 |  | Review feedback of the final peer review, including questionnaire or survey | 1d? | 2005-03-16 | 2005-03-16 |  | 317d |
| 196 |  | Identify required changes to draft standard minimum GIST qualifications/GIS expectations based on the final peer review feedback | 1d? | 2005-03-16 | 2005-03-16 |  | 317d |
| 197 |  | Make required changes, as identified, to draft minimum GIST qualifications/GIS expectations symbols | 1d? | 2005-03-16 | 2005-03-16 |  | 317d |
| 198 |  | Ratify the final draft standard minimum GIST qualifications/GIS expectations | 1d? | 2005-03-16 | 2005-03-16 |  | 317d |
| 199 | 2.4.11 | **Finalize recommendation of standard Minimum GIST Qualifications and Minimum GIS Expectations on an Incident** | 1d? | 2005-03-16 | 2005-03-16 |  | 317d |
| 200 |  | Create a report recommending the adoption of the draft minimum GIST Qualifications/GIS Expectations | 1d? | 2005-03-16 | 2005-03-16 |  | 317d |
| 201 |  | Conduct a review of the report for completeness, accuracy, language, and grammar | 1d? | 2005-03-16 | 2005-03-16 |  | 317d |
| 202 |  | Submit the report to GSTOP-PM | 1d? | 2005-03-16 | 2005-03-16 |  | 317d |
| 203 | 2.5 | **Incident GIS Minimum Essential Datasets Requirements** | 13d? | 2005-03-15 | 2005-04-01 |  | 305d |
| 204 |  | Establish MED Sub-Team business practices | 1d? | 2005-03-16 | 2005-03-16 |  | 317d |
| 205 | 2.5.2 | **Develop a MED Sub-team Communication Plan** | 13d? | 2005-03-16 | 2005-04-01 |  | 305d |
| 206 | 2.5.2.1 | **Define ground-rules for Sub-Team (internal) communication** | 7d? | 2005-03-16 | 2005-03-24 |  | 305d |
| 207 |  | Define ground-rules for communication between the MED Sub-Team and other GSTOP Sub-Teams | 1d? | 2005-03-16 | 2005-03-16 |  | 305d |
| 208 |  | Define ground rules for communication between the Sub-Team and entities outside of the GSTOP Project | 1d? | 2005-03-17 | 2005-03-17 | 207 | 305d |
| 209 |  | Establish a process and schedule for Sub-Team (internal) progress report updates | 1d? | 2005-03-18 | 2005-03-18 | 208 | 305d |
| 210 |  | Establish a process and schedule for Sub-Team progress report updates to the GSTOP Team | 1d? | 2005-03-21 | 2005-03-21 | 209 | 305d |
| 211 |  | Establish Review Processes | 1d? | 2005-03-22 | 2005-03-22 | 210 | 305d |

| ID | WBS | Task | Duration | Start | Finish | Predecessors | Total float | Constraint |
| --- | --- | --- | --- | --- | --- | --- | --- | --- |
| 212 |  | Establish a process for Sub-Team (internal) review of potential MEDs | 1d? | 2005-03-23 | 2005-03-23 | 211 | 305d |  |
| 213 |  | Establish a process for Sub-Team (internal) review of the draft standard MEDs | 1d? | 2005-03-24 | 2005-03-24 | 212 | 305d |  |
| 214 | 2.5.2.2 | **Establish a process for peer reviews** | 2d? | 2005-03-25 | 2005-03-28 | 213 | 305d |  |
| 215 |  | Establish a process for periodic GSTOP Team reviews | 1d? | 2005-03-25 | 2005-03-25 |  | 305d |  |
| 216 |  | Establish a process for reviewing the final report | 1d? | 2005-03-28 | 2005-03-28 | 215 | 305d |  |
| 217 | 2.5.2.3 | **Establish Change processes** | 2d? | 2005-03-29 | 2005-03-30 | 216 | 305d |  |
| 218 |  | Establish a process for additions/deletions of potential MEDs mid-stream through the Project | 1d? | 2005-03-29 | 2005-03-29 |  | 305d |  |
| 219 |  | Establish a change process for the additions/deletion of standard MEDs after the final recommendation has been submitted | 1d? | 2005-03-30 | 2005-03-30 | 218 | 305d |  |
| 220 | 2.5.2.4 | **Establish a change process for the additions/deletion of standard MEDs after the final recommendation has been approved through the GSTOP Project** | 1d? | 2005-03-31 | 2005-03-31 | 219 | 305d |  |
| 221 |  | Establish MED evaluation methods | 1d? | 2005-03-31 | 2005-03-31 |  | 305d |  |
| 222 |  | Define method for evaluating marker MEDs | 1d? | 2005-04-01 | 2005-04-01 | 221 | 305d |  |
| 223 |  | Define method for evaluating line MEDs | 1d? | 2005-03-16 | 2005-03-16 |  | 317d |  |
| 224 | 2.5.3 | **Define method for evaluating fill MEDs** | 2d? | 2005-03-16 | 2005-03-17 |  | 316d |  |
| 225 | 2.5.3.1 | **Conduct a final review of evaluation methods** | 1d? | 2005-03-16 | 2005-03-16 |  | 317d |  |
| 226 |  | Define criteria for the acceptance of MEDs as standards | 1d? | 2005-03-16 | 2005-03-16 |  | 317d |  |
| 227 |  | Develop acceptance criteria for marker MEDs | 1d? | 2005-03-16 | 2005-03-16 |  | 317d |  |
| 228 |  | Develop acceptance criteria for line MEDs | 1d? | 2005-03-16 | 2005-03-16 |  | 317d |  |
| 229 | 2.5.3.2 | **Develop acceptance criteria for fill MEDs** | 1d? | 2005-03-16 | 2005-03-16 |  | 317d |  |
| 230 |  | Conduct a final review of selection criteria | 1d? | 2005-03-16 | 2005-03-16 |  | 317d |  |
| 231 | 2.5.3.3 | **Develop a list of MEDs to be evaluated for acceptance as draft standards** | 1d? | 2005-03-16 | 2005-03-16 |  | 317d |  |
| 232 |  | Collect Fire mapping MEDs from the 5 federal fire management agencies (FS, BLM, NPS, FWS, BIA), state agencies, and USGS via the NWCG Geospatial Task Group (GTG) | 1d? | 2005-03-16 | 2005-03-16 |  | 317d |  |
| 233 | 2.5.3.4 | **Collect Fire mapping MEDs from DHS (FEMA), FAA, and DOD** | 1d? | 2005-03-16 | 2005-03-16 |  | 316d |  |
| 234 |  | Document potential sources for additional fire mapping MEDs | 1d? | 2005-03-16 | 2005-03-16 |  | 316d |  |
| 235 |  | Compile MEDs into a single potential MED set | 1d? | 2005-03-17 | 2005-03-17 | 234 | 316d |  |
| 236 | 2.5.4 | **Determine the draft standard Raster MEDs** | 1d? | 2005-03-16 | 2005-03-16 |  | 317d |  |
| 237 | 2.5.4.1 | **Evaluate each potential marker MED against the marker MED selection criteria** | 1d? | 2005-03-16 | 2005-03-16 |  | 317d |  |
| 238 |  | Sub-Team selection of the draft standard marker MEDs | 1d? | 2005-03-16 | 2005-03-16 |  | 317d |  |
| 239 |  | Conduct a Sub-team completeness review of the draft standard marker MEDs | 1d? | 2005-03-16 | 2005-03-16 |  | 317d |  |
| 240 |  | Determine the draft standard Vector MEDs | 1d? | 2005-03-16 | 2005-03-16 |  | 317d |  |
| 241 |  | Evaluate each potential line MED against the line MED selection criteria | 1d? | 2005-03-16 | 2005-03-16 |  | 317d |  |
| 242 | 2.5.4.3 | **Sub-Team selection of the draft standard line MEDs** | 1d? | 2005-03-16 | 2005-03-16 |  | 317d |  |
| 243 |  | Conduct a Sub-team completeness review of the draft standard line MEDs | 1d? | 2005-03-16 | 2005-03-16 |  | 317d |  |
| 244 |  | Determine the draft standard Point MEDs | 1d? | 2005-03-16 | 2005-03-16 |  | 317d |  |
| 245 |  | Evaluate each potential fill MED against the fill MED selection criteria | 1d? | 2005-03-16 | 2005-03-16 |  | 317d |  |
| 246 |  | Sub-Team selection of the draft standard fill MEDs | 1d? | 2005-03-16 | 2005-03-16 |  | 317d |  |
| 247 |  | Conduct a Sub-team completeness review of the draft standard fill MEDs | 1d? | 2005-03-16 | 2005-03-16 |  | 317d |  |
| 248 |  | Conduct initial peer review of the draft standard marker, line, and fill MEDs | 1d? | 2005-03-16 | 2005-03-16 |  | 317d |  |
| 249 |  | Prepare draft standard MEDs for initial peer review | 1d? | 2005-03-16 | 2005-03-16 |  | 317d |  |
| 250 |  | Submit the draft standard MEDs to the 5 federal fire management agencies, State agencies, and USGS via the NWCG Geospatial Task Group (GTG); and to DHS (FEMA), FAA, DOD, and GSTOP Team for peer review | 0d | 2005-03-15 | 2005-03-15 |  | 318d |  |
| 251 |  | Review feedback of initial peer review | 1d? | 2005-03-16 | 2005-03-16 |  | 317d |  |
| 252 | 2.5.10 | **Identify required changes to draft standard MEDs based on the initial peer review feedback** | 1d? | 2005-03-15 | 2005-03-16 |  | 317d |  |
| 253 | 2.5.10.1 | **Make required changes, as identified, to draft standard MEDs** | 1d? | 2005-03-16 | 2005-03-16 |  | 317d |  |
| 254 |  | Conduct final peer review of the draft standard marker, line, and fill MEDs | 1d? | 2005-03-16 | 2005-03-16 |  | 317d |  |
| 255 |  | Prepare draft standard MEDs for final peer review | 1d? | 2005-03-16 | 2005-03-16 |  | 317d |  |
| 256 | 2.5.10.2 | **Submit the draft standard MEDs to the 5 federal fire management agencies and State agencies via the NWCG Geospatial Task Group (GTG); and to the HSA (FEMA), FAA, DOD, and GSTOP Team for peer review** | 1d? | 2005-03-16 | 2005-03-16 |  | 317d |  |
| 257 |  | Review feedback of the final peer review | 1d? | 2005-03-16 | 2005-03-16 |  | 317d |  |
| 258 |  | Identify required changes to draft standard MEDs based on the final peer review feedback | 1d? | 2005-03-16 | 2005-03-16 |  | 317d |  |
| 259 |  | Make required changes, as identified, to draft standard MEDs | 1d? | 2005-03-16 | 2005-03-16 |  | 317d |  |
| 260 |  | Ratification of the final draft standard MEDs by the Sub-Team | 1d? | 2005-03-16 | 2005-03-16 |  | 317d |  |
| 261 | 2.5.10.3 | **Finalize recommendation of standard Fire Mapping MEDs** | 1d? | 2005-03-16 | 2005-03-16 |  | 317d |  |
| 262 |  | Create a report recommending the adoption of the draft standard MEDs | 1d? | 2005-03-16 | 2005-03-16 |  | 317d |  |
| 263 |  | Conduct a Sub-Team review of the report | 1d? | 2005-03-16 | 2005-03-16 |  | 317d |  |
| 264 |  | Submit the report to GSTOP-PM | 1d? | 2005-03-16 | 2005-03-16 |  | 317d |  |
| 265 |  | Review and Validate draft SOP’s for completeness | 0.5d? | 2005-03-16 | 2005-03-16 |  | 317.5d |  |
| 266 |  | Review and Validate draft SOP’s for GIS content | 1d? | 2005-03-16 | 2005-03-16 |  | 317d |  |
| 267 |  | consolidate reviewers inputs | 1d? | 2005-03-16 | 2005-03-16 |  | 317d |  |
| 268 |  | Evaluate Feedback for inclusion in SOP revision | 1d? | 2005-03-16 | 2005-03-16 |  | 317d |  |
| 269 |  | Incorporate accepted feedback from reviewers | 1d? | 2005-03-16 | 2005-03-16 |  | 317d |  |
| 270 | 2.5.10.4 | **Agencies' review of Draft SOPs** | 1d? | 2005-03-16 | 2005-03-16 |  | 317d |  |
| 271 |  | Create a cover letter, and response process | 1d? | 2005-03-16 | 2005-03-16 |  | 317d |  |
| 272 |  | Review and Validate draft SOP’s | 1d? | 2005-03-16 | 2005-03-16 |  | 317d |  |
| 273 |  | Evaluate Feedback for inclusion in SOP revision | 1d? | 2005-03-16 | 2005-03-16 |  | 317d |  |
| 274 |  | Incorporate Feedback from reviewers | 1d? | 2005-03-16 | 2005-03-16 |  | 317d |  |
| 275 |  | Develop GSTOP Change Management Plan | 1d? | 2005-03-16 | 2005-03-16 |  | 317d |  |
| 276 |  | Review GSTOP Change Management Plan | 1d? | 2005-03-16 | 2005-03-16 |  | 317d |  |
| 277 |  | PRELIMINARY GIS SOP’s READY FOR FIELD TESTING | 0d | 2005-03-15 | 2005-03-15 |  | 318d | start no earlier than 2005-01-18 |
| 278 | 2.6 | **Incident GIS Standard Data Sharing and Archiving Standards (02-08-2005)** | 1d? | 2005-03-16 | 2005-03-16 |  | 317d |  |
| 279 |  | Define Information Needs (What do we need to gather?) | 1d? | 2005-03-16 | 2005-03-16 |  | 317d |  |
| 280 |  | Compile existing archiving standards in use (e.g. data format, transfer mode) | 1d? | 2005-03-16 | 2005-03-16 |  | 317d |  |
| 281 |  | Identify how archiving is done at present time by ICS, military, other incident responders, project-management | 1d? | 2005-03-16 | 2005-03-16 |  | 317d |  |

| ID | WBS | Task | Duration | Start | Finish | Total float | Constraint |
| --- | --- | --- | --- | --- | --- | --- | --- |
| 282 |  | Gather NARA, Records Management requirements (review policies, lawsuits) e.g. physical location, acceptable media, supporting documentation | 1d? | 2005-03-16 | 2005-03-16 | 317d |  |
| 283 |  | Determine the least common denominator (shapefile) or possibility of multiple formats | 1d? | 2005-03-16 | 2005-03-16 | 317d |  |
| 284 | 2.6.2 | **Collect Information** | 1d? | 2005-03-16 | 2005-03-16 | 317d |  |
| 285 |  | Conduct literature review | 1d? | 2005-03-16 | 2005-03-16 | 317d |  |
| 286 | 2.6.3 | **Conduct Analysis** | 1d? | 2005-03-16 | 2005-03-16 | 317d |  |
| 287 |  | Compile, Synthesize requirements | 1d? | 2005-03-16 | 2005-03-16 | 317d |  |
| 288 | 2.6.4 | **Develop Preliminary Requirements Specifications** | 1d? | 2005-03-16 | 2005-03-16 | 317d |  |
| 289 |  | Proposal of SOP | 1d? | 2005-03-16 | 2005-03-16 | 317d |  |
| 290 | 2.6.5 | **Review and Validate Requirements** | 1d? | 2005-03-16 | 2005-03-16 | 317d |  |
| 291 |  | Sub-Team Review of SOP | 1d? | 2005-03-16 | 2005-03-16 | 317d |  |
| 292 |  | Revise, Edit Proposed SOP | 1d? | 2005-03-16 | 2005-03-16 | 317d |  |
| 293 |  | Submit to Project Manager for Team Review | 1d? | 2005-03-16 | 2005-03-16 | 317d |  |
| 295 | 2.7 | **Incident GIS Standard Documentation and Archiving** | 1d? | 2005-03-16 | 2005-03-16 | 317d |  |
| 296 | 2.7.1 | **Incident GIS Standard Documentation and Archiving Procedures** | 1d? | 2005-03-16 | 2005-03-16 | 317d |  |
| 297 |  | Identify hierarchy of archive needs (incident, land unit, agency, NARA) | 1d? | 2005-03-16 | 2005-03-16 | 317d |  |
| 298 |  | Compile procedures currently in use | 1d? | 2005-03-16 | 2005-03-16 | 317d |  |
| 299 |  | Identify if existing procedures in use "somewhere out there" may be acceptible (e.g. NARA) | 1d? | 2005-03-16 | 2005-03-16 | 317d |  |
| 300 |  | Collect Information | 1d? | 2005-03-16 | 2005-03-16 | 317d |  |
| 301 |  | Identify test procedures for documentation and archiving | 1d? | 2005-03-16 | 2005-03-16 | 317d |  |
| 302 |  | Conduct Analysis | 1d? | 2005-03-16 | 2005-03-16 | 317d |  |
| 303 |  | Test and identify strengths/weaknesses of existing procedures | 1d? | 2005-03-16 | 2005-03-16 | 317d |  |
| 304 |  | Develop Preliminary Requirements Specifications | 1d? | 2005-03-16 | 2005-03-16 | 317d |  |
| 305 |  | Prepare recommendations | 1d? | 2005-03-16 | 2005-03-16 | 317d |  |
| 306 |  | Review and Validate Requirements | 1d? | 2005-03-16 | 2005-03-16 | 317d |  |
| 308 | 2.8 | **Incident GIS Transition Procedures** | 1d? | 2005-03-16 | 2005-03-16 | 317d |  |
| 309 | 2.8.1 | **Define Information Needs (What do we need to gather?)** | 1d? | 2005-03-16 | 2005-03-16 | 317d |  |
| 310 |  | Determine "universe" of transitions: (team to team); (team to unit); (team to archive) | 1d? | 2005-03-16 | 2005-03-16 | 317d |  |
| 311 |  | Compile procedures currently in use | 1d? | 2005-03-16 | 2005-03-16 | 317d |  |
| 312 |  | Identify if existing procedures in use "somewhere out there" may be acceptible (e.g. NARA) | 1d? | 2005-03-16 | 2005-03-16 | 317d |  |
| 313 |  | Evaluate Procedures | 1d? | 2005-03-16 | 2005-03-16 | 317d |  |
| 314 |  | Identify test procedures for documentation and archiving | 1d? | 2005-03-16 | 2005-03-16 | 317d |  |
| 315 | 2.8.3 | **Conduct Analysis** | 1d? | 2005-03-16 | 2005-03-16 | 317d |  |
| 316 |  | Test and identify strengths/weaknesses of existing procedures | 1d? | 2005-03-16 | 2005-03-16 | 317d |  |
| 317 | 2.8.4 | **Develop Preliminary Requirements Specifications** | 1d? | 2005-03-16 | 2005-03-16 | 317d |  |
| 318 |  | Prepare recommendations | 1d? | 2005-03-16 | 2005-03-16 | 317d |  |
| 319 | 2.8.5 | **Review and Validate Requirements** | 1d? | 2005-03-16 | 2005-03-16 | 317d |  |
| 320 |  | Sub-Team Review of SOP | 1d? | 2005-03-16 | 2005-03-16 | 317d |  |
| 321 |  | Revise, Edit Proposed SOP | 1d? | 2005-03-16 | 2005-03-16 | 317d |  |
| 322 |  | Submit to Project Manager for Team Review | 1d? | 2005-03-16 | 2005-03-16 | 317d |  |
| 324 | 3 | **Draft Incident GIS SOPs** | 1d? | 2004-12-01 | 2004-12-01 | 392d |  |
| 325 |  | Develop template for GIS SOPs for all Subgroups | 1d? | 2004-12-01 | 2004-12-01 | 392d |  |
| 326 |  | Define Information Needs (What do we need to gather?) | 1d? | 2004-12-01 | 2004-12-01 | 392d |  |
| 327 |  | Collect Information | 1d? | 2004-12-01 | 2004-12-01 | 392d |  |
| 328 |  | Conduct Analysis | 1d? | 2004-12-01 | 2004-12-01 | 392d |  |
| 329 |  | Develop Preliminary SOP’s | 1d? | 2004-12-01 | 2004-12-01 | 392d |  |
| 330 |  | Review and Validate draft SOP’s | 1d? | 2004-12-01 | 2004-12-01 | 392d |  |
| 331 |  | Incorporate Feedback from reviewers | 1d? | 2004-12-01 | 2004-12-01 | 392d |  |
| 332 |  | Develop GSTOP Change Management Plan | 1d? | 2004-12-01 | 2004-12-01 | 392d |  |
| 333 |  | Review GSTOP Change Management Plan | 1d? | 2004-12-01 | 2004-12-01 | 392d |  |
| 334 |  | PRELIMINARY GIS SOP’s READY FOR FIELD TESTING | 1d? | 2004-12-01 | 2004-12-01 | 392d |  |
| 335 | 4 | **Incident GIS SOPs Field Test** | 1d? | 2004-12-01 | 2004-12-01 | 392d |  |
| 336 |  | Develop Quality Assurance and Field Test Plan | 1d? | 2004-12-01 | 2004-12-01 | 392d |  |
| 337 |  | develop questionnaire | 1d? | 2004-12-01 | 2004-12-01 | 392d |  |
| 338 |  | Execute Quality Assurance and Field Test Plan | 1d? | 2004-12-01 | 2004-12-01 | 392d |  |
| 339 |  | collect written/survey results from the field test | 1d? | 2004-12-01 | 2004-12-01 | 392d |  |
| 340 |  | conduct interviews with GISTs to measure success of Draft SOPs | 1d? | 2004-12-01 | 2004-12-01 | 392d |  |
| 341 |  | conduct interviews with SIT Unit Leaders to measure success of Draft SOPs | 1d? | 2004-12-01 | 2004-12-01 | 392d |  |
| 342 |  | Analyze Quality Assurance and Field Test Plan Results | 1d? | 2004-12-01 | 2004-12-01 | 392d |  |
| 343 |  | Ensure requirements are reviewed and tested by business community | 1d? | 2004-12-01 | 2004-12-01 | 392d |  |
| 344 | 5 | **Final Incident GIS SOPs** | 1d? | 2004-12-01 | 2004-12-01 | 392d |  |
| 345 |  | Analyze feedback on Incident GIS SOPs | 1d? | 2004-12-01 | 2004-12-01 | 392d |  |
| 346 |  | Update and finalize Incident GIS SOPs | 1d? | 2004-12-01 | 2004-12-01 | 392d |  |
| 347 |  | Deliver Final Incident GIS SOPs to Executive Committee | 1d? | 2004-12-01 | 2004-12-01 | 392d |  |
| 348 |  | Deliver Final Incident GIS SOPs to Incident Based Automation Project | 1d? | 2004-12-01 | 2004-12-01 | 392d |  |
| 349 | 6 | **GSTOP Project Closeout** | 393d? | 2004-12-01 | 2006-06-02 | 0d |  |
| 350 |  | Prepare GSTOP Team Recommendations | 1d? | 2004-12-01 | 2004-12-01 | 392d |  |
| 351 |  | Document Lessons Learned | 1d? | 2004-12-01 | 2004-12-01 | 392d |  |
| 352 |  | GSTOP PROJECT TEAM RELEASED | 1d? | 2006-06-02 | 2006-06-02 | 0d | finish no earlier than 2006-06-02 |

## Version 2 (saved 2005-03-11, file Copy of GSTOP Project Timel.mpp)

Last finish stays 2006-06-02.

Added:

| ID | Task | Duration | Start | Finish |
| --- | --- | --- | --- | --- |
| 347 | Communication Plan | 1d? | 2004-10-20 | 2004-10-20 |

Removed: 19 Research 4 websites and select option for public communications

Changed:

| ID | Task | Start | Finish | Duration | Total float | Other |
| --- | --- | --- | --- | --- | --- | --- |
| 1 | **GSTOP Project** |  |  |  |  | was named GSTOP Project Initiation |
| 2 | **Initiate the GSTOP Project** |  | 2005-03-04 → 2005-03-15 (+11d) | 98d → 105d? | 325d → 318d |  |
| 5 | GSTOP Project Charter Approved | 2004-12-01 → 2004-10-20 (-42d) |  | 1d → 31d |  | constraint none → start no earlier than 2004-10-20 |
| 7 | **GSTOP Project Team Identified** | 2004-12-01 → 2004-10-20 (-42d) |  | 75d? → 105d? |  |  |
| 8 | **Form the GSTOP Team** | 2004-12-01 → 2004-10-20 (-42d) |  | 75d? → 105d? |  |  |
| 12 | **Develop the GSTOP Project Management Plans** | 2004-12-01 → 2004-10-20 (-42d) |  | 75d? → 105d? |  | resources Smclellan → S.McLellan |
| 16 | Develop Intial Project Responsibility Matrix | 2004-12-01 → 2004-10-20 (-42d) | 2004-12-01 → 2004-10-20 (-42d) |  | 379d → 422d |  |
| 18 | **Develop the GSTOP Communication and Management Structures** | 2004-12-01 → 2004-10-20 (-42d) |  | 65d? → 95d? |  |  |
| 19 | Create GSTOP private team workspace | 2004-12-01 → 2004-10-20 (-42d) | 2004-12-01 → 2004-10-20 (-42d) |  | 379d → 422d |  |
| 22 | Executive Briefing |  |  | 1d? → 0d |  | was named Progress Report to Executive Committee |
| 23 | **GSTOP Requirements** |  | 2005-04-01 → 2005-03-31 (-1d) |  |  |  |
| 24 | **Incident GIS Standard Symbology Requirements** | 2005-03-16 → 2005-03-15 (-1d) | 2005-03-21 → 2005-03-18 (-3d) |  |  |  |
| 25 | **Establish Symbols Sub-Team business practices** | 2005-03-16 → 2005-03-15 (-1d) | 2005-03-16 → 2005-03-15 (-1d) |  |  |  |
| 26 | **Develop a Symbol Sub-team Communication Plan** | 2005-03-16 → 2005-03-15 (-1d) | 2005-03-16 → 2005-03-15 (-1d) |  |  |  |
| 27 | Define ground-rules for Sub-Team (internal) communication | 2005-03-16 → 2005-03-15 (-1d) | 2005-03-16 → 2005-03-15 (-1d) |  |  |  |
| 28 | Define ground-rules for communication between the Symbol Sub-Team and other GSTOP Sub-Teams | 2005-03-16 → 2005-03-15 (-1d) | 2005-03-16 → 2005-03-15 (-1d) |  |  |  |
| 29 | Define ground rules for communication between the Sub-Team and entities outside of the GSTOP Project | 2005-03-16 → 2005-03-15 (-1d) | 2005-03-16 → 2005-03-15 (-1d) |  |  |  |
| 30 | Establish a process and schedule for Sub-Team (internal) progress report updates | 2005-03-16 → 2005-03-15 (-1d) | 2005-03-16 → 2005-03-15 (-1d) |  |  |  |
| 31 | Establish a process and schedule for Sub-Team progress report updates to the GSTOP Team | 2005-03-16 → 2005-03-15 (-1d) | 2005-03-16 → 2005-03-15 (-1d) |  |  |  |
| 32 | **Establish Review Processes** | 2005-03-16 → 2005-03-15 (-1d) | 2005-03-16 → 2005-03-15 (-1d) |  |  |  |
| 33 | Establish a process for Sub-Team (internal) review of potential symbols | 2005-03-16 → 2005-03-15 (-1d) | 2005-03-16 → 2005-03-15 (-1d) |  |  |  |
| 34 | Establish a process for Sub-Team (internal) review of the draft standard symbols | 2005-03-16 → 2005-03-15 (-1d) | 2005-03-16 → 2005-03-15 (-1d) |  |  |  |
| 35 | Establish a process for peer reviews | 2005-03-16 → 2005-03-15 (-1d) | 2005-03-16 → 2005-03-15 (-1d) |  |  |  |
| 36 | Establish a process for periodic GSTOP Team reviews | 2005-03-16 → 2005-03-15 (-1d) | 2005-03-16 → 2005-03-15 (-1d) |  |  |  |
| 37 | Establish a process for reviewing the final report | 2005-03-16 → 2005-03-15 (-1d) | 2005-03-16 → 2005-03-15 (-1d) |  |  |  |
| 38 | **Establish Change processes** | 2005-03-16 → 2005-03-15 (-1d) | 2005-03-16 → 2005-03-15 (-1d) |  |  |  |
| 39 | Establish a process for additions/deletions of potential symbols mid-stream through the Project | 2005-03-16 → 2005-03-15 (-1d) | 2005-03-16 → 2005-03-15 (-1d) |  |  |  |
| 40 | Establish a change process for the additions/deletion of standard symbols after the final recommendation has been submitted and prior to completion of the GSTOP project | 2005-03-16 → 2005-03-15 (-1d) | 2005-03-16 → 2005-03-15 (-1d) |  |  |  |
| 41 | Establish a change process for the additions/deletion of standard symbols after the completion of the GSTOP project | 2005-03-16 → 2005-03-15 (-1d) | 2005-03-16 → 2005-03-15 (-1d) |  |  |  |
| 42 | **Establish symbol evaluation methods** | 2005-03-16 → 2005-03-15 (-1d) | 2005-03-16 → 2005-03-15 (-1d) |  |  |  |
| 43 | Define method for evaluating marker symbols | 2005-03-16 → 2005-03-15 (-1d) | 2005-03-16 → 2005-03-15 (-1d) |  |  |  |
| 44 | Define method for evaluating line symbols | 2005-03-16 → 2005-03-15 (-1d) | 2005-03-16 → 2005-03-15 (-1d) |  |  |  |
| 45 | Define method for evaluating fill symbols | 2005-03-16 → 2005-03-15 (-1d) | 2005-03-16 → 2005-03-15 (-1d) |  |  |  |
| 46 | Conduct a final review of evaluation methods | 2005-03-16 → 2005-03-15 (-1d) | 2005-03-16 → 2005-03-15 (-1d) |  |  |  |
| 47 | **Define criteria for the acceptance of symbols as standards** | 2005-03-16 → 2005-03-15 (-1d) | 2005-03-16 → 2005-03-15 (-1d) |  |  |  |
| 48 | Develop acceptance criteria for marker symbols | 2005-03-16 → 2005-03-15 (-1d) | 2005-03-16 → 2005-03-15 (-1d) |  |  |  |
| 49 | Develop acceptance criteria for line symbols | 2005-03-16 → 2005-03-15 (-1d) | 2005-03-16 → 2005-03-15 (-1d) |  |  |  |
| 50 | Develop acceptance criteria for fill symbols | 2005-03-16 → 2005-03-15 (-1d) | 2005-03-16 → 2005-03-15 (-1d) |  |  |  |
| 51 | Conduct a final review of selection criteria | 2005-03-16 → 2005-03-15 (-1d) | 2005-03-16 → 2005-03-15 (-1d) |  |  |  |
| 52 | **Establish file format for symbols** | 2005-03-16 → 2005-03-15 (-1d) | 2005-03-16 → 2005-03-15 (-1d) |  |  |  |
| 53 | Define acceptable formats of symbols for evaluation | 2005-03-16 → 2005-03-15 (-1d) | 2005-03-16 → 2005-03-15 (-1d) |  |  |  |
| 54 | Define format of recommended standard symbols | 2005-03-16 → 2005-03-15 (-1d) | 2005-03-16 → 2005-03-15 (-1d) |  |  |  |
| 55 | **Develop a list of symbols to be evaluated for acceptance as draft standards** | 2005-03-16 → 2005-03-15 (-1d) | 2005-03-16 → 2005-03-15 (-1d) |  |  |  |
| 56 | Collect Fire mapping symbols from the Fireline Handbook | 2005-03-16 → 2005-03-15 (-1d) | 2005-03-16 → 2005-03-15 (-1d) |  |  |  |
| 57 | Collect Fire mapping symbols suggestions from the 5 federal fire management agencies (FS, BLM, NPS, FWS, BIA) and state agencies via the NWCG Geospatial Task Group (GTG) | 2005-03-16 → 2005-03-15 (-1d) | 2005-03-16 → 2005-03-15 (-1d) |  |  |  |
| 58 | Collect Fire mapping symbols from HSA (FEMA), FAA, and DOD | 2005-03-16 → 2005-03-15 (-1d) | 2005-03-16 → 2005-03-15 (-1d) |  |  |  |
| 59 | Document potential sources for additional fire mapping symbols | 2005-03-16 → 2005-03-15 (-1d) | 2005-03-16 → 2005-03-15 (-1d) |  |  |  |
| 60 | Compile symbols into a single potential symbol set | 2005-03-16 → 2005-03-15 (-1d) | 2005-03-16 → 2005-03-15 (-1d) |  |  |  |
| 61 | **Determine the draft standard marker symbols** | 2005-03-16 → 2005-03-15 (-1d) | 2005-03-16 → 2005-03-15 (-1d) |  |  |  |
| 62 | Evaluate each potential marker symbol against the marker symbol selection criteria | 2005-03-16 → 2005-03-15 (-1d) | 2005-03-16 → 2005-03-15 (-1d) |  |  |  |
| 63 | Selection the draft standard marker symbols | 2005-03-16 → 2005-03-15 (-1d) | 2005-03-16 → 2005-03-15 (-1d) |  |  |  |
| 64 | Conduct a completeness review of the draft standard marker symbols | 2005-03-16 → 2005-03-15 (-1d) | 2005-03-16 → 2005-03-15 (-1d) |  |  |  |
| 65 | **Determine the draft standard line symbols** | 2005-03-16 → 2005-03-15 (-1d) | 2005-03-16 → 2005-03-15 (-1d) |  |  |  |
| 66 | Evaluate each potential line symbol against the line symbol selection criteria | 2005-03-16 → 2005-03-15 (-1d) | 2005-03-16 → 2005-03-15 (-1d) |  |  |  |
| 67 | Select the draft standard line symbols | 2005-03-16 → 2005-03-15 (-1d) | 2005-03-16 → 2005-03-15 (-1d) |  |  |  |
| 68 | Conduct a completeness review of the draft standard line symbols | 2005-03-16 → 2005-03-15 (-1d) | 2005-03-16 → 2005-03-15 (-1d) |  |  |  |
| 69 | **Determine the draft standard fill symbols** | 2005-03-16 → 2005-03-15 (-1d) | 2005-03-16 → 2005-03-15 (-1d) |  |  |  |
| 70 | Evaluate each potential fill symbol against the fill symbol selection criteria | 2005-03-16 → 2005-03-15 (-1d) | 2005-03-16 → 2005-03-15 (-1d) |  |  |  |
| 71 | Select the draft standard fill symbols | 2005-03-16 → 2005-03-15 (-1d) | 2005-03-16 → 2005-03-15 (-1d) |  |  |  |
| 72 | Conduct a completeness review of the draft standard fill symbols | 2005-03-16 → 2005-03-15 (-1d) | 2005-03-16 → 2005-03-15 (-1d) |  |  |  |
| 73 | **Conduct initial peer review of the draft standard marker, line, and fill symbols** | 2005-03-16 → 2005-03-15 (-1d) | 2005-03-21 → 2005-03-18 (-3d) |  |  |  |
| 74 | Prepare draft standard symbols for initial peer review | 2005-03-16 → 2005-03-15 (-1d) | 2005-03-16 → 2005-03-15 (-1d) |  |  |  |
| 75 | Submit the draft standard symbols to the 5 federal fire management agencies and State agencies via the NWCG Geospatial Task Group (GTG); and to the HSA (FEMA), FAA, DOD, and GSTOP Team for peer review | 2005-03-16 → 2005-03-15 (-1d) | 2005-03-16 → 2005-03-15 (-1d) |  |  |  |
| 76 | Review feedback of initial peer review | 2005-03-17 → 2005-03-16 (-1d) | 2005-03-17 → 2005-03-16 (-1d) |  |  |  |
| 77 | Identify required changes to draft standard symbols based on the initial peer review feedback | 2005-03-18 → 2005-03-17 (-1d) | 2005-03-18 → 2005-03-17 (-1d) |  |  |  |
| 78 | Make required changes, as identified, to draft standard symbols | 2005-03-21 → 2005-03-18 (-3d) | 2005-03-21 → 2005-03-18 (-3d) |  |  |  |
| 79 | **Conduct final peer review of the draft standard marker, line and fill symbols** | 2005-03-16 → 2005-03-15 (-1d) | 2005-03-16 → 2005-03-15 (-1d) |  |  |  |
| 80 | Prepare draft standard symbols for final peer review | 2005-03-16 → 2005-03-15 (-1d) | 2005-03-16 → 2005-03-15 (-1d) |  |  |  |
| 81 | Submit the draft standard symbols to the 5 federal fire management agencies and State agencies via the NWCG Geospatial Task Group (GTG); and to the HSA (FEMA), FAA, DOD, and GSTOP Team for peer review | 2005-03-16 → 2005-03-15 (-1d) | 2005-03-16 → 2005-03-15 (-1d) |  |  |  |
| 82 | Review feedback of the final peer review | 2005-03-16 → 2005-03-15 (-1d) | 2005-03-16 → 2005-03-15 (-1d) |  |  |  |

| ID | Task | Start | Finish |
| --- | --- | --- | --- |
| 83 | Identify required changes to draft standard symbols based on the final peer review feedback | 2005-03-16 → 2005-03-15 (-1d) | 2005-03-16 → 2005-03-15 (-1d) |
| 84 | Make required changes, as identified, to draft standard symbols | 2005-03-16 → 2005-03-15 (-1d) | 2005-03-16 → 2005-03-15 (-1d) |
| 85 | Ratify the final draft standard symbols | 2005-03-16 → 2005-03-15 (-1d) | 2005-03-16 → 2005-03-15 (-1d) |
| 86 | **Finalize recommendation of standard Fire Mapping symbols** | 2005-03-16 → 2005-03-15 (-1d) | 2005-03-16 → 2005-03-15 (-1d) |
| 87 | Create a report recommending the adoption of the draft standard symbols | 2005-03-16 → 2005-03-15 (-1d) | 2005-03-16 → 2005-03-15 (-1d) |
| 88 | Conduct a review of the report | 2005-03-16 → 2005-03-15 (-1d) | 2005-03-16 → 2005-03-15 (-1d) |
| 89 | Submit the report to GSTOP-PM | 2005-03-16 → 2005-03-15 (-1d) | 2005-03-16 → 2005-03-15 (-1d) |
| 90 | **Incident GIS Standard Naming Conventions Requirements** | 2005-03-16 → 2005-03-15 (-1d) | 2005-03-31 → 2005-03-30 (-1d) |
| 91 | **Define Information Needs (What do we need to gather?)** | 2005-03-16 → 2005-03-15 (-1d) | 2005-03-16 → 2005-03-15 (-1d) |
| 92 | Set objectives for work plan | 2005-03-16 → 2005-03-15 (-1d) | 2005-03-16 → 2005-03-15 (-1d) |
| 93 | Define ground rules for sub team | 2005-03-16 → 2005-03-15 (-1d) | 2005-03-16 → 2005-03-15 (-1d) |
| 94 | Define common ground with other sub teams | 2005-03-16 → 2005-03-15 (-1d) | 2005-03-16 → 2005-03-15 (-1d) |
| 95 | **Collect Information** | 2005-03-16 → 2005-03-15 (-1d) | 2005-03-16 → 2005-03-15 (-1d) |
| 96 | Collect existing naming and filing conventions from GIST's attached to IMT's | 2005-03-16 → 2005-03-15 (-1d) | 2005-03-16 → 2005-03-15 (-1d) |
| 97 | **Conduct Analysis** | 2005-03-17 → 2005-03-16 (-1d) | 2005-03-18 → 2005-03-17 (-1d) |
| 98 | Review strengths & weaknesses of existing methodologies | 2005-03-17 → 2005-03-16 (-1d) | 2005-03-17 → 2005-03-16 (-1d) |
| 99 | Resolve overlap and conflicts | 2005-03-18 → 2005-03-17 (-1d) | 2005-03-18 → 2005-03-17 (-1d) |
| 100 | **Develop Preliminary Requirements Specifications** | 2005-03-21 → 2005-03-18 (-3d) | 2005-03-22 → 2005-03-21 (-1d) |
| 101 | Draft naming convention guidelines | 2005-03-21 → 2005-03-18 (-3d) | 2005-03-21 → 2005-03-18 (-3d) |
| 102 | Draft directory structure guidelines | 2005-03-22 → 2005-03-21 (-1d) | 2005-03-22 → 2005-03-21 (-1d) |
| 103 | **Requirements Review and Validation** | 2005-03-23 → 2005-03-22 (-1d) | 2005-03-23 → 2005-03-22 (-1d) |
| 104 | Post draft guidelines for inter team review | 2005-03-23 → 2005-03-22 (-1d) | 2005-03-23 → 2005-03-22 (-1d) |
| 105 | Edit draft guidelines based on input | 2005-03-23 → 2005-03-22 (-1d) | 2005-03-23 → 2005-03-22 (-1d) |
| 106 | Post draft guidelines for external review | 2005-03-23 → 2005-03-22 (-1d) | 2005-03-23 → 2005-03-22 (-1d) |
| 107 | Edit draft guidelines based on input | 2005-03-23 → 2005-03-22 (-1d) | 2005-03-23 → 2005-03-22 (-1d) |
| 108 | **Prepare Sample Documents** | 2005-03-16 → 2005-03-15 (-1d) | 2005-03-16 → 2005-03-15 (-1d) |
| 109 | Prepare Naming conventions | 2005-03-16 → 2005-03-15 (-1d) | 2005-03-16 → 2005-03-15 (-1d) |
| 110 | Develop Directory structure | 2005-03-16 → 2005-03-15 (-1d) | 2005-03-16 → 2005-03-15 (-1d) |
| 111 | Prepare Methods of work | 2005-03-16 → 2005-03-15 (-1d) | 2005-03-16 → 2005-03-15 (-1d) |
| 112 | **Sample Documents Review and Validation** | 2005-03-16 → 2005-03-15 (-1d) | 2005-03-31 → 2005-03-30 (-1d) |
| 113 | Post sample documents for inter team review | 2005-03-16 → 2005-03-15 (-1d) | 2005-03-16 → 2005-03-15 (-1d) |
| 114 | Edit sample documents based on input | 2005-03-16 → 2005-03-15 (-1d) | 2005-03-16 → 2005-03-15 (-1d) |
| 115 | Post sample documents for external review | 2005-03-16 → 2005-03-15 (-1d) | 2005-03-22 → 2005-03-21 (-1d) |
| 116 | Edit sample documents based on input | 2005-03-16 → 2005-03-15 (-1d) | 2005-03-31 → 2005-03-30 (-1d) |
| 117 | **Incident GIS Standard Product Definitions Requirements** | 2005-03-16 → 2005-03-15 (-1d) | 2005-03-25 → 2005-03-24 (-1d) |
| 118 | **Define Information Needs (What do we need to gather?)** | 2005-03-16 → 2005-03-15 (-1d) | 2005-03-21 → 2005-03-18 (-3d) |
| 119 | Develop Standard Products Matrix to compare many versions of standard products. (GIST Draft Taskbook/GIST Course Workbook/PNWCG Product Objectives) | 2005-03-16 → 2005-03-15 (-1d) | 2005-03-16 → 2005-03-15 (-1d) |
| 120 | Acquire DPRO Standards and incorporate into above matrix. | 2005-03-17 → 2005-03-16 (-1d) | 2005-03-17 → 2005-03-16 (-1d) |
| 121 | Need group assistance – there are no members who volunteered for this subgroup. It will need the participation of everyone to work. | 2005-03-18 → 2005-03-17 (-1d) | 2005-03-18 → 2005-03-17 (-1d) |
| 122 | Provide a final package of Standard Products including definitions and examples. | 2005-03-21 → 2005-03-18 (-3d) | 2005-03-21 → 2005-03-18 (-3d) |
| 123 | **Collect Information** | 2005-03-16 → 2005-03-15 (-1d) | 2005-03-18 → 2005-03-17 (-1d) |
| 124 | Definitions exist in the National Training course workbook for GIST. PNWCG has also created some standard definitions. Compile these into a list for group to review. Cite source. | 2005-03-16 → 2005-03-15 (-1d) | 2005-03-16 → 2005-03-15 (-1d) |
| 125 | Review DPRO product definitions and compare to existing definitions for GIST. | 2005-03-17 → 2005-03-16 (-1d) | 2005-03-17 → 2005-03-16 (-1d) |
| 126 | Collect examples of standard products. | 2005-03-18 → 2005-03-17 (-1d) | 2005-03-18 → 2005-03-17 (-1d) |
| 127 | **Conduct Analysis** | 2005-03-21 → 2005-03-18 (-3d) | 2005-03-22 → 2005-03-21 (-1d) |
| 128 | Review existing standards definitions (GIST course/PNWCG/DPRO) | 2005-03-21 → 2005-03-18 (-3d) | 2005-03-21 → 2005-03-18 (-3d) |
| 129 | Identify discrepancies between groups defining standard and bring these to the larger group for discussion and resolution. There may be specific reasons for discrepancies (Fire Use vs. Type 1) so these should be highlighted for the preliminary package. | 2005-03-22 → 2005-03-21 (-1d) | 2005-03-22 → 2005-03-21 (-1d) |
| 130 | **Develop Preliminary Requirements Specifications** | 2005-03-23 → 2005-03-22 (-1d) | 2005-03-24 → 2005-03-23 (-1d) |
| 131 | Provide a package of products definitions and samples for group review (GIST/SITL review?) | 2005-03-23 → 2005-03-22 (-1d) | 2005-03-23 → 2005-03-22 (-1d) |
| 132 | Find a storage location for GSTOP group review (NIFC site?) | 2005-03-24 → 2005-03-23 (-1d) | 2005-03-24 → 2005-03-23 (-1d) |
| 133 | **Review and Validate Requirements** | 2005-03-25 → 2005-03-24 (-1d) | 2005-03-25 → 2005-03-24 (-1d) |
| 134 | Decide upon method of acceptance/rejection/modification | 2005-03-25 → 2005-03-24 (-1d) | 2005-03-25 → 2005-03-24 (-1d) |
| 135 | Decide who to get feedback from (GIST 1st, then SITL/PLSC/others?) | 2005-03-25 → 2005-03-24 (-1d) | 2005-03-25 → 2005-03-24 (-1d) |
| 136 | Incorporate feedback into final package of definitions & samples | 2005-03-25 → 2005-03-24 (-1d) | 2005-03-25 → 2005-03-24 (-1d) |
| 137 | Find a permanent storage location for this package? National clearinghouse? | 2005-03-25 → 2005-03-24 (-1d) | 2005-03-25 → 2005-03-24 (-1d) |
| 138 | **Incident GIST Minimum Qualifications Requirements** | 2005-03-16 → 2005-03-15 (-1d) | 2005-03-16 → 2005-03-15 (-1d) |
| 139 | **Establish Min GIST qualifications/GIS expectations Sub-Team business practices** | 2005-03-16 → 2005-03-15 (-1d) | 2005-03-16 → 2005-03-15 (-1d) |
| 140 | **Develop a Symbol Sub-team Communication Plan** | 2005-03-16 → 2005-03-15 (-1d) | 2005-03-16 → 2005-03-15 (-1d) |
| 141 | Define ground-rules for Sub-Team (internal) communication | 2005-03-16 → 2005-03-15 (-1d) | 2005-03-16 → 2005-03-15 (-1d) |
| 142 | Define ground-rules for communication between the Min GIST qualifications/GIS expectations Sub-Team and other GSTOP Sub-Teams | 2005-03-16 → 2005-03-15 (-1d) | 2005-03-16 → 2005-03-15 (-1d) |
| 143 | Define ground rules for communication between the Sub-Team and entities outside of the GSTOP Project | 2005-03-16 → 2005-03-15 (-1d) | 2005-03-16 → 2005-03-15 (-1d) |
| 144 | Establish a process and schedule for Sub-Team (internal) progress report updates | 2005-03-16 → 2005-03-15 (-1d) | 2005-03-16 → 2005-03-15 (-1d) |
| 145 | Establish a process and schedule for Sub-Team progress report updates to the GSTOP Team | 2005-03-16 → 2005-03-15 (-1d) | 2005-03-16 → 2005-03-15 (-1d) |
| 146 | **Establish Review Processes** | 2005-03-16 → 2005-03-15 (-1d) | 2005-03-16 → 2005-03-15 (-1d) |
| 147 | Establish a process for Sub-Team (internal) review of potential minimum GIST qualifications/GIS expectations | 2005-03-16 → 2005-03-15 (-1d) | 2005-03-16 → 2005-03-15 (-1d) |
| 148 | Establish a process for Sub-Team (internal) review of the draft minimum GIST qualifications/GIS expectations | 2005-03-16 → 2005-03-15 (-1d) | 2005-03-16 → 2005-03-15 (-1d) |
| 149 | Establish a process for peer reviews | 2005-03-16 → 2005-03-15 (-1d) | 2005-03-16 → 2005-03-15 (-1d) |
| 150 | Establish a process for periodic GSTOP Team reviews | 2005-03-16 → 2005-03-15 (-1d) | 2005-03-16 → 2005-03-15 (-1d) |
| 151 | Establish a process for reviewing the final report | 2005-03-16 → 2005-03-15 (-1d) | 2005-03-16 → 2005-03-15 (-1d) |
| 152 | **Establish Change processes** | 2005-03-16 → 2005-03-15 (-1d) | 2005-03-16 → 2005-03-15 (-1d) |

| ID | Task | Start | Finish | Other |
| --- | --- | --- | --- | --- |
| 153 | Establish a process for additions/deletions of potential minimum GIST qualifications/GIS expectations mid-stream through the project | 2005-03-16 → 2005-03-15 (-1d) | 2005-03-16 → 2005-03-15 (-1d) |  |
| 154 | Establish a change process for the additions/deletion of minimum GIST qualifications/GIS expectations after the final recommendation has been submitted and prior to completion of the GSTOP project | 2005-03-16 → 2005-03-15 (-1d) | 2005-03-16 → 2005-03-15 (-1d) |  |
| 155 | Establish a change process for the additions/deletion of minimum GIST qualifications/GIS expectations after the completion of the GSTOP project | 2005-03-16 → 2005-03-15 (-1d) | 2005-03-16 → 2005-03-15 (-1d) |  |
| 156 | **Establish evaluation methods for minimum GIST qualifications/GIS expectations** | 2005-03-16 → 2005-03-15 (-1d) | 2005-03-16 → 2005-03-15 (-1d) |  |
| 157 | Define method for evaluating minimum GIST qualifications/GIS expectations | 2005-03-16 → 2005-03-15 (-1d) | 2005-03-16 → 2005-03-15 (-1d) |  |
| 158 | Conduct a final review of evaluation methods | 2005-03-16 → 2005-03-15 (-1d) | 2005-03-16 → 2005-03-15 (-1d) |  |
| 159 | **Define criteria for the acceptance of minimum GIST qualifications/GIS expectations** | 2005-03-16 → 2005-03-15 (-1d) | 2005-03-16 → 2005-03-15 (-1d) |  |
| 160 | Develop acceptance criteria for minimum GIST qualifications/GIS expectations | 2005-03-16 → 2005-03-15 (-1d) | 2005-03-16 → 2005-03-15 (-1d) |  |
| 161 | Conduct a final review of selection criteria | 2005-03-16 → 2005-03-15 (-1d) | 2005-03-16 → 2005-03-15 (-1d) |  |
| 162 | **Collect Information on minimum GIST qualifications and minimum GIS expectations on an incident** | 2005-03-16 → 2005-03-15 (-1d) | 2005-03-16 → 2005-03-15 (-1d) |  |
| 163 | Gather documents and references (including white papers, memos, After Action Reviews) | 2005-03-16 → 2005-03-15 (-1d) | 2005-03-16 → 2005-03-15 (-1d) |  |
| 164 | Scan or translate paper documents to electronic format | 2005-03-16 → 2005-03-15 (-1d) | 2005-03-16 → 2005-03-15 (-1d) |  |
| 165 | Research current GIST/GIS standards | 2005-03-16 → 2005-03-15 (-1d) | 2005-03-16 → 2005-03-15 (-1d) |  |
| 166 | **Develop a list of GIST qualifications to be evaluated for acceptance as draft minimum standards** | 2005-03-16 → 2005-03-15 (-1d) | 2005-03-16 → 2005-03-15 (-1d) |  |
| 167 | Compare the current GIST standards | 2005-03-16 → 2005-03-15 (-1d) | 2005-03-16 → 2005-03-15 (-1d) |  |
| 168 | Compile the GIST qualifications into a single list of potential minimum GIST qualifications | 2005-03-16 → 2005-03-15 (-1d) | 2005-03-16 → 2005-03-15 (-1d) |  |
| 169 | Compile a list of GIST qualifications which are deemed to be beyond the minimum for future reference | 2005-03-16 → 2005-03-15 (-1d) | 2005-03-16 → 2005-03-15 (-1d) |  |
| 170 | **Develop a list of GIS expectations to be evaluated for acceptance as draft minimum standards** | 2005-03-16 → 2005-03-15 (-1d) | 2005-03-16 → 2005-03-15 (-1d) |  |
| 171 | Compare any current GIS expectation standards | 2005-03-16 → 2005-03-15 (-1d) | 2005-03-16 → 2005-03-15 (-1d) |  |
| 172 | Compile the GIS expectations into a list of potential minimum GIS expectations on an incident | 2005-03-16 → 2005-03-15 (-1d) | 2005-03-16 → 2005-03-15 (-1d) |  |
| 173 | Compile a list of GIST qualifications which are deemed to be beyond the minimum for future reference | 2005-03-16 → 2005-03-15 (-1d) | 2005-03-16 → 2005-03-15 (-1d) |  |
| 174 | **Determine the draft standard minimum GIST qualifications** | 2005-03-16 → 2005-03-15 (-1d) | 2005-03-16 → 2005-03-15 (-1d) |  |
| 175 | Evaluate each potential minimum GIST qualification using the evaluation methods in 2.4.2 | 2005-03-16 → 2005-03-15 (-1d) | 2005-03-16 → 2005-03-15 (-1d) |  |
| 176 | Select the minimum GIST qualifications | 2005-03-16 → 2005-03-15 (-1d) | 2005-03-16 → 2005-03-15 (-1d) |  |
| 177 | Conduct a completeness review of the draft minimum GIST qualifications | 2005-03-16 → 2005-03-15 (-1d) | 2005-03-16 → 2005-03-15 (-1d) |  |
| 178 | **Determine the draft standard minimum GIS expectations** | 2005-03-16 → 2005-03-15 (-1d) | 2005-03-16 → 2005-03-15 (-1d) |  |
| 179 | Evaluate each potential minimum GIS expectation using the evaluation methods in 2.4.2 | 2005-03-16 → 2005-03-15 (-1d) | 2005-03-16 → 2005-03-15 (-1d) |  |
| 180 | Select the minimum GIS expectations | 2005-03-16 → 2005-03-15 (-1d) | 2005-03-16 → 2005-03-15 (-1d) |  |
| 181 | Conduct a completeness review of the draft minimum GIS expectations | 2005-03-16 → 2005-03-15 (-1d) | 2005-03-16 → 2005-03-15 (-1d) |  |
| 182 | **Conduct internal review of draft standard minimum GIST qualifications and GIS expectations** | 2005-03-16 → 2005-03-15 (-1d) | 2005-03-16 → 2005-03-15 (-1d) |  |
| 183 | Prepare draft standard minimum GIST qualifications and GIS expectations, including acceptance criteria | 2005-03-16 → 2005-03-15 (-1d) | 2005-03-16 → 2005-03-15 (-1d) |  |
| 184 | Post draft standard to DisasterHelp website and notify GSTOP team for group review | 2005-03-16 → 2005-03-15 (-1d) | 2005-03-16 → 2005-03-15 (-1d) |  |
| 185 | Provide data location and review process to internal group | 2005-03-16 → 2005-03-15 (-1d) | 2005-03-16 → 2005-03-15 (-1d) |  |
| 186 | Review feedback of initial peer review | 2005-03-16 → 2005-03-15 (-1d) | 2005-03-16 → 2005-03-15 (-1d) |  |
| 187 | Identify required changes to draft standard based on the initial peer review feedback | 2005-03-16 → 2005-03-15 (-1d) | 2005-03-16 → 2005-03-15 (-1d) |  |
| 188 | Make required changes, as identified, to draft standard | 2005-03-16 → 2005-03-15 (-1d) | 2005-03-16 → 2005-03-15 (-1d) |  |
| 189 | **Conduct final peer review of the draft standard minimum GIST qualifications and GIS expectations** | 2005-03-16 → 2005-03-15 (-1d) | 2005-03-16 → 2005-03-15 (-1d) | resources none → Victoria Smith |
| 190 | Prepare survey or questionnaire to accompany draft standards for final peer review. | 2005-03-16 → 2005-03-15 (-1d) | 2005-03-16 → 2005-03-15 (-1d) |  |
| 191 | Prepare draft standard minimum GIST Qualification/GIST expectations for final peer review, including the survey or questionnaire | 2005-03-16 → 2005-03-15 (-1d) | 2005-03-16 → 2005-03-15 (-1d) |  |
| 192 | Submit the draft expectations to the 5 federal fire management agencies and State agencies via the NWCG Geospatial Task Group (GTG); and to the HSA (FEMA), FAA, DOD, and GSTOP Team for peer review. | 2005-03-16 → 2005-03-15 (-1d) | 2005-03-16 → 2005-03-15 (-1d) |  |
| 193 | Review feedback of the final peer review, including questionnaire or survey | 2005-03-16 → 2005-03-15 (-1d) | 2005-03-16 → 2005-03-15 (-1d) |  |
| 194 | Identify required changes to draft standard minimum GIST qualifications/GIS expectations based on the final peer review feedback | 2005-03-16 → 2005-03-15 (-1d) | 2005-03-16 → 2005-03-15 (-1d) |  |
| 195 | Make required changes, as identified, to draft minimum GIST qualifications/GIS expectations symbols | 2005-03-16 → 2005-03-15 (-1d) | 2005-03-16 → 2005-03-15 (-1d) |  |
| 196 | Ratify the final draft standard minimum GIST qualifications/GIS expectations | 2005-03-16 → 2005-03-15 (-1d) | 2005-03-16 → 2005-03-15 (-1d) |  |
| 197 | **Finalize recommendation of standard Minimum GIST Qualifications and Minimum GIS Expectations on an Incident** | 2005-03-16 → 2005-03-15 (-1d) | 2005-03-16 → 2005-03-15 (-1d) |  |
| 198 | Create a report recommending the adoption of the draft minimum GIST Qualifications/GIS Expectations | 2005-03-16 → 2005-03-15 (-1d) | 2005-03-16 → 2005-03-15 (-1d) |  |
| 199 | Conduct a review of the report for completeness, accuracy, language, and grammar | 2005-03-16 → 2005-03-15 (-1d) | 2005-03-16 → 2005-03-15 (-1d) |  |
| 200 | Submit the report to GSTOP-PM | 2005-03-16 → 2005-03-15 (-1d) | 2005-03-16 → 2005-03-15 (-1d) |  |
| 201 | **Incident GIS Minimum Essential Datasets Requirements** |  | 2005-04-01 → 2005-03-31 (-1d) |  |
| 202 | Establish MED Sub-Team business practices | 2005-03-16 → 2005-03-15 (-1d) | 2005-03-16 → 2005-03-15 (-1d) |  |
| 203 | **Develop a MED Sub-team Communication Plan** | 2005-03-16 → 2005-03-15 (-1d) | 2005-04-01 → 2005-03-31 (-1d) |  |
| 204 | **Define ground-rules for Sub-Team (internal) communication** | 2005-03-16 → 2005-03-15 (-1d) | 2005-03-24 → 2005-03-23 (-1d) |  |
| 205 | Define ground-rules for communication between the MED Sub-Team and other GSTOP Sub-Teams | 2005-03-16 → 2005-03-15 (-1d) | 2005-03-16 → 2005-03-15 (-1d) |  |
| 206 | Define ground rules for communication between the Sub-Team and entities outside of the GSTOP Project | 2005-03-17 → 2005-03-16 (-1d) | 2005-03-17 → 2005-03-16 (-1d) |  |
| 207 | Establish a process and schedule for Sub-Team (internal) progress report updates | 2005-03-18 → 2005-03-17 (-1d) | 2005-03-18 → 2005-03-17 (-1d) |  |
| 208 | Establish a process and schedule for Sub-Team progress report updates to the GSTOP Team | 2005-03-21 → 2005-03-18 (-3d) | 2005-03-21 → 2005-03-18 (-3d) |  |
| 209 | Establish Review Processes | 2005-03-22 → 2005-03-21 (-1d) | 2005-03-22 → 2005-03-21 (-1d) |  |
| 210 | Establish a process for Sub-Team (internal) review of potential MEDs | 2005-03-23 → 2005-03-22 (-1d) | 2005-03-23 → 2005-03-22 (-1d) |  |
| 211 | Establish a process for Sub-Team (internal) review of the draft standard MEDs | 2005-03-24 → 2005-03-23 (-1d) | 2005-03-24 → 2005-03-23 (-1d) |  |
| 212 | **Establish a process for peer reviews** | 2005-03-25 → 2005-03-24 (-1d) | 2005-03-28 → 2005-03-25 (-3d) |  |
| 213 | Establish a process for periodic GSTOP Team reviews | 2005-03-25 → 2005-03-24 (-1d) | 2005-03-25 → 2005-03-24 (-1d) |  |
| 214 | Establish a process for reviewing the final report | 2005-03-28 → 2005-03-25 (-3d) | 2005-03-28 → 2005-03-25 (-3d) |  |
| 215 | **Establish Change processes** | 2005-03-29 → 2005-03-28 (-1d) | 2005-03-30 → 2005-03-29 (-1d) |  |
| 216 | Establish a process for additions/deletions of potential MEDs mid-stream through the Project | 2005-03-29 → 2005-03-28 (-1d) | 2005-03-29 → 2005-03-28 (-1d) |  |
| 217 | Establish a change process for the additions/deletion of standard MEDs after the final recommendation has been submitted | 2005-03-30 → 2005-03-29 (-1d) | 2005-03-30 → 2005-03-29 (-1d) |  |
| 218 | **Establish a change process for the additions/deletion of standard MEDs after the final recommendation has been approved through the GSTOP Project** | 2005-03-31 → 2005-03-30 (-1d) | 2005-03-31 → 2005-03-30 (-1d) |  |
| 219 | Establish MED evaluation methods | 2005-03-31 → 2005-03-30 (-1d) | 2005-03-31 → 2005-03-30 (-1d) |  |
| 220 | Define method for evaluating marker MEDs | 2005-04-01 → 2005-03-31 (-1d) | 2005-04-01 → 2005-03-31 (-1d) |  |
| 221 | Define method for evaluating line MEDs | 2005-03-16 → 2005-03-15 (-1d) | 2005-03-16 → 2005-03-15 (-1d) |  |
| 222 | **Define method for evaluating fill MEDs** | 2005-03-16 → 2005-03-15 (-1d) | 2005-03-17 → 2005-03-16 (-1d) |  |

| ID | Task | Start | Finish |
| --- | --- | --- | --- |
| 223 | **Conduct a final review of evaluation methods** | 2005-03-16 → 2005-03-15 (-1d) | 2005-03-16 → 2005-03-15 (-1d) |
| 224 | Define criteria for the acceptance of MEDs as standards | 2005-03-16 → 2005-03-15 (-1d) | 2005-03-16 → 2005-03-15 (-1d) |
| 225 | Develop acceptance criteria for marker MEDs | 2005-03-16 → 2005-03-15 (-1d) | 2005-03-16 → 2005-03-15 (-1d) |
| 226 | Develop acceptance criteria for line MEDs | 2005-03-16 → 2005-03-15 (-1d) | 2005-03-16 → 2005-03-15 (-1d) |
| 227 | **Develop acceptance criteria for fill MEDs** | 2005-03-16 → 2005-03-15 (-1d) | 2005-03-16 → 2005-03-15 (-1d) |
| 228 | Conduct a final review of selection criteria | 2005-03-16 → 2005-03-15 (-1d) | 2005-03-16 → 2005-03-15 (-1d) |
| 229 | **Develop a list of MEDs to be evaluated for acceptance as draft standards** | 2005-03-16 → 2005-03-15 (-1d) | 2005-03-16 → 2005-03-15 (-1d) |
| 230 | Collect Fire mapping MEDs from the 5 federal fire management agencies (FS, BLM, NPS, FWS, BIA), state agencies, and USGS via the NWCG Geospatial Task Group (GTG) | 2005-03-16 → 2005-03-15 (-1d) | 2005-03-16 → 2005-03-15 (-1d) |
| 231 | **Collect Fire mapping MEDs from DHS (FEMA), FAA, and DOD** | 2005-03-16 → 2005-03-15 (-1d) | 2005-03-16 → 2005-03-15 (-1d) |
| 232 | Document potential sources for additional fire mapping MEDs | 2005-03-16 → 2005-03-15 (-1d) | 2005-03-16 → 2005-03-15 (-1d) |
| 233 | Compile MEDs into a single potential MED set | 2005-03-17 → 2005-03-16 (-1d) | 2005-03-17 → 2005-03-16 (-1d) |
| 234 | **Determine the draft standard Raster MEDs** | 2005-03-16 → 2005-03-15 (-1d) | 2005-03-16 → 2005-03-15 (-1d) |
| 235 | **Evaluate each potential marker MED against the marker MED selection criteria** | 2005-03-16 → 2005-03-15 (-1d) | 2005-03-16 → 2005-03-15 (-1d) |
| 236 | Sub-Team selection of the draft standard marker MEDs | 2005-03-16 → 2005-03-15 (-1d) | 2005-03-16 → 2005-03-15 (-1d) |
| 237 | Conduct a Sub-team completeness review of the draft standard marker MEDs | 2005-03-16 → 2005-03-15 (-1d) | 2005-03-16 → 2005-03-15 (-1d) |
| 238 | Determine the draft standard Vector MEDs | 2005-03-16 → 2005-03-15 (-1d) | 2005-03-16 → 2005-03-15 (-1d) |
| 239 | Evaluate each potential line MED against the line MED selection criteria | 2005-03-16 → 2005-03-15 (-1d) | 2005-03-16 → 2005-03-15 (-1d) |
| 240 | **Sub-Team selection of the draft standard line MEDs** | 2005-03-16 → 2005-03-15 (-1d) | 2005-03-16 → 2005-03-15 (-1d) |
| 241 | Conduct a Sub-team completeness review of the draft standard line MEDs | 2005-03-16 → 2005-03-15 (-1d) | 2005-03-16 → 2005-03-15 (-1d) |
| 242 | Determine the draft standard Point MEDs | 2005-03-16 → 2005-03-15 (-1d) | 2005-03-16 → 2005-03-15 (-1d) |
| 243 | Evaluate each potential fill MED against the fill MED selection criteria | 2005-03-16 → 2005-03-15 (-1d) | 2005-03-16 → 2005-03-15 (-1d) |
| 244 | Sub-Team selection of the draft standard fill MEDs | 2005-03-16 → 2005-03-15 (-1d) | 2005-03-16 → 2005-03-15 (-1d) |
| 245 | Conduct a Sub-team completeness review of the draft standard fill MEDs | 2005-03-16 → 2005-03-15 (-1d) | 2005-03-16 → 2005-03-15 (-1d) |
| 246 | Conduct initial peer review of the draft standard marker, line, and fill MEDs | 2005-03-16 → 2005-03-15 (-1d) | 2005-03-16 → 2005-03-15 (-1d) |
| 247 | Prepare draft standard MEDs for initial peer review | 2005-03-16 → 2005-03-15 (-1d) | 2005-03-16 → 2005-03-15 (-1d) |
| 249 | Review feedback of initial peer review | 2005-03-16 → 2005-03-15 (-1d) | 2005-03-16 → 2005-03-15 (-1d) |
| 250 | **Identify required changes to draft standard MEDs based on the initial peer review feedback** |  | 2005-03-16 → 2005-03-15 (-1d) |
| 251 | **Make required changes, as identified, to draft standard MEDs** | 2005-03-16 → 2005-03-15 (-1d) | 2005-03-16 → 2005-03-15 (-1d) |
| 252 | Conduct final peer review of the draft standard marker, line, and fill MEDs | 2005-03-16 → 2005-03-15 (-1d) | 2005-03-16 → 2005-03-15 (-1d) |
| 253 | Prepare draft standard MEDs for final peer review | 2005-03-16 → 2005-03-15 (-1d) | 2005-03-16 → 2005-03-15 (-1d) |
| 254 | **Submit the draft standard MEDs to the 5 federal fire management agencies and State agencies via the NWCG Geospatial Task Group (GTG); and to the HSA (FEMA), FAA, DOD, and GSTOP Team for peer review** | 2005-03-16 → 2005-03-15 (-1d) | 2005-03-16 → 2005-03-15 (-1d) |
| 255 | Review feedback of the final peer review | 2005-03-16 → 2005-03-15 (-1d) | 2005-03-16 → 2005-03-15 (-1d) |
| 256 | Identify required changes to draft standard MEDs based on the final peer review feedback | 2005-03-16 → 2005-03-15 (-1d) | 2005-03-16 → 2005-03-15 (-1d) |
| 257 | Make required changes, as identified, to draft standard MEDs | 2005-03-16 → 2005-03-15 (-1d) | 2005-03-16 → 2005-03-15 (-1d) |
| 258 | Ratification of the final draft standard MEDs by the Sub-Team | 2005-03-16 → 2005-03-15 (-1d) | 2005-03-16 → 2005-03-15 (-1d) |
| 259 | **Finalize recommendation of standard Fire Mapping MEDs** | 2005-03-16 → 2005-03-15 (-1d) | 2005-03-16 → 2005-03-15 (-1d) |
| 260 | Create a report recommending the adoption of the draft standard MEDs | 2005-03-16 → 2005-03-15 (-1d) | 2005-03-16 → 2005-03-15 (-1d) |
| 261 | Conduct a Sub-Team review of the report | 2005-03-16 → 2005-03-15 (-1d) | 2005-03-16 → 2005-03-15 (-1d) |
| 262 | Submit the report to GSTOP-PM | 2005-03-16 → 2005-03-15 (-1d) | 2005-03-16 → 2005-03-15 (-1d) |
| 263 | Review and Validate draft SOP’s for completeness | 2005-03-16 → 2005-03-15 (-1d) | 2005-03-16 → 2005-03-15 (-1d) |
| 264 | Review and Validate draft SOP’s for GIS content | 2005-03-16 → 2005-03-15 (-1d) | 2005-03-16 → 2005-03-15 (-1d) |
| 265 | consolidate reviewers inputs | 2005-03-16 → 2005-03-15 (-1d) | 2005-03-16 → 2005-03-15 (-1d) |
| 266 | Evaluate Feedback for inclusion in SOP revision | 2005-03-16 → 2005-03-15 (-1d) | 2005-03-16 → 2005-03-15 (-1d) |
| 267 | Incorporate accepted feedback from reviewers | 2005-03-16 → 2005-03-15 (-1d) | 2005-03-16 → 2005-03-15 (-1d) |
| 268 | **Agencies' review of Draft SOPs** | 2005-03-16 → 2005-03-15 (-1d) | 2005-03-16 → 2005-03-15 (-1d) |
| 269 | Create a cover letter, and response process | 2005-03-16 → 2005-03-15 (-1d) | 2005-03-16 → 2005-03-15 (-1d) |
| 270 | Review and Validate draft SOP’s | 2005-03-16 → 2005-03-15 (-1d) | 2005-03-16 → 2005-03-15 (-1d) |
| 271 | Evaluate Feedback for inclusion in SOP revision | 2005-03-16 → 2005-03-15 (-1d) | 2005-03-16 → 2005-03-15 (-1d) |
| 272 | Incorporate Feedback from reviewers | 2005-03-16 → 2005-03-15 (-1d) | 2005-03-16 → 2005-03-15 (-1d) |
| 273 | Develop GSTOP Change Management Plan | 2005-03-16 → 2005-03-15 (-1d) | 2005-03-16 → 2005-03-15 (-1d) |
| 274 | Review GSTOP Change Management Plan | 2005-03-16 → 2005-03-15 (-1d) | 2005-03-16 → 2005-03-15 (-1d) |
| 276 | **Incident GIS Standard Data Sharing and Archiving Standards (02-08-2005)** | 2005-03-16 → 2005-03-15 (-1d) | 2005-03-16 → 2005-03-15 (-1d) |
| 277 | Define Information Needs (What do we need to gather?) | 2005-03-16 → 2005-03-15 (-1d) | 2005-03-16 → 2005-03-15 (-1d) |
| 278 | Compile existing archiving standards in use (e.g. data format, transfer mode) | 2005-03-16 → 2005-03-15 (-1d) | 2005-03-16 → 2005-03-15 (-1d) |
| 279 | Identify how archiving is done at present time by ICS, military, other incident responders, project-management | 2005-03-16 → 2005-03-15 (-1d) | 2005-03-16 → 2005-03-15 (-1d) |
| 280 | Gather NARA, Records Management requirements (review policies, lawsuits) e.g. physical location, acceptable media, supporting documentation | 2005-03-16 → 2005-03-15 (-1d) | 2005-03-16 → 2005-03-15 (-1d) |
| 281 | Determine the least common denominator (shapefile) or possibility of multiple formats | 2005-03-16 → 2005-03-15 (-1d) | 2005-03-16 → 2005-03-15 (-1d) |
| 282 | **Collect Information** | 2005-03-16 → 2005-03-15 (-1d) | 2005-03-16 → 2005-03-15 (-1d) |
| 283 | Conduct literature review | 2005-03-16 → 2005-03-15 (-1d) | 2005-03-16 → 2005-03-15 (-1d) |
| 284 | **Conduct Analysis** | 2005-03-16 → 2005-03-15 (-1d) | 2005-03-16 → 2005-03-15 (-1d) |
| 285 | Compile, Synthesize requirements | 2005-03-16 → 2005-03-15 (-1d) | 2005-03-16 → 2005-03-15 (-1d) |
| 286 | **Develop Preliminary Requirements Specifications** | 2005-03-16 → 2005-03-15 (-1d) | 2005-03-16 → 2005-03-15 (-1d) |
| 287 | Proposal of SOP | 2005-03-16 → 2005-03-15 (-1d) | 2005-03-16 → 2005-03-15 (-1d) |
| 288 | **Review and Validate Requirements** | 2005-03-16 → 2005-03-15 (-1d) | 2005-03-16 → 2005-03-15 (-1d) |
| 289 | Sub-Team Review of SOP | 2005-03-16 → 2005-03-15 (-1d) | 2005-03-16 → 2005-03-15 (-1d) |
| 290 | Revise, Edit Proposed SOP | 2005-03-16 → 2005-03-15 (-1d) | 2005-03-16 → 2005-03-15 (-1d) |
| 291 | Submit to Project Manager for Team Review | 2005-03-16 → 2005-03-15 (-1d) | 2005-03-16 → 2005-03-15 (-1d) |
| 293 | **Incident GIS Standard Documentation and Archiving** | 2005-03-16 → 2005-03-15 (-1d) | 2005-03-16 → 2005-03-15 (-1d) |
| 294 | **Incident GIS Standard Documentation and Archiving Procedures** | 2005-03-16 → 2005-03-15 (-1d) | 2005-03-16 → 2005-03-15 (-1d) |
| 295 | Identify hierarchy of archive needs (incident, land unit, agency, NARA) | 2005-03-16 → 2005-03-15 (-1d) | 2005-03-16 → 2005-03-15 (-1d) |

| ID | Task | Start | Finish | Duration | Total float | Predecessors | Other |
| --- | --- | --- | --- | --- | --- | --- | --- |
| 296 | Compile procedures currently in use | 2005-03-16 → 2005-03-15 (-1d) | 2005-03-16 → 2005-03-15 (-1d) |  |  |  |  |
| 297 | Identify if existing procedures in use "somewhere out there" may be acceptible (e.g. NARA) | 2005-03-16 → 2005-03-15 (-1d) | 2005-03-16 → 2005-03-15 (-1d) |  |  |  |  |
| 298 | Collect Information | 2005-03-16 → 2005-03-15 (-1d) | 2005-03-16 → 2005-03-15 (-1d) |  |  |  |  |
| 299 | Identify test procedures for documentation and archiving | 2005-03-16 → 2005-03-15 (-1d) | 2005-03-16 → 2005-03-15 (-1d) |  |  |  |  |
| 300 | Conduct Analysis | 2005-03-16 → 2005-03-15 (-1d) | 2005-03-16 → 2005-03-15 (-1d) |  |  |  |  |
| 301 | Test and identify strengths/weaknesses of existing procedures | 2005-03-16 → 2005-03-15 (-1d) | 2005-03-16 → 2005-03-15 (-1d) |  |  |  |  |
| 302 | Develop Preliminary Requirements Specifications | 2005-03-16 → 2005-03-15 (-1d) | 2005-03-16 → 2005-03-15 (-1d) |  |  |  |  |
| 303 | Prepare recommendations | 2005-03-16 → 2005-03-15 (-1d) | 2005-03-16 → 2005-03-15 (-1d) |  |  |  |  |
| 304 | Review and Validate Requirements | 2005-03-16 → 2005-03-15 (-1d) | 2005-03-16 → 2005-03-15 (-1d) |  |  |  |  |
| 306 | **Incident GIS Transition Procedures** | 2005-03-16 → 2005-03-15 (-1d) | 2005-03-16 → 2005-03-15 (-1d) |  |  |  |  |
| 307 | **Define Information Needs (What do we need to gather?)** | 2005-03-16 → 2005-03-15 (-1d) | 2005-03-16 → 2005-03-15 (-1d) |  |  |  |  |
| 308 | Determine "universe" of transitions: (team to team); (team to unit); (team to archive) | 2005-03-16 → 2005-03-15 (-1d) | 2005-03-16 → 2005-03-15 (-1d) |  |  |  |  |
| 309 | Compile procedures currently in use | 2005-03-16 → 2005-03-15 (-1d) | 2005-03-16 → 2005-03-15 (-1d) |  |  |  |  |
| 310 | Identify if existing procedures in use "somewhere out there" may be acceptible (e.g. NARA) | 2005-03-16 → 2005-03-15 (-1d) | 2005-03-16 → 2005-03-15 (-1d) |  |  |  |  |
| 311 | Evaluate Procedures | 2005-03-16 → 2005-03-15 (-1d) | 2005-03-16 → 2005-03-15 (-1d) |  |  |  |  |
| 312 | Identify test procedures for documentation and archiving | 2005-03-16 → 2005-03-15 (-1d) | 2005-03-16 → 2005-03-15 (-1d) |  |  |  |  |
| 313 | **Conduct Analysis** | 2005-03-16 → 2005-03-15 (-1d) | 2005-03-16 → 2005-03-15 (-1d) |  |  |  |  |
| 314 | Test and identify strengths/weaknesses of existing procedures | 2005-03-16 → 2005-03-15 (-1d) | 2005-03-16 → 2005-03-15 (-1d) |  |  |  |  |
| 315 | **Develop Preliminary Requirements Specifications** | 2005-03-16 → 2005-03-15 (-1d) | 2005-03-16 → 2005-03-15 (-1d) |  |  |  |  |
| 316 | Prepare recommendations | 2005-03-16 → 2005-03-15 (-1d) | 2005-03-16 → 2005-03-15 (-1d) |  |  |  |  |
| 317 | **Review and Validate Requirements** | 2005-03-16 → 2005-03-15 (-1d) | 2005-03-16 → 2005-03-15 (-1d) |  |  |  |  |
| 318 | Sub-Team Review of SOP | 2005-03-16 → 2005-03-15 (-1d) | 2005-03-16 → 2005-03-15 (-1d) |  |  |  |  |
| 319 | Revise, Edit Proposed SOP | 2005-03-16 → 2005-03-15 (-1d) | 2005-03-16 → 2005-03-15 (-1d) |  |  |  |  |
| 320 | Submit to Project Manager for Team Review | 2005-03-16 → 2005-03-15 (-1d) | 2005-03-16 → 2005-03-15 (-1d) |  |  |  |  |
| 322 | **Draft Incident GIS SOPs (Somewhat Incorporated into WBS 2)** | 2004-12-01 → 2004-10-20 (-42d) | 2004-12-01 → 2004-10-20 (-42d) |  | 392d → 422d |  | was named Draft Incident GIS SOPs |
| 323 | Develop template for GIS SOPs for all Subgroups | 2004-12-01 → 2004-10-20 (-42d) | 2004-12-01 → 2004-10-20 (-42d) |  | 392d → 422d |  |  |
| 324 | Define Information Needs (What do we need to gather?) | 2004-12-01 → 2004-10-20 (-42d) | 2004-12-01 → 2004-10-20 (-42d) |  | 392d → 422d |  |  |
| 325 | Collect Information | 2004-12-01 → 2004-10-20 (-42d) | 2004-12-01 → 2004-10-20 (-42d) |  | 392d → 422d |  |  |
| 326 | Conduct Analysis | 2004-12-01 → 2004-10-20 (-42d) | 2004-12-01 → 2004-10-20 (-42d) |  | 392d → 422d |  |  |
| 327 | Develop Preliminary SOP’s | 2004-12-01 → 2004-10-20 (-42d) | 2004-12-01 → 2004-10-20 (-42d) |  | 392d → 422d |  |  |
| 328 | Review and Validate draft SOP’s | 2004-12-01 → 2004-10-20 (-42d) | 2004-12-01 → 2004-10-20 (-42d) |  | 392d → 422d |  |  |
| 329 | Incorporate Feedback from reviewers | 2004-12-01 → 2004-10-20 (-42d) | 2004-12-01 → 2004-10-20 (-42d) |  | 392d → 422d |  |  |
| 330 | Develop GSTOP Change Management Plan | 2004-12-01 → 2004-10-20 (-42d) | 2004-12-01 → 2004-10-20 (-42d) |  | 392d → 422d |  |  |
| 331 | Review GSTOP Change Management Plan | 2004-12-01 → 2004-10-20 (-42d) | 2004-12-01 → 2004-10-20 (-42d) |  | 392d → 422d |  |  |
| 332 | PRELIMINARY GIS SOP’s READY FOR FIELD TESTING | 2004-12-01 → 2004-10-20 (-42d) | 2004-12-01 → 2004-10-20 (-42d) |  | 392d → 422d |  |  |
| 333 | **Incident GIS SOPs Field Test** | 2004-12-01 → 2004-10-20 (-42d) | 2004-12-01 → 2004-10-20 (-42d) |  | 392d → 422d |  |  |
| 334 | Develop Quality Assurance and Field Test Plan | 2004-12-01 → 2004-10-20 (-42d) | 2004-12-01 → 2004-10-20 (-42d) |  | 392d → 422d |  | resources none → Subteam Lead |
| 335 | develop questionnaire | 2004-12-01 → 2004-10-20 (-42d) | 2004-12-01 → 2004-10-20 (-42d) |  | 392d → 422d |  |  |
| 336 | Execute Quality Assurance and Field Test Plan | 2004-12-01 → 2004-10-20 (-42d) | 2004-12-01 → 2004-10-20 (-42d) |  | 392d → 422d |  |  |
| 337 | collect written/survey results from the field test | 2004-12-01 → 2004-10-20 (-42d) | 2004-12-01 → 2004-10-20 (-42d) |  | 392d → 422d |  |  |
| 338 | conduct interviews with GISTs to measure success of Draft SOPs | 2004-12-01 → 2004-10-20 (-42d) | 2004-12-01 → 2004-10-20 (-42d) |  | 392d → 422d |  |  |
| 339 | conduct interviews with SIT Unit Leaders to measure success of Draft SOPs | 2004-12-01 → 2004-10-20 (-42d) | 2004-12-01 → 2004-10-20 (-42d) |  | 392d → 422d |  |  |
| 340 | Analyze Quality Assurance and Field Test Plan Results | 2004-12-01 → 2004-10-20 (-42d) | 2004-12-01 → 2004-10-20 (-42d) |  | 392d → 422d |  |  |
| 341 | Ensure requirements are reviewed and tested by business community | 2004-12-01 → 2004-10-20 (-42d) | 2004-12-01 → 2004-10-20 (-42d) |  | 392d → 422d |  |  |
| 342 | **Final Incident GIS SOPs** | 2004-12-01 → 2005-04-01 (+121d) | 2004-12-01 → 2005-04-01 (+121d) |  | 392d → 305d | none → 23 |  |
| 343 | Analyze feedback on Incident GIS SOPs | 2004-12-01 → 2005-04-01 (+121d) | 2004-12-01 → 2005-04-01 (+121d) |  | 392d → 305d |  |  |
| 344 | Update and finalize Incident GIS SOPs | 2004-12-01 → 2005-04-01 (+121d) | 2004-12-01 → 2005-04-01 (+121d) |  | 392d → 305d |  |  |
| 345 | Deliver Final Incident GIS SOPs to Executive Committee | 2004-12-01 → 2005-04-01 (+121d) | 2004-12-01 → 2005-04-01 (+121d) |  | 392d → 305d |  |  |
| 346 | Deliver Final Incident GIS SOPs to Incident Based Automation Project | 2004-12-01 → 2005-04-01 (+121d) | 2004-12-01 → 2005-04-01 (+121d) |  | 392d → 305d |  |  |
| 348 | **GSTOP Project Closeout** | 2004-12-01 → 2004-10-20 (-42d) |  | 393d? → 423d? |  |  |  |
| 349 | Prepare GSTOP Team Recommendations | 2004-12-01 → 2004-10-20 (-42d) | 2004-12-01 → 2004-10-20 (-42d) |  | 392d → 422d |  |  |
| 350 | Document Lessons Learned | 2004-12-01 → 2004-10-20 (-42d) | 2004-12-01 → 2004-10-20 (-42d) |  | 392d → 422d |  |  |

## Version 3 (data date 2005-03-23, saved 2005-03-25, file GSTOP Project Timeline032505.mpp)

Last finish stays 2006-06-02. Complete tasks 0 → 24.

Added:

| ID | Task | Duration | Start | Finish | Predecessors | Constraint | Resources |
| --- | --- | --- | --- | --- | --- | --- | --- |
| 56 | Collect Fire mapping symbols suggestions from the BIA | 7d? | 2005-03-24 | 2005-04-01 | 55 | finish no earlier than 2005-04-01 | Kim Kelly; Luther Arizana |
| 57 | Collect Fire mapping symbols from HSA (FEMA), FAA | 81d? | 2004-12-01 A | 2005-03-23 A |  |  |  |
| 76 | Review draft Standard Symbols | 5d | 2005-04-18 | 2005-04-22 | 75 |  | GSTOP Team; GTG |
| 83 | Review draft Standard Symbols | 10d | 2005-05-10 | 2005-05-23 | 82 |  | Reviewers |
| 120 | **Establish Std Products Subteam Business Practices** | 14d? | 2005-03-16 | 2005-04-04 |  |  |  |
| 121 | **Develop a Std Products Sub-team Communication Plan** | 1d? | 2005-03-16 | 2005-03-16 |  |  |  |
| 122 | Define ground-rules for Sub-Team (internal) communication | 1d? | 2005-03-16 | 2005-03-16 |  |  |  |
| 123 | Define ground-rules for communication between the Sub-Team and other GSTOP Sub-Teams | 1d? | 2005-03-16 | 2005-03-16 |  |  |  |
| 124 | Define ground rules for communication between the Sub-Team and entities outside of the GSTOP Project | 1d? | 2005-03-16 | 2005-03-16 |  |  |  |
| 125 | Establish a process and schedule for Sub-Team (internal) progress report updates | 1d? | 2005-03-16 | 2005-03-16 |  |  |  |
| 126 | Establish a process and schedule for Sub-Team progress report updates to the GSTOP Team | 1d? | 2005-03-16 | 2005-03-16 |  |  |  |
| 127 | **Establish Review Processes** | 1d? | 2005-03-16 | 2005-03-16 |  |  |  |
| 128 | Establish a process for Sub-Team (internal) review of std products definitions template | 1d? | 2005-03-16 | 2005-03-16 |  |  |  |
| 129 | Establish a process for Sub-Team (internal) review of std products definitions | 1d? | 2005-03-16 | 2005-03-16 |  |  |  |
| 130 | Establish a process for peer reviews | 1d? | 2005-03-16 | 2005-03-16 |  |  |  |
| 131 | Establish a process for periodic GSTOP Team reviews | 1d? | 2005-03-16 | 2005-03-16 |  |  |  |
| 132 | Establish a process for reviewing the final report | 1d? | 2005-03-16 | 2005-03-16 |  |  |  |
| 133 | **Establish Change Processes** | 1d? | 2005-03-16 | 2005-03-16 |  |  |  |
| 134 | Establish a process for additions/deletions of std products mid-stream through the Project | 1d? | 2005-03-16 | 2005-03-16 |  |  |  |
| 135 | Establish a change process for the additions/deletion of standard products after the final recommendation has been submitted and prior to completion of the GSTOP project | 1d? | 2005-03-16 | 2005-03-16 |  |  |  |
| 136 | Establish a change process for the additions/deletion of standard products after the completion of the GSTOP project | 1d? | 2005-03-16 | 2005-03-16 |  |  |  |
| 137 | Review Business Practices Developed by Symbology SubTeam and agree or advise | 1d? | 2005-04-04 | 2005-04-04 | 23 |  | StdProd Subteam |
| 138 | **Define criteria for the acceptance of standard products definitions** | 2d? | 2005-03-16 | 2005-03-17 |  |  |  |
| 139 | Develop acceptance criteria for std products definitions | 1d? | 2005-03-16 | 2005-03-16 |  |  |  |
| 140 | Conduct a final review of selection criteria | 1d? | 2005-03-17 | 2005-03-17 | 139 |  |  |
| 141 | **Define/Collect Information** | 25d? | 2005-02-09 A | 2005-03-16 |  |  |  |
| 144 | Victoria Smith definitions/PNWCG definitions/DPRO defs. Compile these into a list for group to review. Cite source. | 0d? | 2005-03-01 A | 2005-03-01 A |  |  |  |
| 145 | Post for review including samples | 1d? | 2005-03-16 | 2005-03-16 | 144 |  |  |
| 146 | Collect examples of new kinds of standard products that aren't in any of the existing definitions | 1d? | 2005-02-10 A | 2005-02-10 |  | start no earlier than 2005-02-10 |  |
| 148 | Define the meaning of product definitions - what goes into them? | 1d? | 2005-03-17 | 2005-03-17 |  |  |  |
| 149 | Create a draft template of what a product definition is | 1d? | 2005-03-23 | 2005-03-23 |  | finish no earlier than 2005-03-23 |  |
| 150 | Review existing standards definitions (Victoria/PNWCG/DPRO) & Identify discrepancies between groups defining standard | 10d | 2005-03-24 | 2005-04-06 | 149 |  |  |
| 151 | Highlight specific reasons for discrepancies (Fire Use vs. Type 1) if needed | 1d? | 2005-03-24 | 2005-03-24 | 149 |  |  |
| 152 | Bring these to the larger group for discussion and resolution | 10d | 2005-04-07 | 2005-04-20 | 151, 150, 149 |  | GSTOP Team; GTG |
| 153 | Gather responses from GSTOP and GTG; incorporte feedback | 1d? | 2005-04-21 | 2005-04-21 | 152 |  |  |
| 154 | Send out to wider folks for review (Field Test) | 1d? | 2005-04-22 | 2005-04-22 | 153 |  |  |
| 155 | **Develop Preliminary Package of Standard Products Definitions for Internal Review** | 1d? | 2005-04-25 | 2005-04-25 | 147 |  |  |
| 156 | Provide a package of draft products definitions and samples for review | 1d? | 2005-04-25 | 2005-04-25 |  |  |  |
| 157 | Evaluate std products against acceptance criteria | 1d? | 2005-04-25 | 2005-04-25 |  |  |  |
| 159 | Provide data location and review process to internal group | 1d? | 2005-04-25 | 2005-04-25 |  |  |  |
| 160 | **Conduct outside peer review of the draft standard products definitions** | 4d? | 2005-04-26 | 2005-04-29 | 155 |  |  |
| 161 | Submit the draft standard symbols to the 5 federal fire management agencies and State agencies via the NWCG Geospatial Task Group (GTG); and to the DHS (FEMA), FAA, DOD, and GSTOP Team for peer review | 1d? | 2005-04-26 | 2005-04-26 |  |  | GTG |
| 162 | Review feedback of initial peer review | 1d? | 2005-04-27 | 2005-04-27 | 161 |  |  |
| 163 | Identify required changes to draft standard products based on the initial peer review feedback | 1d? | 2005-04-28 | 2005-04-28 | 162 |  |  |
| 164 | Make required changes, as identified, to draft standard products | 1d? | 2005-04-29 | 2005-04-29 | 163 |  |  |
| 165 | **Conduct final peer review of the draft standard products** | 6d? | 2005-05-02 | 2005-05-09 | 160 |  |  |
| 166 | Prepare draft standard products for final peer review | 1d? | 2005-05-02 | 2005-05-02 |  |  |  |
| 167 | Submit the draft standard products to the 5 federal fire management agencies and State agencies via the NWCG Geospatial Task Group (GTG); and to the HSA (FEMA), FAA, DOD, and GSTOP Team for peer review | 1d? | 2005-05-03 | 2005-05-03 | 166 |  | GTG |
| 168 | Review feedback of the final peer review | 1d? | 2005-05-04 | 2005-05-04 | 167 |  |  |
| 169 | Identify required changes to draft standard products based on the final peer review feedback | 1d? | 2005-05-05 | 2005-05-05 | 168 |  |  |
| 170 | Make required changes, as identified, to draft standard products | 1d? | 2005-05-06 | 2005-05-06 | 169 |  |  |
| 171 | Ratify the final draft standard symbols | 1d? | 2005-05-09 | 2005-05-09 | 170 |  |  |
| 172 | **Finalize recommendation of standard Fire Mapping products** | 2d? | 2005-05-10 | 2005-05-11 | 165 |  |  |
| 173 | Create a report recommending the adoption of the draft standard product definitions | 1d? | 2005-05-10 | 2005-05-10 |  |  |  |
| 174 | Conduct a review of the report for completeness, accuracy, language, and grammar | 1d? | 2005-05-11 | 2005-05-11 | 173 |  | StdProd Subteam |
| 175 | Submit the report to GSTOP-PM | 0d | 2005-05-11 | 2005-05-11 | 174 |  |  |
| 204 | Obtain and review revised Taskbook | 0.5d? | 2005-03-24 | 2005-03-24 | 203 |  | John Guthrie; Victoria Smith |
| 260 | **Establish MED evaluation methods** | 15d? | 2005-03-16 A | 2005-04-05 |  |  | MED Subteam |
| 262 | Determine GIS tasks to be done on an incident | 1d? | 2005-03-16 | 2005-03-16 |  |  |  |
| 263 | Determine GIS products needed per proposed GIS task | 1d? | 2005-03-16 | 2005-03-16 |  |  |  |
| 265 | Post draft Acceptance Critera for GSTOP Team review | 4d? | 2005-03-18 A | 2005-03-23 A |  |  |  |
| 266 | Review draft Acceptance Criteria | 1d? | 2005-03-28 | 2005-03-28 | 265 | finish no earlier than 2005-03-28 | GSTOP Team |
| 267 | Update Acceptance Criteria for GSTOP Team input | 4d | 2005-03-29 | 2005-04-01 | 266 |  |  |
| 282 | **Determine the draft extended vector and raster MEDs** | 3d? | 2005-04-08 | 2005-04-12 | 274, 278 |  | MED Subteam |
| 283 | Evaluate each potential extended MED against the extended MED selection criteria | 1d? | 2005-04-08 | 2005-04-08 |  |  |  |
| 284 | Sub-Team selection of the draft standard MEDs vs. extended MED list | 1d? | 2005-04-11 | 2005-04-11 | 283 |  |  |
| 285 | Conduct a Sub-team completeness review of the draft standard MEDs | 1d? | 2005-04-12 | 2005-04-12 | 284 |  |  |
| 323 | Compile existing archiving standards in use (e.g. data format, transfer mode) | 1d? | 2005-03-16 | 2005-03-16 |  |  | GTG Standards Committee; Mary Kwart |
| 324 | Identify how archiving is done at present time by ICS, military, other incident responders, project-management | 1d? | 2005-03-16 | 2005-03-16 |  |  | Internet Search; Military; etc.; survey GISTs; Plans Sections (Mary Kwart); Documents Sections |
| 325 | Gather NARA, Records Management requirements (review policies, lawsuits) e.g. physical location, acceptable media, supporting documentation | 1d? | 2005-03-16 | 2005-03-16 |  |  | Business Lead; FGDC; NARA; agency guidance |
| 326 | Determine the least common denominator (shapefile) or possibility of multiple formats | 1d? | 2005-03-16 | 2005-03-16 |  |  | TBD |
| 327 | Collect Information: Conduct literature review | 1d? | 2005-03-16 | 2005-03-16 |  |  | FGDC; GeoMAC; NPS I&M; NPS Focus; NARA |
| 328 | Conduct Analysis: Compile, Synthesize requirements | 1d? | 2005-03-17 | 2005-03-17 | 327 |  |  |
| 340 | **Evaluate Procedures** | 1d? | 2005-03-21 | 2005-03-21 | 336 |  |  |
| 342 | Conduct Analysis: Test and identify strengths/weaknesses of existing procedures | 1d? | 2005-03-22 | 2005-03-22 | 340 |  | field teams; DataShareArcTrans Subteam |
| 343 | Develop Preliminary Requirements Specifications | 1d? | 2005-03-23 | 2005-03-23 | 342 |  |  |
| 345 | Sub-Team Review of SOP | 1d? | 2005-03-24 | 2005-03-24 |  |  | DataShareArcTrans Subteam |
| 346 | Revise, Edit Proposed SOP | 1d? | 2005-03-25 | 2005-03-25 | 345 |  | DataShareArcTrans Subteam |
| 347 | Submit to Project Manager for Team Review | 1d? | 2005-03-28 | 2005-03-28 | 346 |  |  |
| 349 | MS1: Requirements for GIS SOPs are developed | 0d | 2005-03-31 | 2005-03-31 | 22, 92, 119, 178, 242, 305, 321 | must finish on 2005-03-31 | Project Mgr; GSTOP Exec Comm |
| 357 | MS2: Draft SOPs are produced and ready for Field Test | 0.5d? | 2005-05-13 | 2005-05-13 |  | must finish on 2005-05-13 | Project Mgr; Business Lead |
| 358 | **>>> Check this stuff too>>Might be part of Subteam plans** | 1d? | 2004-10-20 | 2004-10-20 |  |  |  |
| 382 | MS3: Requirements are reviewed and tested by business community | 0d | 2005-12-15 | 2005-12-15 |  | must finish on 2005-12-15 | Business Lead; Business Community; Project Mgr |
| 390 | MS5: GIS SOPs are finalized | 0d | 2006-05-15 | 2006-05-15 |  | must finish on 2006-05-15 | Project Mgr; GSTOP Exec Comm |
| 392 | MS6: Draft recommendation for SOP implementation | 0d | 2006-06-01 | 2006-06-01 |  | must finish on 2006-06-01 | GSTOP Team; GSTOP Exec Comm |
| 393 | **GSTOP Project Management** | 423d? | 2004-10-20 A | 2006-06-02 |  |  | Sue McLellan |
| 394 | **Manage GSTOP Project** | 147d? | 2004-10-20 A | 2005-05-12 |  |  |  |
| 396 | **Conduct Periodic Team Meetings** | 78d | 2005-01-25 A | 2005-05-12 |  |  | Project Mgr |
| 397 | Conduct January Team Meeting (Portland) | 3d | 2005-01-25 A | 2005-01-27 A |  | start no earlier than 2005-01-25 | GSTOP Team; Project Mgr |
| 398 | Conduct May Team Meeting (Denver) | 3d | 2005-05-10 | 2005-05-12 |  | start no earlier than 2005-05-10 | GSTOP Team; Project Mgr |
| 399 | **Report to Executive Committee** | 105d | 2004-10-20 A | 2005-03-16 |  |  |  |
| 401 | Q2 2005 Executive Briefing | 1d | 2004-10-20 | 2004-10-20 |  |  | Project Mgr; GTG Exec Comm |

Removed: 1 GSTOP Project; 21 Team Meeting; 121 Need group assistance – there are no members who volunteered for this subgroup. It will need the participation of everyone to work.; 122 Provide a final package of Standard Products including definitions and examples.; 123 Collect Information; 124 Definitions exist in the National Training course workbook for GIST. PNWCG has also created some standard definitions. Compile these into a list for group to review. Cite source.; 125 Review DPRO product definitions and compare to existing definitions for GIST.; 126 Collect examples of standard products.; 128 Review existing standards definitions (GIST course/PNWCG/DPRO); 129 Identify discrepancies between groups defining standard and bring these to the larger group for discussion and resolution. There may be specific reasons for discrepancies (Fire Use vs. Type 1) so these should be highlighted for the preliminary package.; 130 Develop Preliminary Requirements Specifications; 131 Provide a package of products definitions and samples for group review (GIST/SITL review?); 134 Decide upon method of acceptance/rejection/modification; 135 Decide who to get feedback from (GIST 1st, then SITL/PLSC/others?); 136 Incorporate feedback into final package of definitions & samples; 219 Establish MED evaluation methods; 220 Define method for evaluating marker MEDs; 221 Define method for evaluating line MEDs; 223 Conduct a final review of evaluation methods; 225 Develop acceptance criteria for marker MEDs; 226 Develop acceptance criteria for line MEDs; 227 Develop acceptance criteria for fill MEDs; 242 Determine the draft standard Point MEDs; 243 Evaluate each potential fill MED against the fill MED selection criteria; 244 Sub-Team selection of the draft standard fill MEDs; 294 Incident GIS Standard Documentation and Archiving Procedures; 295 Identify hierarchy of archive needs (incident, land unit, agency, NARA); 298 Collect Information; 300 Conduct Analysis; 301 Test and identify strengths/weaknesses of existing procedures; 303 Prepare recommendations; 304 Review and Validate Requirements; 309 Compile procedures currently in use; 310 Identify if existing procedures in use "somewhere out there" may be acceptible (e.g. NARA); 311 Evaluate Procedures; 312 Identify test procedures for documentation and archiving; 313 Conduct Analysis; 314 Test and identify strengths/weaknesses of existing procedures; 315 Develop Preliminary Requirements Specifications; 316 Prepare recommendations; 324 Define Information Needs (What do we need to gather?); 325 Collect Information; 326 Conduct Analysis; 332 PRELIMINARY GIS SOP’s READY FOR FIELD TESTING

Changed:

| ID | Task | Start | Finish | Duration | Complete | Total float | Predecessors | Other |
| --- | --- | --- | --- | --- | --- | --- | --- | --- |
| 1 | **Initiate the GSTOP Project** | 2004-10-20 A | 2005-03-15 A |  | 0% → 100% | 318d → none |  |  |
| 2 | GSTOP Executive Committee Formed | 2004-12-01 A | 2004-12-08 A |  | 0% → 100% | 387d → none |  | resources IRWMT → IRMWT |
| 3 | GSTOP Project Manager Identified | 2004-10-20 A | 2004-10-20 A |  | 0% → 100% | 422d → none |  |  |
| 4 | GSTOP Project Charter Approved | 2004-10-20 A | 2004-12-01 A |  | 0% → 100% | 392d → none |  | constraint start no earlier than 2004-10-20 → none; resources NWCG member agencies → NWCG Member Agencies |
| 5 | Secure GSTOP Project Funding | 2004-12-01 A | 2005-03-04 A |  | 0% → 100% | 325d → none |  | was named GSTOP Project Funding Secured; resources NWCG member agencies → NWCG Member Agencies |
| 6 | **Identify GSTOP Project Team** | 2004-10-20 → 2004-12-02 A (+43d) | 2005-03-15 A | 105d? → 74d? | 0% → 100% | 318d → none |  | was named GSTOP Project Team Identified |
| 7 | **Form the GSTOP Team** | 2004-10-20 → 2004-12-02 A (+43d) | 2005-03-15 A | 105d? → 74d? | 0% → 100% | 318d → none | none → 4 |  |
| 8 | GSTOP Project Business Lead Identified | 2004-12-15 A | 2005-01-24 A |  | 0% → 100% | 354d → none |  |  |
| 9 | Define and Assign Project Subteams and Leads | 2005-01-24 → 2004-12-02 A (-53d) | 2005-01-28 → 2004-12-08 A (-51d) |  | 0% → 100% | 350d → none |  | constraint start no earlier than 2005-01-24 → none |
| 10 | Develop Project Team Operating Principles & Guidelines | 2005-01-24 → 2004-12-02 A (-53d) | 2005-01-28 → 2004-12-08 A (-51d) |  | 0% → 100% | 350d → none |  | constraint start no earlier than 2005-01-24 → none |
| 11 | **Develop the GSTOP Project Management Plans** | 2004-10-20 → 2004-12-02 A (+43d) | 2005-03-15 A | 105d? → 74d? | 0% → 100% | 318d → none |  | resources S.McLellan → Project Mgr |
| 12 | Review Charter and resolve any ambiguities/issues | 2005-01-03 → 2004-12-02 A (-32d) | 2005-03-14 → 2005-02-10 A (-32d) |  | 0% → 100% | 319d → none |  | constraint start no earlier than 2005-01-03 → none |
| 13 | Develop Intial Project Work Plan | 2005-01-04 → 2004-12-02 A (-33d) | 2005-03-14 → 2005-02-09 A (-33d) |  | 0% → 100% | 319d → none |  | constraint start no earlier than 2005-01-04 → none |
| 14 | Develop Intial Project Communication Plan | 2004-12-06 A | 2005-03-15 A |  | 0% → 100% | 318d → none |  |  |
| 15 | Develop Intial Project Responsibility Matrix | 2004-10-20 → 2004-12-02 A (+43d) | 2004-10-20 → 2004-12-02 A (+43d) |  | 0% → 100% | 422d → none |  |  |
| 16 | Develop Intial Project Resource Plan | 2005-01-31 → 2004-12-02 A (-60d) | 2005-03-14 → 2005-01-13 A (-60d) |  | 0% → 100% | 319d → none |  | constraint start no earlier than 2005-01-31 → none |
| 17 | **Setup the project team's structures for communication** | 2004-10-20 → 2004-12-02 A (+43d) | 2005-03-01 → 2005-01-28 A (-32d) | 95d? → 42d? | 0% → 100% | 328d → none |  | was named Develop the GSTOP Communication and Management Structures; resources Mary Kwart → Business Lead |
| 18 | Create GSTOP private team workspace | 2004-10-20 → 2004-12-02 A (+43d) | 2004-10-20 → 2004-12-02 A (+43d) |  | 0% → 100% | 422d → none |  |  |
| 19 | Develop Project Status Report Template | 2005-01-03 → 2004-12-02 A (-32d) | 2005-03-01 → 2005-01-28 A (-32d) |  | 0% → 100% | 328d → none |  | constraint start no earlier than 2005-01-03 → none |
| 21 | **GSTOP Requirements** | 2005-03-15 → 2004-12-01 A (-104d) | 2005-03-31 → 2005-06-02 (+63d) | 13d? → 132d? | 0% → 15% | 305d → 247d |  |  |
| 22 | **Incident GIS Standard Symbology Requirements** | 2005-03-15 → 2004-12-01 A (-104d) | 2005-03-18 → 2005-06-02 (+76d) | 4d? → 132d? | 0% → 19% | 314d → -44d |  | resources subteam → Ken Bottle |
| 23 | **Establish Symbols Sub-Team business practices** | 2005-03-15 → 2005-01-12 A (-62d) | 2005-03-15 → 2005-04-01 (+17d) | 1d? → 58d? |  | 317d → 0d |  |  |
| 24 | **Develop a Symbol Sub-team Communication Plan** | 2005-03-15 → 2005-01-12 A (-62d) | 2005-03-15 → 2005-03-25 (+10d) | 1d? → 53d? |  | 317d → 3d |  |  |
| 25 | Define ground-rules for Sub-Team (internal) communication | 2005-03-15 → 2005-01-12 A (-62d) | 2005-03-15 → 2005-03-25 (+10d) | 1d? → 53d? |  | 317d → 3d |  | constraint none → finish no earlier than 2005-03-25 |
| 26 | Define ground-rules for communication between the Symbol Sub-Team and other GSTOP Sub-Teams | 2005-03-15 → 2005-01-12 A (-62d) | 2005-03-15 → 2005-03-25 (+10d) | 1d? → 53d? |  | 317d → 3d |  | constraint none → finish no earlier than 2005-03-25 |
| 27 | Define ground rules for communication between the Sub-Team and entities outside of the GSTOP Project | 2005-03-15 → 2005-01-12 A (-62d) | 2005-03-15 → 2005-03-25 (+10d) | 1d? → 53d? |  | 317d → 3d |  | constraint none → finish no earlier than 2005-03-25 |
| 28 | Establish a process and schedule for Sub-Team (internal) progress report updates | 2005-03-15 → 2005-01-12 A (-62d) | 2005-03-15 → 2005-03-25 (+10d) | 1d? → 53d? |  | 317d → 3d |  | constraint none → finish no earlier than 2005-03-25 |
| 29 | Establish a process and schedule for Sub-Team progress report updates to the GSTOP Team | 2005-03-15 → 2005-01-12 A (-62d) | 2005-03-15 → 2005-03-25 (+10d) | 1d? → 53d? |  | 317d → 3d |  | constraint none → finish no earlier than 2005-03-25 |
| 30 | **Establish Review Processes** | 2005-03-15 → 2005-01-12 A (-62d) | 2005-03-15 → 2005-04-01 (+17d) | 1d? → 58d? |  | 317d → 0d |  |  |
| 31 | Establish a process for Sub-Team (internal) review of potential symbols | 2005-03-15 → 2005-01-12 A (-62d) | 2005-03-15 → 2005-04-01 (+17d) | 1d? → 58d? |  | 317d → 0d |  | constraint none → finish no earlier than 2005-04-01 |
| 32 | Establish a process for Sub-Team (internal) review of the draft standard symbols | 2005-03-15 → 2005-01-12 A (-62d) | 2005-03-15 → 2005-04-01 (+17d) | 1d? → 58d? |  | 317d → 0d |  | constraint none → finish no earlier than 2005-04-01 |
| 33 | Establish a process for peer reviews | 2005-03-15 → 2005-01-12 A (-62d) | 2005-03-15 → 2005-04-01 (+17d) | 1d? → 58d? |  | 317d → 0d |  | constraint none → finish no earlier than 2005-04-01 |
| 34 | Establish a process for periodic GSTOP Team reviews | 2005-03-15 → 2005-01-12 A (-62d) | 2005-03-15 → 2005-04-01 (+17d) | 1d? → 58d? |  | 317d → 0d |  | constraint none → finish no earlier than 2005-04-01 |
| 35 | Establish a process for reviewing the final report | 2005-03-15 → 2005-01-12 A (-62d) | 2005-03-15 → 2005-04-01 (+17d) | 1d? → 58d? |  | 317d → 0d |  | constraint none → finish no earlier than 2005-04-01 |
| 36 | **Establish Change processes** | 2005-03-15 → 2005-01-12 A (-62d) | 2005-03-15 → 2005-04-01 (+17d) | 1d? → 58d? |  | 317d → 0d |  |  |
| 37 | Establish a process for additions/deletions of potential symbols mid-stream through the Project | 2005-03-15 → 2005-01-12 A (-62d) | 2005-03-15 → 2005-04-01 (+17d) | 1d? → 58d? |  | 317d → -58d |  |  |
| 38 | Establish a change process for the additions/deletion of standard symbols after the final recommendation has been submitted and prior to completion of the GSTOP project | 2005-03-15 → 2005-01-12 A (-62d) | 2005-03-15 → 2005-04-01 (+17d) | 1d? → 58d? |  | 317d → -58d | none → 37 |  |
| 39 | Establish a change process for the additions/deletion of standard symbols after the completion of the GSTOP project | 2005-03-15 → 2005-01-12 A (-62d) | 2005-03-15 → 2005-04-01 (+17d) | 1d? → 58d? |  | 317d → -2d | none → 38 |  |
| 40 | **Establish symbol evaluation methods** | 2005-03-15 → 2005-03-17 (+2d) | 2005-03-15 → 2005-04-01 (+17d) | 1d? → 12d? |  | 317d → -1d |  |  |
| 41 | Define method for evaluating marker symbols | 2005-03-15 → 2005-03-17 (+2d) | 2005-03-15 → 2005-04-01 (+17d) | 1d? → 12d? |  | 317d → -1d |  | constraint none → finish no earlier than 2005-04-01 |
| 42 | Define method for evaluating line symbols | 2005-03-15 → 2005-03-17 (+2d) | 2005-03-15 → 2005-04-01 (+17d) | 1d? → 12d? |  | 317d → -1d |  | constraint none → finish no earlier than 2005-04-01 |
| 43 | Define method for evaluating fill symbols | 2005-03-15 → 2005-03-17 (+2d) | 2005-03-15 → 2005-04-01 (+17d) | 1d? → 12d? |  | 317d → -1d |  | constraint none → finish no earlier than 2005-04-01 |
| 44 | Conduct a final review of evaluation methods | 2005-03-15 → 2005-03-17 (+2d) | 2005-03-15 → 2005-04-01 (+17d) | 1d? → 12d? |  | 317d → -1d |  | constraint none → finish no earlier than 2005-04-01 |
| 45 | **Define criteria for the acceptance of symbols as standards** | 2005-03-15 → 2005-03-17 (+2d) | 2005-03-15 → 2005-04-08 (+24d) | 1d? → 17d? |  | 317d → -6d |  | resources none → John Guthrie; Karen Folger; Ken Bottle |
| 46 | Develop acceptance criteria for marker symbols | 2005-03-15 → 2005-03-17 (+2d) | 2005-03-15 → 2005-04-08 (+24d) | 1d? → 17d? |  | 317d → -6d |  | constraint none → finish no earlier than 2005-04-08 |
| 47 | Develop acceptance criteria for line symbols | 2005-03-15 → 2005-03-17 (+2d) | 2005-03-15 → 2005-04-08 (+24d) | 1d? → 17d? |  | 317d → -6d |  | constraint none → finish no earlier than 2005-04-08 |
| 48 | Develop acceptance criteria for fill symbols | 2005-03-15 → 2005-03-17 (+2d) | 2005-03-15 → 2005-04-08 (+24d) | 1d? → 17d? |  | 317d → -6d |  | constraint none → finish no earlier than 2005-04-08 |
| 49 | Conduct a final review of selection criteria | 2005-03-15 → 2005-03-17 (+2d) | 2005-03-15 → 2005-04-08 (+24d) | 1d? → 17d? |  | 317d → -6d |  | constraint none → finish no earlier than 2005-04-08 |
| 50 | **Establish file format for symbols** | 2005-03-15 → 2005-02-01 A (-42d) | 2005-03-15 → 2005-04-01 (+17d) | 1d? → 44d? |  | 317d → 0d |  |  |
| 51 | Define acceptable formats of symbols for evaluation | 2005-03-15 → 2005-02-01 A (-42d) | 2005-03-15 → 2005-04-01 (+17d) | 1d? → 44d? |  | 317d → 0d |  | constraint none → finish no earlier than 2005-04-01 |
| 52 | Define format of recommended standard symbols | 2005-03-15 → 2005-02-01 A (-42d) | 2005-03-15 → 2005-04-01 (+17d) | 1d? → 44d? |  | 317d → 0d |  | constraint none → finish no earlier than 2005-04-01 |
| 53 | **Develop a list of symbols to be evaluated for acceptance as draft standards** | 2005-03-15 → 2004-12-01 A (-104d) | 2005-03-15 → 2005-04-04 (+20d) | 1d? → 89d? | 0% → 94% | 317d → -8d |  |  |
| 54 | Collect Fire mapping symbols from the Fireline Handbook | 2005-03-15 → 2004-12-01 A (-104d) | 2005-03-15 → 2005-03-23 A (+8d) | 1d? → 81d? | 0% → 100% | 317d → none |  |  |
| 55 | Collect Fire mapping symbols suggestions from the 5 federal fire management agencies (FS, BLM, NPS, FWS, BIA) and state agencies | 2005-03-15 → 2004-12-01 A (-104d) | 2005-03-15 → 2005-03-23 A (+8d) | 1d? → 81d? | 0% → 100% | 317d → none |  | was named Collect Fire mapping symbols suggestions from the 5 federal fire management agencies (FS, BLM, NPS, FWS, BIA) and state agencies via the NWCG Geospatial Task Group (GTG) |
| 58 | Collect Fire mapping symbols from HSA (FEMA), FAA, and DOD | 2005-03-15 → 2005-03-24 (+9d) | 2005-03-15 → 2005-04-01 (+17d) | 1d? → 7d? |  | 317d → -44d | none → 57 | constraint none → finish no earlier than 2005-04-01; resources none → Sherry Durst |
| 59 | Document potential sources for additional fire mapping symbols | 2005-03-15 → 2005-03-16 (+1d) | 2005-03-15 → 2005-03-16 (+1d) |  |  | 317d → -32d |  |  |
| 60 | Compile symbols into a single potential symbol set | 2005-03-15 → 2005-04-04 (+20d) | 2005-03-15 → 2005-04-04 (+20d) |  |  | 317d → -45d | none → 54, 55, 56, 57 |  |
| 61 | **Determine the draft standard marker symbols** | 2005-03-15 → 2005-04-05 (+21d) | 2005-03-15 → 2005-04-14 (+30d) | 1d? → 8d? |  | 317d → -45d | none → 53 |  |
| 62 | Evaluate each potential marker symbol against the marker symbol selection criteria | 2005-03-15 → 2005-04-05 (+21d) | 2005-03-15 → 2005-04-05 (+21d) |  |  | 317d → -38d |  |  |
| 63 | Selection the draft standard marker symbols | 2005-03-15 → 2005-04-05 (+21d) | 2005-03-15 → 2005-04-05 (+21d) |  |  | 317d → -38d |  |  |
| 64 | Conduct a completeness review of the draft standard marker symbols | 2005-03-15 → 2005-04-05 (+21d) | 2005-03-15 → 2005-04-14 (+30d) | 1d? → 8d? |  | 317d → -45d |  | constraint none → finish no earlier than 2005-04-14 |
| 65 | **Determine the draft standard line symbols** | 2005-03-15 → 2005-04-05 (+21d) | 2005-03-15 → 2005-04-14 (+30d) | 1d? → 8d? |  | 317d → -45d | none → 53 |  |
| 66 | Evaluate each potential line symbol against the line symbol selection criteria | 2005-03-15 → 2005-04-05 (+21d) | 2005-03-15 → 2005-04-05 (+21d) |  |  | 317d → -38d |  |  |
| 67 | Select the draft standard line symbols | 2005-03-15 → 2005-04-05 (+21d) | 2005-03-15 → 2005-04-05 (+21d) |  |  | 317d → -38d |  |  |
| 68 | Conduct a completeness review of the draft standard line symbols | 2005-03-15 → 2005-04-05 (+21d) | 2005-03-15 → 2005-04-14 (+30d) | 1d? → 8d? |  | 317d → -45d |  | constraint none → finish no earlier than 2005-04-14 |
| 69 | **Determine the draft standard fill symbols** | 2005-03-15 → 2005-04-05 (+21d) | 2005-03-15 → 2005-04-14 (+30d) | 1d? → 8d? |  | 317d → -45d | none → 53 |  |
| 70 | Evaluate each potential fill symbol against the fill symbol selection criteria | 2005-03-15 → 2005-04-05 (+21d) | 2005-03-15 → 2005-04-05 (+21d) |  |  | 317d → -38d |  |  |
| 71 | Select the draft standard fill symbols | 2005-03-15 → 2005-04-05 (+21d) | 2005-03-15 → 2005-04-05 (+21d) |  |  | 317d → -38d |  |  |
| 72 | Conduct a completeness review of the draft standard fill symbols | 2005-03-15 → 2005-04-05 (+21d) | 2005-03-15 → 2005-04-14 (+30d) | 1d? → 8d? |  | 317d → -45d |  | constraint none → finish no earlier than 2005-04-14 |
| 73 | **Conduct initial peer review of the draft standard marker, line, and fill symbols** | 2005-03-15 → 2005-04-15 (+31d) | 2005-03-18 → 2005-05-06 (+49d) | 4d? → 16d? |  | 314d → -45d | none → 61, 65, 69 |  |

| ID | Task | Start | Finish | Duration | Complete | Total float | Predecessors | Other |
| --- | --- | --- | --- | --- | --- | --- | --- | --- |
| 74 | Prepare draft standard symbols for initial peer review | 2005-03-15 → 2005-04-15 (+31d) | 2005-03-15 → 2005-04-15 (+31d) |  |  | 317d → -45d |  |  |
| 75 | Submit the draft standard symbols to the 5 federal fire management agencies and State agencies via the NWCG Geospatial Task Group (GTG); and to the HSA (FEMA), FAA, DOD, and GSTOP Team for peer review | 2005-03-15 → 2005-04-15 (+31d) | 2005-03-15 → 2005-04-15 (+31d) | 1d? → 0d |  | 314d → -45d | none → 74 |  |
| 77 | Review feedback of initial peer review | 2005-03-16 → 2005-05-02 (+47d) | 2005-03-16 → 2005-05-03 (+48d) | 1d? → 2d |  | 314d → -45d | 75 → 75FS+10d |  |
| 78 | Identify required changes to draft standard symbols based on the initial peer review feedback | 2005-03-17 → 2005-05-04 (+48d) | 2005-03-17 → 2005-05-05 (+49d) | 1d? → 2d |  | 314d → -45d |  |  |
| 79 | Make required changes, as identified, to draft standard symbols | 2005-03-18 → 2005-05-06 (+49d) | 2005-03-18 → 2005-05-06 (+49d) |  |  | 314d → -45d |  |  |
| 80 | **Conduct final peer review of the draft standard marker, line and fill symbols** | 2005-03-15 → 2005-05-09 (+55d) | 2005-03-15 → 2005-05-31 (+77d) | 1d? → 17d? |  | 317d → -45d | none → 73 |  |
| 81 | Prepare draft standard symbols for final peer review | 2005-03-15 → 2005-05-09 (+55d) | 2005-03-15 → 2005-05-09 (+55d) |  |  | 317d → -45d |  |  |
| 82 | Submit the draft standard symbols to the 5 federal fire management agencies and State agencies via the NWCG Geospatial Task Group (GTG); and to the HSA (FEMA), FAA, DOD, and GSTOP Team for peer review | 2005-03-15 → 2005-05-09 (+55d) | 2005-03-15 → 2005-05-09 (+55d) | 1d? → 0d |  | 317d → -45d | none → 81 |  |
| 84 | Review feedback of the final peer review | 2005-03-15 → 2005-05-24 (+70d) | 2005-03-15 → 2005-05-24 (+70d) |  |  | 317d → -45d | none → 83 |  |
| 85 | Identify required changes to draft standard symbols based on the final peer review feedback | 2005-03-15 → 2005-05-25 (+71d) | 2005-03-15 → 2005-05-26 (+72d) | 1d? → 2d |  | 317d → -45d | none → 84 |  |
| 86 | Make required changes, as identified, to draft standard symbols | 2005-03-15 → 2005-05-27 (+73d) | 2005-03-15 → 2005-05-30 (+76d) | 1d? → 2d |  | 317d → -45d | none → 85 |  |
| 87 | Ratify the final draft standard symbols | 2005-03-15 → 2005-05-31 (+77d) | 2005-03-15 → 2005-05-31 (+77d) |  |  | 317d → -45d | none → 86 |  |
| 88 | **Finalize recommendation of standard Fire Mapping symbols** | 2005-03-15 → 2005-06-01 (+78d) | 2005-03-15 → 2005-06-02 (+79d) | 1d? → 2d? |  | 317d → -45d | none → 80 |  |
| 89 | Create a report recommending the adoption of the draft standard symbols | 2005-03-15 → 2005-06-01 (+78d) | 2005-03-15 → 2005-06-01 (+78d) |  |  | 317d → -45d |  |  |
| 90 | Conduct a review of the report | 2005-03-15 → 2005-06-02 (+79d) | 2005-03-15 → 2005-06-02 (+79d) |  |  | 317d → -45d | none → 89 |  |
| 91 | Submit the report to GSTOP-PM | 2005-03-15 → 2005-06-02 (+79d) | 2005-03-15 → 2005-06-02 (+79d) | 1d → 0d |  | 317d → -45d | none → 90 |  |
| 92 | **Incident GIS Standard Naming Conventions Requirements** | 2005-03-15 → 2005-03-16 (+1d) | 2005-03-30 → 2005-03-31 (+1d) |  |  | 306d → 0d |  | resources none → Emmor Nile |
| 93 | **Define Information Needs (What do we need to gather?)** | 2005-03-15 → 2005-03-16 (+1d) | 2005-03-15 → 2005-03-16 (+1d) |  |  | 317d → 11d |  |  |
| 94 | Set objectives for work plan | 2005-03-15 → 2005-03-16 (+1d) | 2005-03-15 → 2005-03-16 (+1d) |  |  | 317d → 11d |  |  |
| 95 | Define ground rules for sub team | 2005-03-15 → 2005-03-16 (+1d) | 2005-03-15 → 2005-03-16 (+1d) |  |  | 317d → 11d |  |  |
| 96 | Define common ground with other sub teams | 2005-03-15 → 2005-03-16 (+1d) | 2005-03-15 → 2005-03-16 (+1d) |  |  | 317d → 11d |  |  |
| 97 | **Collect Information** | 2005-03-15 → 2005-03-16 (+1d) | 2005-03-15 → 2005-03-16 (+1d) |  |  | 312d → 6d |  |  |
| 98 | Collect existing naming and filing conventions from GIST's attached to IMT's | 2005-03-15 → 2005-03-16 (+1d) | 2005-03-15 → 2005-03-16 (+1d) |  |  | 312d → 6d |  |  |
| 99 | **Conduct Analysis** | 2005-03-16 → 2005-03-17 (+1d) | 2005-03-17 → 2005-03-18 (+1d) |  |  | 312d → 6d |  |  |
| 100 | Review strengths & weaknesses of existing methodologies | 2005-03-16 → 2005-03-17 (+1d) | 2005-03-16 → 2005-03-17 (+1d) |  |  | 312d → 6d |  |  |
| 101 | Resolve overlap and conflicts | 2005-03-17 → 2005-03-18 (+1d) | 2005-03-17 → 2005-03-18 (+1d) |  |  | 312d → 6d |  |  |
| 102 | **Develop Preliminary Requirements Specifications** | 2005-03-18 → 2005-03-21 (+3d) | 2005-03-21 → 2005-03-22 (+1d) |  |  | 312d → 6d |  |  |
| 103 | Draft naming convention guidelines | 2005-03-18 → 2005-03-21 (+3d) | 2005-03-18 → 2005-03-21 (+3d) |  |  | 312d → 6d |  |  |
| 104 | Draft directory structure guidelines | 2005-03-21 → 2005-03-22 (+1d) | 2005-03-21 → 2005-03-22 (+1d) |  |  | 312d → 6d |  |  |
| 105 | **Requirements Review and Validation** | 2005-03-22 → 2005-03-23 (+1d) | 2005-03-22 → 2005-03-23 (+1d) |  |  | 312d → 6d |  |  |
| 106 | Post draft guidelines for inter team review | 2005-03-22 → 2005-03-23 (+1d) | 2005-03-22 → 2005-03-23 (+1d) |  |  | 312d → 6d |  |  |
| 107 | Edit draft guidelines based on input | 2005-03-22 → 2005-03-23 (+1d) | 2005-03-22 → 2005-03-23 (+1d) |  |  | 312d → 6d |  |  |
| 108 | Post draft guidelines for external review | 2005-03-22 → 2005-03-23 (+1d) | 2005-03-22 → 2005-03-23 (+1d) |  |  | 312d → 6d |  |  |
| 109 | Edit draft guidelines based on input | 2005-03-22 → 2005-03-23 (+1d) | 2005-03-22 → 2005-03-23 (+1d) |  |  | 312d → 6d |  |  |
| 110 | **Prepare Sample Documents** | 2005-03-15 → 2005-03-16 (+1d) | 2005-03-15 → 2005-03-16 (+1d) |  |  | 317d → 11d |  |  |
| 111 | Prepare Naming conventions | 2005-03-15 → 2005-03-16 (+1d) | 2005-03-15 → 2005-03-16 (+1d) |  |  | 317d → 11d |  |  |
| 112 | Develop Directory structure | 2005-03-15 → 2005-03-16 (+1d) | 2005-03-15 → 2005-03-16 (+1d) |  |  | 317d → 11d |  |  |
| 113 | Prepare Methods of work | 2005-03-15 → 2005-03-16 (+1d) | 2005-03-15 → 2005-03-16 (+1d) |  |  | 317d → 11d |  |  |
| 114 | **Sample Documents Review and Validation** | 2005-03-15 → 2005-03-16 (+1d) | 2005-03-30 → 2005-03-31 (+1d) |  |  | 306d → 0d |  |  |
| 115 | Post sample documents for inter team review | 2005-03-15 → 2005-03-16 (+1d) | 2005-03-15 → 2005-03-16 (+1d) |  |  | 317d → 11d |  |  |
| 116 | Edit sample documents based on input | 2005-03-15 → 2005-03-16 (+1d) | 2005-03-15 → 2005-03-16 (+1d) |  |  | 317d → 11d |  |  |
| 117 | Post sample documents for external review | 2005-03-15 → 2005-03-16 (+1d) | 2005-03-21 → 2005-03-22 (+1d) |  |  | 313d → 7d |  |  |
| 118 | Edit sample documents based on input | 2005-03-15 → 2005-03-16 (+1d) | 2005-03-30 → 2005-03-31 (+1d) |  |  | 306d → 0d |  |  |
| 119 | **Incident GIS Standard Product Definitions Requirements** | 2005-03-15 → 2005-02-09 A (-34d) | 2005-03-24 → 2005-05-11 (+48d) | 8d? → 65d? |  | 310d → -29d |  | resources none → Karen Folger |
| 142 | Develop Standard Products Matrix to compare many versions of standard products. (GIST Draft Taskbook/GIST Course Workbook/PNWCG Product Objectives) | 2005-03-15 → 2005-02-09 A (-34d) | 2005-03-15 → 2005-02-09 A (-34d) | 1d? → 0d? | 0% → 100% | 314d → none |  | baseline start 2004-12-31 → none; baseline finish 2004-12-31 → none |
| 143 | Acquire DPRO Standards and incorporate into above matrix. | 2005-03-16 → 2005-03-01 A (-15d) | 2005-03-16 → 2005-03-01 A (-15d) | 1d? → 0d? | 0% → 100% | 314d → none | 142 → none | baseline start 2005-01-03 → none; baseline finish 2005-01-03 → none |
| 147 | **Conduct Analysis** | 2005-03-18 → 2005-03-17 (-1d) | 2005-03-21 → 2005-04-22 (+32d) | 2d? → 27d? |  | 310d → -29d | Collect examples of standard products. → 141 | baseline start 2005-01-11 → none; baseline finish 2005-01-12 → none |
| 158 | Find a storage location for GSTOP group review (NIFC site?) | 2005-03-23 → 2005-04-25 (+33d) | 2005-03-23 → 2005-04-25 (+33d) |  |  | 310d → -29d | Provide a package of products definitions and samples for group review (GIST/SITL review?) → none | baseline start 2005-01-14 → none; baseline finish 2005-01-14 → none |
| 176 | Find a permanent storage location for this package? National clearinghouse? | 2005-03-24 → 2005-05-10 (+47d) | 2005-03-24 → 2005-05-10 (+47d) |  |  | 310d → -28d |  | baseline start 2005-01-17 → none; baseline finish 2005-01-17 → none |
| 178 | **Incident GIST Minimum Qualifications Requirements** | 2005-03-15 → 2005-03-16 A (+1d) | 2005-03-15 → 2005-04-25 (+41d) | 1d? → 28.5d? | 0% → 3% | 317d → -16.5d |  | resources none → Victoria Smith |
| 179 | **Establish Min GIST qualifications/GIS expectations Sub-Team business practices** | 2005-03-15 → 2005-03-16 (+1d) | 2005-03-15 → 2005-04-01 (+17d) | 1d? → 13d? |  | 317d → -1d |  |  |
| 180 | **Develop a GIST Qual/GIST Min Expec Sub-team Communication Plan** | 2005-03-15 → 2005-03-16 (+1d) | 2005-03-15 → 2005-04-01 (+17d) | 1d? → 13d? |  | 317d → -1d |  | was named Develop a Symbol Sub-team Communication Plan; resources none → GIST Qual/GIS Min Expec Subteam |
| 181 | Define ground-rules for Sub-Team (internal) communication | 2005-03-15 → 2005-03-16 (+1d) | 2005-03-15 → 2005-04-01 (+17d) | 1d? → 13d? |  | 317d → -1d |  | constraint none → finish no earlier than 2005-04-01 |
| 182 | Define ground-rules for communication between the GIST Qual/GIST Min Expec Sub-Team and other GSTOP Sub-Teams | 2005-03-15 → 2005-03-16 (+1d) | 2005-03-15 → 2005-04-01 (+17d) | 1d? → 13d? |  | 317d → -1d |  | was named Define ground-rules for communication between the Min GIST qualifications/GIS expectations Sub-Team and other GSTOP Sub-Teams; constraint none → finish no earlier than 2005-04-01 |
| 183 | Define ground rules for communication between the Sub-Team and entities outside of the GSTOP Project | 2005-03-15 → 2005-03-16 (+1d) | 2005-03-15 → 2005-04-01 (+17d) | 1d? → 13d? |  | 317d → -1d |  | constraint none → finish no earlier than 2005-04-01 |
| 184 | Establish a process and schedule for Sub-Team (internal) progress report updates | 2005-03-15 → 2005-03-16 (+1d) | 2005-03-15 → 2005-04-01 (+17d) | 1d? → 13d? |  | 317d → -1d |  | constraint none → finish no earlier than 2005-04-01 |
| 185 | Establish a process and schedule for Sub-Team progress report updates to the GSTOP Team | 2005-03-15 → 2005-03-16 (+1d) | 2005-03-15 → 2005-04-01 (+17d) | 1d? → 13d? |  | 317d → -1d |  | constraint none → finish no earlier than 2005-04-01 |
| 186 | **Establish Review Processes** | 2005-03-15 → 2005-03-16 (+1d) | 2005-03-15 → 2005-04-01 (+17d) | 1d? → 13d? |  | 317d → -1d |  | resources none → GIST Qual/GIS Min Expec Subteam |
| 187 | Establish a process for Sub-Team (internal) review of potential minimum GIST qualifications/GIS expectations | 2005-03-15 → 2005-03-16 (+1d) | 2005-03-15 → 2005-04-01 (+17d) | 1d? → 13d? |  | 317d → -1d |  | constraint none → finish no earlier than 2005-04-01 |
| 188 | Establish a process for Sub-Team (internal) review of the draft minimum GIST qualifications/GIS expectations | 2005-03-15 → 2005-03-16 (+1d) | 2005-03-15 → 2005-04-01 (+17d) | 1d? → 13d? |  | 317d → -1d |  | constraint none → finish no earlier than 2005-04-01 |
| 189 | Establish a process for peer reviews | 2005-03-15 → 2005-03-16 (+1d) | 2005-03-15 → 2005-04-01 (+17d) | 1d? → 13d? |  | 317d → -1d |  | constraint none → finish no earlier than 2005-04-01 |
| 190 | Establish a process for periodic GSTOP Team reviews | 2005-03-15 → 2005-03-16 (+1d) | 2005-03-15 → 2005-04-01 (+17d) | 1d? → 13d? |  | 317d → -1d |  | constraint none → finish no earlier than 2005-04-01 |
| 191 | Establish a process for reviewing the final report | 2005-03-15 → 2005-03-16 (+1d) | 2005-03-15 → 2005-04-01 (+17d) | 1d? → 13d? |  | 317d → -1d |  | constraint none → finish no earlier than 2005-04-01 |
| 192 | **Establish Change Processes** | 2005-03-15 → 2005-03-16 (+1d) | 2005-03-15 → 2005-04-01 (+17d) | 1d? → 13d? |  | 317d → -1d |  | was named Establish Change processes; resources none → GIST Qual/GIS Min Expec Subteam |
| 193 | Establish a process for additions/deletions of potential minimum GIST qualifications/GIS expectations mid-stream through the project | 2005-03-15 → 2005-03-16 (+1d) | 2005-03-15 → 2005-04-01 (+17d) | 1d? → 13d? |  | 317d → -1d |  | constraint none → finish no earlier than 2005-04-01 |
| 194 | Establish a change process for the additions/deletion of minimum GIST qualifications/GIS expectations after the final recommendation has been submitted and prior to completion of the GSTOP project | 2005-03-15 → 2005-03-16 (+1d) | 2005-03-15 → 2005-04-01 (+17d) | 1d? → 13d? |  | 317d → -1d |  | constraint none → finish no earlier than 2005-04-01 |
| 195 | Establish a change process for the additions/deletion of minimum GIST qualifications/GIS expectations after the completion of the GSTOP project | 2005-03-15 → 2005-03-16 (+1d) | 2005-03-15 → 2005-04-01 (+17d) | 1d? → 13d? |  | 317d → -1d |  | constraint none → finish no earlier than 2005-04-01 |
| 196 | **Establish evaluation methods for minimum GIST qualifications/GIS expectations** | 2005-03-15 → 2005-03-16 (+1d) | 2005-03-15 → 2005-03-16 (+1d) |  |  | 317d → 11d |  |  |
| 197 | Define method for evaluating minimum GIST qualifications/GIS expectations | 2005-03-15 → 2005-03-16 (+1d) | 2005-03-15 → 2005-03-16 (+1d) |  |  | 317d → 11d |  |  |
| 198 | Conduct a final review of evaluation methods | 2005-03-15 → 2005-03-16 (+1d) | 2005-03-15 → 2005-03-16 (+1d) |  |  | 317d → 11d |  |  |

| ID | Task | Start | Finish | Duration | Complete | Total float | Predecessors | Other |
| --- | --- | --- | --- | --- | --- | --- | --- | --- |
| 199 | **Define criteria for the acceptance of minimum GIST qualifications/GIS expectations** | 2005-03-15 → 2005-03-16 (+1d) | 2005-03-15 → 2005-03-16 (+1d) |  |  | 317d → 11d |  |  |
| 200 | Develop acceptance criteria for minimum GIST qualifications/GIS expectations | 2005-03-15 → 2005-03-16 (+1d) | 2005-03-15 → 2005-03-16 (+1d) |  |  | 317d → 11d |  |  |
| 201 | Conduct a final review of selection criteria | 2005-03-15 → 2005-03-16 (+1d) | 2005-03-15 → 2005-03-16 (+1d) |  |  | 317d → 11d |  |  |
| 202 | **Collect Information on minimum GIST qualifications and minimum GIS expectations on an incident** | 2005-03-15 → 2005-03-16 A (+1d) | 2005-03-15 → 2005-03-24 (+9d) | 1d? → 6.5d? | 0% → 71% | 317d → -0.5d |  |  |
| 203 | Gather documents and references (including white papers, memos, After Action Reviews, agency guidelines) | 2005-03-15 → 2005-03-16 A (+1d) | 2005-03-15 → 2005-03-23 A (+8d) | 1d? → 6d? | 0% → 100% | 317d → none |  | was named Gather documents and references (including white papers, memos, After Action Reviews); resources GTAG; Firescope; NWCG Agency Guidelines → GTAG; Firescope; NWCG Member Agencies |
| 205 | Scan or translate paper documents to electronic format | 2005-03-15 → 2005-03-16 (+1d) | 2005-03-15 → 2005-03-16 (+1d) |  |  | 317d → -11d |  | resources books; media (including internet and magazines) → none |
| 206 | Research current GIST/GIS standards | 2005-03-15 → 2005-03-16 (+1d) | 2005-03-15 → 2005-03-16 (+1d) |  |  | 317d → -11d |  | resources FEMA; NWCG Agency specific guidelines; GACC guidelines → FEMA; GACC guidelines; NWCG Agency |
| 207 | **Develop a list of GIST qualifications to be evaluated for acceptance as draft minimum standards** | 2005-03-15 → 2005-03-24 (+9d) | 2005-03-15 → 2005-03-29 (+14d) | 1d? → 3d? |  | 317d → -16.5d | none → 202 |  |
| 208 | Compare the current GIST standards | 2005-03-15 → 2005-03-24 (+9d) | 2005-03-15 → 2005-03-25 (+10d) |  |  | 317d → -16.5d |  | resources none → Elise Browne |
| 209 | Compile the GIST qualifications into a single list of potential minimum GIST qualifications | 2005-03-15 → 2005-03-25 (+10d) | 2005-03-15 → 2005-03-28 (+13d) |  |  | 317d → -16.5d | none → 208 |  |
| 210 | Compile a list of GIST qualifications which are deemed to be beyond the minimum for future reference | 2005-03-15 → 2005-03-28 (+13d) | 2005-03-15 → 2005-03-29 (+14d) |  |  | 317d → -16.5d | none → 209 |  |
| 211 | **Develop a list of GIS expectations to be evaluated for acceptance as draft minimum standards** | 2005-03-15 → 2005-03-24 (+9d) | 2005-03-15 → 2005-03-29 (+14d) | 1d? → 3d? |  | 317d → -16.5d | none → 202 |  |
| 212 | Compare any current GIS expectation standards | 2005-03-15 → 2005-03-24 (+9d) | 2005-03-15 → 2005-03-25 (+10d) |  |  | 317d → -16.5d |  |  |
| 213 | Compile the GIS expectations into a list of potential minimum GIS expectations on an incident | 2005-03-15 → 2005-03-25 (+10d) | 2005-03-15 → 2005-03-28 (+13d) |  |  | 317d → -16.5d | none → 212 |  |
| 214 | Compile a list of GIS qualifications which are deemed to be beyond the minimum for future reference | 2005-03-15 → 2005-03-28 (+13d) | 2005-03-15 → 2005-03-29 (+14d) |  |  | 317d → -16.5d | none → 213 | was named Compile a list of GIST qualifications which are deemed to be beyond the minimum for future reference |
| 215 | **Determine the draft standard minimum GIST qualifications** | 2005-03-15 → 2005-03-29 (+14d) | 2005-03-15 → 2005-04-01 (+17d) | 1d? → 3d? |  | 317d → -16.5d | none → 207 |  |
| 216 | Evaluate each potential minimum GIST qualification using the evaluation methods in 2.4.2 | 2005-03-15 → 2005-03-29 (+14d) | 2005-03-15 → 2005-03-30 (+15d) |  |  | 317d → -16.5d |  |  |
| 217 | Select the minimum GIST qualifications | 2005-03-15 → 2005-03-30 (+15d) | 2005-03-15 → 2005-03-31 (+16d) |  |  | 317d → -16.5d | none → 216 |  |
| 218 | Conduct a completeness review of the draft minimum GIST qualifications | 2005-03-15 → 2005-03-31 (+16d) | 2005-03-15 → 2005-04-01 (+17d) |  |  | 317d → -16.5d | none → 217 |  |
| 219 | **Determine the draft standard minimum GIS expectations** | 2005-03-15 → 2005-03-29 (+14d) | 2005-03-15 → 2005-04-01 (+17d) | 1d? → 3d? |  | 317d → -16.5d | none → 211 |  |
| 220 | Evaluate each potential minimum GIS expectation using the evaluation methods in 2.4.2 | 2005-03-15 → 2005-03-29 (+14d) | 2005-03-15 → 2005-03-30 (+15d) |  |  | 317d → -16.5d |  |  |
| 221 | Select the minimum GIS expectations | 2005-03-15 → 2005-03-30 (+15d) | 2005-03-15 → 2005-03-31 (+16d) |  |  | 317d → -16.5d | none → 220 |  |
| 222 | Conduct a completeness review of the draft minimum GIS expectations | 2005-03-15 → 2005-03-31 (+16d) | 2005-03-15 → 2005-04-01 (+17d) |  |  | 317d → -16.5d | none → 221 |  |
| 223 | **Conduct internal review of draft standard minimum GIST qualifications and GIS expectations** | 2005-03-15 → 2005-04-01 (+17d) | 2005-03-15 → 2005-04-11 (+27d) | 1d? → 6d? |  | 317d → -16.5d | none → 215, 219 |  |
| 224 | Prepare draft standard minimum GIST qualifications and GIS expectations, including acceptance criteria | 2005-03-15 → 2005-04-01 (+17d) | 2005-03-15 → 2005-04-04 (+20d) |  |  | 317d → -16.5d |  |  |
| 225 | Post draft standard to DisasterHelp website and notify GSTOP team for group review | 2005-03-15 → 2005-04-04 (+20d) | 2005-03-15 → 2005-04-05 (+21d) |  |  | 317d → -16.5d | none → 224 |  |
| 226 | Provide data location and review process to internal group | 2005-03-15 → 2005-04-05 (+21d) | 2005-03-15 → 2005-04-06 (+22d) |  |  | 317d → -16.5d | none → 225 |  |
| 227 | Review feedback of initial peer review | 2005-03-15 → 2005-04-06 (+22d) | 2005-03-15 → 2005-04-07 (+23d) |  |  | 317d → -16.5d | none → 226 |  |
| 228 | Identify required changes to draft standard based on the initial peer review feedback | 2005-03-15 → 2005-04-07 (+23d) | 2005-03-15 → 2005-04-08 (+24d) |  |  | 317d → -16.5d | none → 227 |  |
| 229 | Make required changes, as identified, to draft standard | 2005-03-15 → 2005-04-08 (+24d) | 2005-03-15 → 2005-04-11 (+27d) |  |  | 317d → -16.5d | none → 228 |  |
| 230 | **Conduct final peer review of the draft standard minimum GIST qualifications and GIS expectations** | 2005-03-15 → 2005-04-11 (+27d) | 2005-03-15 → 2005-04-20 (+36d) | 1d? → 7d? |  | 317d → -16.5d | none → 223 | resources Victoria Smith → GIST Qual/GIS Min Expec Subteam |
| 231 | Prepare survey or questionnaire to accompany draft standards for final peer review. | 2005-03-15 → 2005-04-11 (+27d) | 2005-03-15 → 2005-04-12 (+28d) |  |  | 317d → -16.5d |  |  |
| 232 | Prepare draft standard minimum GIST Qualification/GIST expectations for final peer review, including the survey or questionnaire | 2005-03-15 → 2005-04-12 (+28d) | 2005-03-15 → 2005-04-13 (+29d) |  |  | 317d → -16.5d | none → 231 |  |
| 233 | Submit the draft expectations to the 5 federal fire management agencies and State agencies via the NWCG Geospatial Task Group (GTG); and to the HSA (FEMA), FAA, DOD, and GSTOP Team for peer review. | 2005-03-15 → 2005-04-13 (+29d) | 2005-03-15 → 2005-04-14 (+30d) |  |  | 317d → -16.5d | none → 232 | resources none → GTG |
| 234 | Review feedback of the final peer review, including questionnaire or survey | 2005-03-15 → 2005-04-14 (+30d) | 2005-03-15 → 2005-04-15 (+31d) |  |  | 317d → -16.5d | none → 233 |  |
| 235 | Identify required changes to draft standard minimum GIST qualifications/GIS expectations based on the final peer review feedback | 2005-03-15 → 2005-04-15 (+31d) | 2005-03-15 → 2005-04-18 (+34d) |  |  | 317d → -16.5d | none → 234 |  |
| 236 | Make required changes, as identified, to draft minimum GIST qualifications/GIS expectations symbols | 2005-03-15 → 2005-04-18 (+34d) | 2005-03-15 → 2005-04-19 (+35d) |  |  | 317d → -16.5d | none → 235 |  |
| 237 | Ratify the final draft standard minimum GIST qualifications/GIS expectations | 2005-03-15 → 2005-04-19 (+35d) | 2005-03-15 → 2005-04-20 (+36d) |  |  | 317d → -16.5d | none → 236 | resources none → GIST Qual/GIS Min Expec Subteam |
| 238 | **Finalize recommendation of standard Minimum GIST Qualifications and Minimum GIS Expectations on an Incident** | 2005-03-15 → 2005-04-20 (+36d) | 2005-03-15 → 2005-04-25 (+41d) | 1d? → 3d? |  | 317d → -16.5d | none → 230 |  |
| 239 | Create a report recommending the adoption of the draft minimum GIST Qualifications/GIS Expectations | 2005-03-15 → 2005-04-20 (+36d) | 2005-03-15 → 2005-04-21 (+37d) |  |  | 317d → -16.5d |  |  |
| 240 | Conduct a review of the report for completeness, accuracy, language, and grammar | 2005-03-15 → 2005-04-21 (+37d) | 2005-03-15 → 2005-04-22 (+38d) |  |  | 317d → -16.5d | none → 239 |  |
| 241 | Submit the report to GSTOP-PM | 2005-03-15 → 2005-04-22 (+38d) | 2005-03-15 → 2005-04-25 (+41d) |  |  | 317d → -16.5d | none → 240 |  |
| 242 | **Incident GIS Minimum Essential Datasets Requirements** | 2005-03-15 → 2005-02-10 A (-33d) | 2005-03-31 → 2005-04-12 (+12d) | 13d? → 44d? | 0% → 5% | 305d → -5d |  | resources none → John Guthrie |
| 243 | **Establish MED Sub-Team business practices** | 2005-03-15 → 2005-02-10 A (-33d) | 2005-03-15 → 2005-03-16 (+1d) | 1d? → 25d? |  | 317d → 11d |  |  |
| 244 | **Develop a MED Sub-team Communication Plan** | 2005-03-15 → 2005-02-10 A (-33d) | 2005-03-31 → 2005-03-16 (-15d) | 13d? → 25d? |  | 305d → 11d |  |  |
| 245 | **Define ground-rules for Sub-Team (internal) communication** | 2005-03-15 → 2005-02-10 A (-33d) | 2005-03-23 → 2005-02-10 (-41d) | 7d? → 1d? |  | 305d → 12d |  |  |
| 246 | Define ground-rules for communication between the MED Sub-Team and other GSTOP Sub-Teams | 2005-03-15 → 2005-02-10 A (-33d) | 2005-03-15 → 2005-02-10 (-33d) |  |  | 305d → -1d |  |  |
| 247 | Define ground rules for communication between the Sub-Team and entities outside of the GSTOP Project | 2005-03-16 → 2005-02-10 A (-34d) | 2005-03-16 → 2005-02-10 (-34d) |  |  | 305d → -1d |  |  |
| 248 | Establish a process and schedule for Sub-Team (internal) progress report updates | 2005-03-17 → 2005-02-10 A (-35d) | 2005-03-17 → 2005-02-10 (-35d) |  |  | 305d → -1d |  |  |
| 249 | Establish a process and schedule for Sub-Team progress report updates to the GSTOP Team | 2005-03-18 → 2005-02-10 A (-36d) | 2005-03-18 → 2005-02-10 (-36d) |  |  | 305d → -1d |  |  |
| 250 | Establish Review Processes | 2005-03-21 → 2005-02-10 A (-39d) | 2005-03-21 → 2005-02-10 (-39d) |  |  | 305d → -1d |  |  |
| 251 | Establish a process for Sub-Team (internal) review of potential MEDs | 2005-03-22 → 2005-02-10 A (-40d) | 2005-03-22 → 2005-02-10 (-40d) |  |  | 305d → -1d |  |  |
| 252 | Establish a process for Sub-Team (internal) review of the draft standard MEDs | 2005-03-23 → 2005-02-10 A (-41d) | 2005-03-23 → 2005-02-10 (-41d) |  |  | 305d → 12d |  |  |
| 253 | **Establish a process for peer reviews** | 2005-03-24 → 2005-03-01 A (-23d) | 2005-03-25 → 2005-03-01 (-24d) | 2d? → 1d? |  | 305d → 0d |  |  |
| 254 | Establish a process for periodic GSTOP Team reviews | 2005-03-24 → 2005-03-01 A (-23d) | 2005-03-24 → 2005-03-01 (-23d) |  |  | 305d → -1d |  |  |
| 255 | Establish a process for reviewing the final report | 2005-03-25 → 2005-03-01 A (-24d) | 2005-03-25 → 2005-03-01 (-24d) |  |  | 305d → -1d |  |  |
| 256 | **Establish Change processes** | 2005-03-28 → 2005-03-01 A (-27d) | 2005-03-29 → 2005-03-16 (-13d) | 2d? → 12d? |  | 305d → 11d |  |  |
| 257 | Establish a process for additions/deletions of potential MEDs mid-stream through the Project | 2005-03-28 → 2005-03-01 A (-27d) | 2005-03-28 → 2005-03-01 (-27d) |  |  | 305d → -1d |  |  |
| 258 | Establish a change process for the additions/deletion of standard MEDs after the final recommendation has been submitted | 2005-03-29 → 2005-03-01 A (-28d) | 2005-03-29 → 2005-03-01 (-28d) |  |  | 305d → 21d |  |  |
| 259 | Establish a change process for the additions/deletion of standard MEDs after the final recommendation has been approved through the GSTOP Project | 2005-03-30 → 2005-03-16 (-14d) | 2005-03-30 → 2005-03-16 (-14d) |  |  | 305d → 11d |  |  |
| 261 | Define method for evaluating fill MEDs | 2005-03-15 → 2005-03-18 A (+3d) | 2005-03-16 → 2005-04-05 (+20d) | 2d? → 13d? |  | 316d → -3d |  |  |
| 264 | Define criteria for the acceptance of MEDs as standards | 2005-03-15 → 2005-03-17 A (+2d) | 2005-03-15 → 2005-03-17 (+2d) |  | 0% → 40% | 317d → 10d | none → 263 |  |
| 268 | Conduct a final review of selection criteria | 2005-03-15 → 2005-03-16 (+1d) | 2005-03-15 → 2005-03-16 (+1d) |  |  | 317d → 11d |  |  |
| 269 | **Develop a list of MEDs to be evaluated for acceptance as draft standards** | 2005-03-15 → 2005-03-01 A (-14d) | 2005-03-15 → 2005-04-04 (+20d) | 1d? → 25d? |  | 317d → -1d |  | resources none → MED Subteam |
| 270 | Collect Fire mapping MEDs from the 5 federal fire management agencies (FS, BLM, NPS, FWS, BIA), state agencies, and USGS via the NWCG Geospatial Task Group (GTG) | 2005-03-15 → 2005-03-01 A (-14d) | 2005-03-15 → 2005-04-01 (+17d) | 1d? → 24d? |  | 317d → 0d |  | constraint none → finish no earlier than 2005-04-01 |
| 271 | Collect Fire mapping MEDs from DHS (FEMA), FAA, and DOD | 2005-03-15 → 2005-03-23 A (+8d) | 2005-03-15 → 2005-03-23 (+8d) |  |  | 316d → -1d |  | resources none → Eric |
| 272 | Document potential sources for additional fire mapping MEDs | 2005-03-15 → 2005-03-16 (+1d) | 2005-03-15 → 2005-03-16 (+1d) |  |  | 316d → 5d |  |  |
| 273 | Compile MEDs into a single potential MED set | 2005-03-16 → 2005-04-04 (+19d) | 2005-03-16 → 2005-04-04 (+19d) |  |  | 316d → -8d | 272 → 270, 271 |  |
| 274 | **Determine the draft standard Raster MEDs** | 2005-03-15 → 2005-04-05 (+21d) | 2005-03-15 → 2005-04-07 (+23d) | 1d? → 3d? |  | 317d → -8d | none → 269 | resources none → MED Subteam |
| 275 | Evaluate each potential marker MED against the marker MED selection criteria | 2005-03-15 → 2005-04-05 (+21d) | 2005-03-15 → 2005-04-05 (+21d) |  |  | 317d → -8d |  |  |

| ID | Task | Start | Finish | Duration | Total float | Predecessors | Other |
| --- | --- | --- | --- | --- | --- | --- | --- |
| 276 | Sub-Team selection of the draft standard marker MEDs | 2005-03-15 → 2005-04-06 (+22d) | 2005-03-15 → 2005-04-06 (+22d) |  | 317d → -8d | none → 275 |  |
| 277 | Conduct a Sub-team completeness review of the draft standard marker MEDs | 2005-03-15 → 2005-04-07 (+23d) | 2005-03-15 → 2005-04-07 (+23d) |  | 317d → -8d | none → 276 |  |
| 278 | **Determine the draft standard Vector MEDs** | 2005-03-15 → 2005-03-16 (+1d) | 2005-03-15 → 2005-03-18 (+3d) | 1d? → 3d? | 317d → 6d |  | resources none → MED Subteam |
| 279 | Evaluate each potential line MED against the line MED selection criteria | 2005-03-15 → 2005-03-16 (+1d) | 2005-03-15 → 2005-03-16 (+1d) |  | 317d → 6d |  |  |
| 280 | Sub-Team selection of the draft standard line MEDs | 2005-03-15 → 2005-03-17 (+2d) | 2005-03-15 → 2005-03-17 (+2d) |  | 317d → 6d | none → 279 |  |
| 281 | Conduct a Sub-team completeness review of the draft standard line MEDs | 2005-03-15 → 2005-03-18 (+3d) | 2005-03-15 → 2005-03-18 (+3d) |  | 317d → 6d | none → 280 |  |
| 286 | **Conduct a Sub-team completeness review of the draft standard fill MEDs** | 2005-03-15 → 2005-03-16 (+1d) | 2005-03-15 → 2005-03-16 (+1d) |  | 317d → 11d |  |  |
| 287 | Conduct initial peer review of the draft standard marker, line, and fill MEDs | 2005-03-15 → 2005-03-16 (+1d) | 2005-03-15 → 2005-03-16 (+1d) |  | 317d → 11d |  |  |
| 288 | Prepare draft standard MEDs for initial peer review | 2005-03-15 → 2005-03-16 (+1d) | 2005-03-15 → 2005-03-16 (+1d) |  | 317d → 11d |  |  |
| 289 | Submit the draft standard MEDs to the 5 federal fire management agencies, State agencies, and USGS via the NWCG Geospatial Task Group (GTG); and to DHS (FEMA), FAA, DOD, and GSTOP Team for peer review | 2005-03-15 → 2005-03-16 (+1d) | 2005-03-15 → 2005-03-16 (+1d) |  | 318d → 12d |  |  |
| 290 | Review feedback of initial peer review | 2005-03-15 → 2005-03-16 (+1d) | 2005-03-15 → 2005-03-16 (+1d) |  | 317d → 11d |  |  |
| 291 | Identify required changes to draft standard MEDs based on the initial peer review feedback | 2005-03-15 → 2005-03-16 (+1d) | 2005-03-15 → 2005-03-16 (+1d) |  | 317d → 11d |  |  |
| 292 | Make required changes, as identified, to draft standard MEDs | 2005-03-15 → 2005-03-16 (+1d) | 2005-03-15 → 2005-03-16 (+1d) |  | 317d → 11d |  |  |
| 293 | **Conduct final peer review of the draft standard marker, line, and fill MEDs** | 2005-03-15 → 2005-03-16 (+1d) | 2005-03-15 → 2005-03-16 (+1d) |  | 317d → 11d |  |  |
| 294 | Prepare draft standard MEDs for final peer review | 2005-03-15 → 2005-03-16 (+1d) | 2005-03-15 → 2005-03-16 (+1d) |  | 317d → 11d |  | resources Victoria; ; deb epps → Victoria Smith; Deb Epps |
| 295 | Submit the draft standard MEDs to the 5 federal fire management agencies and State agencies via the NWCG Geospatial Task Group (GTG); and to the HSA (FEMA), FAA, DOD, and GSTOP Team for peer review | 2005-03-15 → 2005-03-16 (+1d) | 2005-03-15 → 2005-03-16 (+1d) |  | 317d → 11d |  | resources subteam(s) → GSTOP Subteam(s) |
| 296 | Review feedback of the final peer review | 2005-03-15 → 2005-03-16 (+1d) | 2005-03-15 → 2005-03-16 (+1d) |  | 317d → 11d |  | resources subteam(s) → GSTOP Subteam(s) |
| 297 | Identify required changes to draft standard MEDs based on the final peer review feedback | 2005-03-15 → 2005-03-16 (+1d) | 2005-03-15 → 2005-03-16 (+1d) |  | 317d → 11d |  | resources subteam(s) → GSTOP Subteam(s) |
| 298 | Make required changes, as identified, to draft standard MEDs | 2005-03-15 → 2005-03-16 (+1d) | 2005-03-15 → 2005-03-16 (+1d) |  | 317d → 11d |  | resources subteam(s) → GSTOP Subteam(s) |
| 299 | Ratification of the final draft standard MEDs by the Sub-Team | 2005-03-15 → 2005-03-16 (+1d) | 2005-03-15 → 2005-03-16 (+1d) |  | 317d → 11d |  |  |
| 300 | **Finalize recommendation of standard Fire Mapping MEDs** | 2005-03-15 → 2005-03-16 (+1d) | 2005-03-15 → 2005-03-16 (+1d) |  | 317d → 11d |  |  |
| 301 | Create a report recommending the adoption of the draft standard MEDs | 2005-03-15 → 2005-03-16 (+1d) | 2005-03-15 → 2005-03-16 (+1d) |  | 317d → 11d |  |  |
| 302 | Conduct a Sub-Team review of the report | 2005-03-15 → 2005-03-16 (+1d) | 2005-03-15 → 2005-03-16 (+1d) |  | 317d → 11d |  |  |
| 303 | Submit the report to GSTOP-PM | 2005-03-15 → 2005-03-16 (+1d) | 2005-03-15 → 2005-03-16 (+1d) |  | 317d → 11d |  |  |
| 305 | **Incident GIS Standard Data Sharing and Archiving Standards (02-08-2005)** | 2005-03-15 → 2005-03-16 (+1d) | 2005-03-15 → 2005-03-16 (+1d) |  | 317d → 11d |  | resources none → Sean Triplett |
| 306 | **Define Information Needs (What do we need to gather?)** | 2005-03-15 → 2005-03-16 (+1d) | 2005-03-15 → 2005-03-16 (+1d) |  | 317d → 11d |  |  |
| 307 | Compile existing archiving standards in use (e.g. data format, transfer mode) | 2005-03-15 → 2005-03-16 (+1d) | 2005-03-15 → 2005-03-16 (+1d) |  | 317d → 11d |  | resources none → Business Lead; GTG Standards Committee |
| 308 | Identify how archiving is done at present time by ICS, military, other incident responders, project-management | 2005-03-15 → 2005-03-16 (+1d) | 2005-03-15 → 2005-03-16 (+1d) | 1d? → 0.17d? | 317d → 11.83d |  | resources none → Internet Search; Military; etc.; survey GISTs; Plans Sections (Mary Kwart); Documents Sections |
| 309 | Gather NARA, Records Management requirements (review policies, lawsuits) e.g. physical location, acceptable media, supporting documentation | 2005-03-15 → 2005-03-16 (+1d) | 2005-03-15 → 2005-03-16 (+1d) | 1d? → 0.25d? | 317d → 11.75d |  | resources none → Business Lead; FGDC; NARA; NWCG Member Agencies |
| 310 | Determine the least common denominator (shapefile) or possibility of multiple formats | 2005-03-15 → 2005-03-16 (+1d) | 2005-03-15 → 2005-03-16 (+1d) |  | 317d → 11d |  |  |
| 311 | **Collect Information** | 2005-03-15 → 2005-03-16 (+1d) | 2005-03-15 → 2005-03-16 (+1d) |  | 317d → 11d |  |  |
| 312 | Conduct literature review | 2005-03-15 → 2005-03-16 (+1d) | 2005-03-15 → 2005-03-16 (+1d) |  | 317d → 11d |  | resources none → FGDC; GeoMAC; NPS I&M; NPS Focus; NARA |
| 313 | **Conduct Analysis** | 2005-03-15 → 2005-03-16 (+1d) | 2005-03-15 → 2005-03-16 (+1d) |  | 317d → 11d |  |  |
| 314 | Compile, Synthesize requirements | 2005-03-15 → 2005-03-16 (+1d) | 2005-03-15 → 2005-03-16 (+1d) |  | 317d → 11d |  |  |
| 315 | **Develop Preliminary Requirements Specifications** | 2005-03-15 → 2005-03-16 (+1d) | 2005-03-15 → 2005-03-16 (+1d) |  | 317d → 11d |  |  |
| 316 | Proposal of SOP | 2005-03-15 → 2005-03-16 (+1d) | 2005-03-15 → 2005-03-16 (+1d) |  | 317d → 11d |  | resources none → DataShareArcTrans Subteam |
| 317 | **Review and Validate Requirements** | 2005-03-15 → 2005-03-16 (+1d) | 2005-03-15 → 2005-03-16 (+1d) |  | 317d → 11d |  |  |
| 318 | Sub-Team Review of SOP | 2005-03-15 → 2005-03-16 (+1d) | 2005-03-15 → 2005-03-16 (+1d) |  | 317d → 11d |  | resources none → DataShareArcTrans Subteam |
| 319 | Revise, Edit Proposed SOP | 2005-03-15 → 2005-03-16 (+1d) | 2005-03-15 → 2005-03-16 (+1d) |  | 317d → 11d |  | resources none → DataShareArcTrans Subteam |
| 320 | Submit to Project Manager for Team Review | 2005-03-15 → 2005-03-16 (+1d) | 2005-03-15 → 2005-03-16 (+1d) |  | 317d → 11d |  |  |
| 321 | **Incident GIS Standard Documentation and Archiving** | 2005-03-15 → 2005-03-16 (+1d) | 2005-03-15 → 2005-03-23 (+8d) | 1d? → 6d? | 317d → 6d |  | resources none → Sean Triplett |
| 322 | **Define Information Needs (What do we need to gather?)** | 2005-03-15 → 2005-03-16 (+1d) | 2005-03-18 → 2005-03-16 (-2d) | 4d? → 1d? | 314d → 11d |  |  |
| 329 | Develop Preliminary Requirements Specifications | 2005-03-15 → 2005-03-18 (+3d) | 2005-03-15 → 2005-03-18 (+3d) |  | 317d → 6d | none → 328 | resources none → DataShareArcTrans Subteam |
| 330 | **Review and Validate Requirements** | 2005-03-24 → 2005-03-21 (-3d) | 2005-03-24 → 2005-03-23 (-1d) | 1d? → 3d? | 310d → 6d | 158 → 329 | baseline start 2005-01-17 → none; baseline finish 2005-01-17 → none |
| 331 | Sub-Team Review of SOP | 2005-03-15 → 2005-03-21 (+6d) | 2005-03-15 → 2005-03-21 (+6d) |  | 317d → 6d |  | resources none → DataShareArcTrans Subteam |
| 332 | Revise, Edit Proposed SOP | 2005-03-15 → 2005-03-22 (+7d) | 2005-03-15 → 2005-03-22 (+7d) |  | 317d → 6d | none → 331 | resources none → DataShareArcTrans Subteam |
| 333 | Submit to Project Manager for Team Review | 2005-03-15 → 2005-03-23 (+8d) | 2005-03-15 → 2005-03-23 (+8d) |  | 317d → 6d | none → 332 |  |
| 335 | **Incident GIS Transition Procedures** | 2005-03-15 → 2005-03-16 (+1d) | 2005-03-15 → 2005-03-28 (+13d) | 1d? → 9d? | 317d → 295d |  |  |
| 336 | **Define Information Needs (What do we need to gather?)** | 2005-03-15 → 2005-03-16 (+1d) | 2005-03-15 → 2005-03-18 (+3d) | 1d? → 3d? | 317d → 295d |  |  |
| 337 | Determine "universe" of transitions: (team to team); (team to unit); (team to archive) | 2005-03-15 → 2005-03-16 (+1d) | 2005-03-15 → 2005-03-16 (+1d) |  | 317d → 295d |  | resources none → Business Lead; FGDC; NARA; agency guidance |
| 338 | Compile procedures currently in use | 2005-03-15 → 2005-03-17 (+2d) | 2005-03-15 → 2005-03-17 (+2d) |  | 317d → 295d | none → 337 | resources none → Other "team" environs (e.g. military); survey? Mary Kwart? |
| 339 | Identify if existing procedures in use "somewhere out there" may be acceptible (e.g. NARA) | 2005-03-15 → 2005-03-18 (+3d) | 2005-03-15 → 2005-03-18 (+3d) |  | 317d → 295d | none → 338 | resources none → DataShareArcTrans Subteam |
| 341 | Identify test procedures for documentation and archiving | 2005-03-15 → 2005-03-21 (+6d) | 2005-03-15 → 2005-03-21 (+6d) |  | 317d → 295d |  | resources none → DataShareArcTrans Subteam |
| 344 | **Review and Validate Requirements** | 2005-03-15 → 2005-03-24 (+9d) | 2005-03-15 → 2005-03-28 (+13d) | 1d? → 3d? | 317d → 295d | none → 343 |  |
| 350 | **Draft Incident GIS SOPs (>>chk for somewhat Incorporated into WBS 1)** |  | 2004-10-20 → 2005-05-13 (+205d) | 1d? → 148d? | 422d → 147.5d |  | was named Draft Incident GIS SOPs (Somewhat Incorporated into WBS 2) |
| 359 | Review and Validate draft SOP’s for completeness | 2005-03-15 → 2004-10-20 (-146d) | 2005-03-15 → 2004-10-20 (-146d) |  | 317.5d → 422.5d |  | resources GSTOP Team; GTG; GTAG; some other reviewers → GSTOP Team; GTG; GTAG; Reviewers |
| 360 | Review and Validate draft SOP’s for GIS content | 2005-03-15 → 2004-10-20 (-146d) | 2005-03-15 → 2004-10-20 (-146d) |  | 317d → 422d |  | resources GSTOP Team; GTAG; somes other reviewers → GSTOP Team; GTAG; Reviewers |
| 361 | Consolidate reviewers' inputs | 2005-03-15 → 2004-10-20 (-146d) | 2005-03-15 → 2004-10-20 (-146d) |  | 317d → 422d |  | was named consolidate reviewers inputs |
| 362 | Evaluate Feedback for inclusion in SOP revision | 2005-03-15 → 2004-10-20 (-146d) | 2005-03-15 → 2004-10-20 (-146d) |  | 317d → 422d |  | resources GSTOP Team; Indepdent reviewer → GSTOP Team; Independent Reviewer |
| 363 | Incorporate accepted feedback from reviewers | 2005-03-15 → 2004-10-20 (-146d) | 2005-03-15 → 2004-10-20 (-146d) |  | 317d → 422d |  | resources subteams → GSTOP Subteam(s) |
| 364 | **Agencies' review of Draft SOPs** | 2005-03-15 → 2004-10-20 (-146d) | 2005-03-15 → 2004-10-20 (-146d) |  | 317d → 422d |  |  |
| 365 | Create a cover letter and response process | 2005-03-15 → 2004-10-20 (-146d) | 2005-03-15 → 2004-10-20 (-146d) |  | 317d → 422d |  | was named Create a cover letter, and response process |
| 366 | Review and Validate draft SOP’s | 2005-03-15 → 2004-10-20 (-146d) | 2005-03-15 → 2004-10-20 (-146d) |  | 317d → 422d |  | resources NWCG member agencies → NWCG Member Agencies |
| 367 | Evaluate Feedback for inclusion in SOP revision | 2005-03-15 → 2004-10-20 (-146d) | 2005-03-15 → 2004-10-20 (-146d) |  | 317d → 422d |  |  |
| 368 | Incorporate Feedback from reviewers | 2005-03-15 → 2004-10-20 (-146d) | 2005-03-15 → 2004-10-20 (-146d) |  | 317d → 422d |  |  |
| 369 | Develop GSTOP Change Management Plan | 2005-03-15 → 2004-10-20 (-146d) | 2005-03-15 → 2004-10-20 (-146d) |  | 317d → 422d |  |  |
| 370 | Review GSTOP Change Management Plan | 2005-03-15 → 2004-10-20 (-146d) | 2005-03-15 → 2004-10-20 (-146d) |  | 317d → 422d |  |  |
| 371 | PRELIMINARY GIS SOP’s READY FOR FIELD TESTING | 2005-03-15 → 2004-10-20 (-146d) | 2005-03-15 → 2004-10-20 (-146d) |  | 318d → 423d |  | constraint start no earlier than 2005-01-18 → none |
| 373 | **Incident GIS SOPs Field Test** |  | 2004-10-20 → 2005-12-15 (+421d) | 1d? → 302d? | 422d → 121d |  |  |
| 375 | Develop Questionnaire |  |  |  |  |  | was named develop questionnaire |

| ID | Task | Start | Finish | Duration | Complete | Total float | Other |
| --- | --- | --- | --- | --- | --- | --- | --- |
| 376 | Execute Quality Assurance and Field Test Plan |  |  |  |  |  | resources none → Subteam Lead |
| 377 | Collect written/survey results from the field test |  |  |  |  |  | was named collect written/survey results from the field test |
| 378 | Conduct interviews with GISTs to measure success of Draft SOPs |  |  |  |  |  | was named conduct interviews with GISTs to measure success of Draft SOPs |
| 379 | Conduct interviews with SIT Unit Leaders to measure success of Draft SOPs |  |  |  |  |  | was named conduct interviews with SIT Unit Leaders to measure success of Draft SOPs |
| 381 | Conduct Field Test of GIS SOP Requirements |  |  | 1d? → 0.5d? |  | 422d → 422.5d | was named Ensure requirements are reviewed and tested by business community; resources none → Business Community; Business Lead |
| 385 | **Final Incident GIS SOPs** | 2005-04-01 → 2005-06-03 (+63d) | 2005-04-01 → 2006-06-01 (+426d) | 1d? → 260d? |  | 305d → 1d |  |
| 386 | Analyze feedback on Incident GIS SOPs | 2005-04-01 → 2005-06-03 (+63d) | 2005-04-01 → 2005-06-03 (+63d) |  |  | 305d → 260d |  |
| 387 | Update and finalize Incident GIS SOPs | 2005-04-01 → 2005-06-03 (+63d) | 2005-04-01 → 2005-06-03 (+63d) |  |  | 305d → 260d |  |
| 388 | Deliver Final Incident GIS SOPs to Executive Committee | 2005-04-01 → 2005-06-03 (+63d) | 2005-04-01 → 2005-06-03 (+63d) |  |  | 305d → 260d |  |
| 389 | Deliver Final Incident GIS SOPs to Incident Based Automation Project | 2005-04-01 → 2005-06-03 (+63d) | 2005-04-01 → 2005-06-03 (+63d) |  |  | 305d → 260d |  |
| 395 | Implement GSTOP Project Communication Plan |  |  |  |  |  | was named Communication Plan; resources none → Business Lead |
| 400 | Q1 2005 Executive Briefing | 2005-03-15 → 2005-03-16 A (+1d) | 2005-03-15 → 2005-03-16 A (+1d) |  | 0% → 100% | 305d → none | was named Executive Briefing; constraint start no earlier than 2005-03-15 → none; resources Smclellan → Project Mgr; GTG Exec Comm |
| 402 | **Closeout GSTOP Project** |  |  |  |  |  | was named GSTOP Project Closeout |
| 405 | GSTOP Project Complete |  |  | 1d? → 0d |  |  | was named GSTOP PROJECT TEAM RELEASED |
